Schedule from MS Project, 2026-01-05 to 2026-05-23.
Microsoft

## Calendars

- Стандартный: Mon-Sun 09:00-13:00, 14:00-18:00.

## Schedule

| ID | WBS | Task | Type | Duration | Start | Finish | Predecessors | Total slack | Free slack | Constraint | Work |
| --- | --- | --- | --- | --- | --- | --- | --- | --- | --- | --- | --- |
| 1 | 1 | **КГ3** |  | 139d | 2026-01-05 | 2026-05-23 |  | 0d |  |  | 14452.3h |
| 2 | 1.1 | Поставка оставшегося металла | milestone | 0d | 2026-02-28 | 2026-02-28 |  | 75d | 0d | start no earlier than 2026-02-28 |  |
| 3 | 1.2 | **ОЧЕРЕДЬ 1** |  | 74d | 2026-01-05 | 2026-03-19 |  | 65d |  |  | 2960.48h |
| 4 | 1.2.1 | **Ось 1** |  | 4d | 2026-01-05 | 2026-01-08 |  | 125d |  |  |  |
| 5 | 1.2.1.1 | Поставка материалов | milestone | 0d | 2026-01-05 | 2026-01-05 |  | 139d |  |  |  |
| 6 | 1.2.1.2 | **Колонны** |  | 1d | 2026-01-05 | 2026-01-05 |  | 125d |  |  |  |
| 7 | 1.2.1.2.1 | Монтаж колонн одноэтажных и многоэтажных зданий и крановых эстакад высотой: до 25 м составного сечения массой до 5,0 т |  | 1d | 2026-01-05 | 2026-01-05 |  | 125d | 0d | start no earlier than 2026-01-05 |  |
| 8 | 1.2.1.3 | **Связи горизонт. и вертик.** |  | 1d | 2026-01-06 | 2026-01-06 |  | 125d |  |  |  |
| 9 | 1.2.1.3.1 | Монтаж связей и распорок из одиночных и парных уголков, гнутосварных профилей для пролетов: до 24 м при высоте здания до 25 м |  | 1d | 2026-01-06 | 2026-01-06 | 7 | 125d | 0d | start no earlier than 2026-01-06 |  |
| 10 | 1.2.1.4 | **Установка О-элемента** |  | 1d | 2026-01-07 | 2026-01-07 |  | 125d |  |  |  |
| 11 | 1.2.1.4.1 | Монтаж балок, ригелей перекрытия, покрытия и под установку оборудования многоэтажных зданий при высоте здания: до 25 м |  | 1d | 2026-01-07 | 2026-01-07 | 9 | 125d | 0d | start no earlier than 2026-01-06 |  |
| 12 | 1.2.1.5 | **Стеновой фахверк** |  | 1d | 2026-01-08 | 2026-01-08 |  | 125d |  |  |  |
| 13 | 1.2.1.5.1 | Монтаж фахверка |  | 1d | 2026-01-08 | 2026-01-08 | 11 | 125d | 0d | start no earlier than 2026-01-08 |  |
| 14 | 1.2.2 | **Ось 1-2** |  | 4d | 2026-01-09 | 2026-01-12 |  | 125d |  |  | 350.06h |
| 15 | 1.2.2.1 | **Колонны** |  | 1d | 2026-01-09 | 2026-01-09 |  | 125d |  |  |  |
| 16 | 1.2.2.1.1 | Монтаж колонн одноэтажных и многоэтажных зданий и крановых эстакад высотой: до 25 м составного сечения массой до 5,0 т |  | 1d | 2026-01-09 | 2026-01-09 | 13 | 125d | 0d | finish no earlier than 2026-01-07 |  |
| 17 | 1.2.2.2 | **Балки перекрытий и фермы ФП1** |  | 1d | 2026-01-09 | 2026-01-09 |  | 134d |  |  | 350.06h |
| 18 | 1.2.2.2.1 | Монтаж балок, ригелей перекрытия, покрытия и под установку оборудования многоэтажных зданий при высоте здания: до 25 м |  | 1d | 2026-01-09 | 2026-01-09 | 16SS | 134d | 9d | finish no earlier than 2025-08-28 | 350.06h |
| 19 | 1.2.2.3 | **Связи горизонт. и вертик.** |  | 1d | 2026-01-10 | 2026-01-10 |  | 125d |  |  |  |
| 20 | 1.2.2.3.1 | Монтаж связей и распорок из одиночных и парных уголков, гнутосварных профилей для пролетов: до 24 м при высоте здания до 25 м |  | 1d | 2026-01-10 | 2026-01-10 | 16 | 125d | 0d | start no earlier than 2026-01-10 |  |
| 21 | 1.2.2.4 | **Установка О-элемента** |  | 1d | 2026-01-11 | 2026-01-11 |  | 125d |  |  |  |
| 22 | 1.2.2.4.1 | Монтаж балок, ригелей перекрытия, покрытия и под установку оборудования многоэтажных зданий при высоте здания: до 25 м |  | 1d | 2026-01-11 | 2026-01-11 | 20 | 125d | 0d | start no earlier than 2026-01-07 |  |
| 23 | 1.2.2.5 | **Прогоны покрытия** |  | 1d | 2026-01-12 | 2026-01-12 |  | 125d |  |  |  |
| 24 | 1.2.2.5.1 | Монтаж балок, ригелей перекрытия, покрытия и под установку оборудования многоэтажных зданий при высоте здания: до 25 м |  | 1d | 2026-01-12 | 2026-01-12 | 22 | 125d | 0d | start no earlier than 2026-01-10 |  |

| ID | WBS | Task | Duration | Start | Finish | Predecessors | Total slack | Free slack | Constraint | Work |
| --- | --- | --- | --- | --- | --- | --- | --- | --- | --- | --- |
| 25 | 1.2.2.6 | **Стеновой фахверк** | 1d | 2026-01-11 | 2026-01-11 |  | 132d |  |  |  |
| 26 | 1.2.2.6.1 | Монтаж фахверка | 1d | 2026-01-11 | 2026-01-11 | 20 | 132d |  | start no earlier than 2026-01-09 |  |
| 27 | 1.2.3 | **Ось 2-3** | 4d | 2026-01-13 | 2026-01-16 |  | 125d |  |  | 350.06h |
| 28 | 1.2.3.1 | **Колонны** | 1d | 2026-01-13 | 2026-01-13 |  | 125d |  |  |  |
| 29 | 1.2.3.1.1 | Монтаж колонн одноэтажных и многоэтажных зданий и крановых эстакад высотой: до 25 м составного сечения массой до 5,0 т | 1d | 2026-01-13 | 2026-01-13 | 24 | 125d | 0d | finish no earlier than 2026-01-08 |  |
| 30 | 1.2.3.2 | **Балки перекрытий и фермы ФП1** | 1d | 2026-01-13 | 2026-01-13 |  | 130d |  |  | 350.06h |
| 31 | 1.2.3.2.1 | Монтаж балок, ригелей перекрытия, покрытия и под установку оборудования многоэтажных зданий при высоте здания: до 25 м | 1d | 2026-01-13 | 2026-01-13 | 29SS | 130d | 5d | finish no earlier than 2025-08-28 | 350.06h |
| 32 | 1.2.3.3 | **Связи горизонт. и вертик.** | 1d | 2026-01-14 | 2026-01-14 |  | 125d |  |  |  |
| 33 | 1.2.3.3.1 | Монтаж связей и распорок из одиночных и парных уголков, гнутосварных профилей для пролетов: до 24 м при высоте здания до 25 м | 1d | 2026-01-14 | 2026-01-14 | 29 | 125d | 0d | start no earlier than 2026-01-11 |  |
| 34 | 1.2.3.4 | **Установка О-элемента** | 1d | 2026-01-15 | 2026-01-15 |  | 125d |  |  |  |
| 35 | 1.2.3.4.1 | Монтаж балок, ригелей перекрытия, покрытия и под установку оборудования многоэтажных зданий при высоте здания: до 25 м | 1d | 2026-01-15 | 2026-01-15 | 33 | 125d | 0d | start no earlier than 2026-01-08 |  |
| 36 | 1.2.3.5 | **Прогоны покрытия** | 1d | 2026-01-16 | 2026-01-16 |  | 125d |  |  |  |
| 37 | 1.2.3.5.1 | Монтаж балок, ригелей перекрытия, покрытия и под установку оборудования многоэтажных зданий при высоте здания: до 25 м | 1d | 2026-01-16 | 2026-01-16 | 35 | 125d | 0d | start no earlier than 2026-01-10 |  |
| 38 | 1.2.3.6 | **Стеновой фахверк** | 1d | 2026-01-15 | 2026-01-15 |  | 128d |  |  |  |
| 39 | 1.2.3.6.1 | Монтаж фахверка | 1d | 2026-01-15 | 2026-01-15 | 33 | 128d |  | start no earlier than 2026-01-09 |  |
| 40 | 1.2.4 | **Ось 3-4** | 5d | 2026-01-17 | 2026-01-21 |  | 116d |  |  | 350.06h |
| 41 | 1.2.4.1 | **Колонны** | 1d | 2026-01-17 | 2026-01-17 |  | 125d |  |  |  |
| 42 | 1.2.4.1.1 | Монтаж колонн одноэтажных и многоэтажных зданий и крановых эстакад высотой: до 25 м составного сечения массой до 5,0 т | 1d | 2026-01-17 | 2026-01-17 | 37 | 125d | 0d | finish no earlier than 2026-01-08 |  |
| 43 | 1.2.4.2 | **Балки перекрытий и фермы ФП1** | 1d | 2026-01-18 | 2026-01-18 |  | 125d |  |  | 350.06h |
| 44 | 1.2.4.2.1 | Монтаж балок, ригелей перекрытия, покрытия и под установку оборудования многоэтажных зданий при высоте здания: до 25 м | 1d | 2026-01-18 | 2026-01-18 | 42 | 125d | 0d | finish no earlier than 2025-08-28 | 350.06h |
| 45 | 1.2.4.3 | **Связи горизонт. и вертик.** | 1d | 2026-01-18 | 2026-01-18 |  | 115d |  |  |  |
| 46 | 1.2.4.3.1 | Монтаж связей и распорок из одиночных и парных уголков, гнутосварных профилей для пролетов: до 24 м при высоте здания до 25 м | 1d | 2026-01-18 | 2026-01-18 | 44SS, 31SS, 18SS | 115d | 0d | start no earlier than 2026-01-10 |  |
| 47 | 1.2.4.4 | **Установка О-элемента** | 2d | 2026-01-19 | 2026-01-20 |  | 115d |  |  |  |
| 48 | 1.2.4.4.1 | Монтаж балок, ригелей перекрытия, покрытия и под установку оборудования многоэтажных зданий при высоте здания: до 25 м | 2d | 2026-01-19 | 2026-01-20 | 46 | 115d | 0d | finish no earlier than 2026-01-11 |  |

| ID | WBS | Task | Duration | Start | Finish | Predecessors | Total slack | Free slack | Constraint | Work |
| --- | --- | --- | --- | --- | --- | --- | --- | --- | --- | --- |
| 49 | 1.2.4.5 | **Прогоны покрытия** | 1d | 2026-01-21 | 2026-01-21 |  | 115d |  |  |  |
| 50 | 1.2.4.5.1 | Монтаж балок, ригелей перекрытия, покрытия и под установку оборудования многоэтажных зданий при высоте здания: до 25 м | 1d | 2026-01-21 | 2026-01-21 | 48 | 115d | 4d | finish no earlier than 2026-01-12 |  |
| 51 | 1.2.4.6 | **Стеновой фахверк** | 1d | 2026-01-19 | 2026-01-19 |  | 124d |  |  |  |
| 52 | 1.2.4.6.1 | Монтаж фахверка | 1d | 2026-01-19 | 2026-01-19 | 46 | 124d |  | start no earlier than 2026-01-09 |  |
| 53 | 1.2.5 | **Ось 4-5** | 18d | 2026-01-26 | 2026-02-12 |  | 100d |  |  | 350.06h |
| 54 | 1.2.5.1 | **Колонны** | 1d | 2026-01-26 | 2026-01-26 |  | 111d |  |  |  |
| 55 | 1.2.5.1.1 | Монтаж колонн одноэтажных и многоэтажных зданий и крановых эстакад высотой: до 25 м составного сечения массой до 5,0 т | 1d | 2026-01-26 | 2026-01-26 | 50 | 111d | 3d | start no earlier than 2026-01-26 |  |
| 56 | 1.2.5.2 | **Балки перекрытий и фермы ФП1** | 1d | 2026-01-30 | 2026-01-30 |  | 108d |  |  | 350.06h |
| 57 | 1.2.5.2.1 | Монтаж балок, ригелей перекрытия, покрытия и под установку оборудования многоэтажных зданий при высоте здания: до 25 м | 1d | 2026-01-30 | 2026-01-30 | 55 | 108d | 0d | start no earlier than 2026-01-30 | 350.06h |
| 58 | 1.2.5.3 | **Связи горизонт. и вертик.** | 1d | 2026-01-30 | 2026-01-30 |  | 108d |  |  |  |
| 59 | 1.2.5.3.1 | Монтаж связей и распорок из одиночных и парных уголков, гнутосварных профилей для пролетов: до 24 м при высоте здания до 25 м | 1d | 2026-01-30 | 2026-01-30 | 57SS | 108d | 0d | start no earlier than 2026-01-10 |  |
| 60 | 1.2.5.4 | **Установка С-элемента** | 2d | 2026-02-10 | 2026-02-11 |  | 98d |  |  |  |
| 61 | 1.2.5.4.1 | Монтаж балок, ригелей перекрытия, покрытия и под установку оборудования многоэтажных зданий при высоте здания: до 25 м | 2d | 2026-02-10 | 2026-02-11 | 59 | 98d | 0d | start no earlier than 2026-02-10 |  |
| 62 | 1.2.5.5 | **Прогоны покрытия** | 1d | 2026-02-12 | 2026-02-12 |  | 98d |  |  |  |
| 63 | 1.2.5.5.1 | Монтаж балок, ригелей перекрытия, покрытия и под установку оборудования многоэтажных зданий при высоте здания: до 25 м | 1d | 2026-02-12 | 2026-02-12 | 61 | 98d | 0d | finish no earlier than 2026-01-12 |  |
| 64 | 1.2.5.6 | **Стеновой фахверк** | 1d | 2026-01-31 | 2026-01-31 |  | 112d |  |  |  |
| 65 | 1.2.5.6.1 | Монтаж фахверка | 1d | 2026-01-31 | 2026-01-31 | 59 | 112d |  | start no earlier than 2026-01-09 |  |
| 66 | 1.2.6 | **Ось 5-6** | 5d | 2026-02-13 | 2026-02-17 |  | 69d |  |  | 350.06h |
| 67 | 1.2.6.1 | **Колонны** | 1d | 2026-02-13 | 2026-02-13 |  | 98d |  |  |  |
| 68 | 1.2.6.1.1 | Монтаж колонн одноэтажных и многоэтажных зданий и крановых эстакад высотой: до 25 м составного сечения массой до 5,0 т | 1d | 2026-02-13 | 2026-02-13 | 63 | 98d | 0d | finish no earlier than 2026-01-08 |  |
| 69 | 1.2.6.2 | **Балки перекрытий и фермы ФП1** | 1d | 2026-02-14 | 2026-02-14 |  | 98d |  |  | 350.06h |
| 70 | 1.2.6.2.1 | Монтаж балок, ригелей перекрытия, покрытия и под установку оборудования многоэтажных зданий при высоте здания: до 25 м | 1d | 2026-02-14 | 2026-02-14 | 68 | 98d | 0d | finish no earlier than 2025-08-28 | 350.06h |
| 71 | 1.2.6.3 | **Связи горизонт. и вертик.** | 1d | 2026-02-14 | 2026-02-14 |  | 68d |  |  |  |
| 72 | 1.2.6.3.1 | Монтаж связей и распорок из одиночных и парных уголков, гнутосварных профилей для пролетов: до 24 м при высоте здания до 25 м | 1d | 2026-02-14 | 2026-02-14 | 70SS | 68d | 0d | start no earlier than 2026-01-10 |  |

| ID | WBS | Task | Duration | Start | Finish | Predecessors | Total slack | Free slack | Constraint | Work |
| --- | --- | --- | --- | --- | --- | --- | --- | --- | --- | --- |
| 73 | 1.2.6.4 | **Установка С-элемента** | 2d | 2026-02-15 | 2026-02-16 |  | 68d |  |  |  |
| 74 | 1.2.6.4.1 | Монтаж балок, ригелей перекрытия, покрытия и под установку оборудования многоэтажных зданий при высоте здания: до 25 м | 2d | 2026-02-15 | 2026-02-16 | 72 | 68d | 0d | finish no earlier than 2026-01-11 |  |
| 75 | 1.2.6.5 | **Прогоны покрытия** | 1d | 2026-02-17 | 2026-02-17 |  | 68d |  |  |  |
| 76 | 1.2.6.5.1 | Монтаж балок, ригелей перекрытия, покрытия и под установку оборудования многоэтажных зданий при высоте здания: до 25 м | 1d | 2026-02-17 | 2026-02-17 | 74 | 68d | 0d | finish no earlier than 2026-01-12 |  |
| 77 | 1.2.7 | Монтаж площадок с настилом и ограждением из листовой, рифленой, просечной и круглой стали | 20d | 2026-02-18 | 2026-03-09 | 76 | 68d | 0d |  |  |
| 78 | 1.2.8 | **Ось 6-7** | 5d | 2026-02-18 | 2026-02-22 |  | 89d |  |  | 350.06h |
| 79 | 1.2.8.1 | **Колонны** | 1d | 2026-02-18 | 2026-02-18 |  | 93d |  |  |  |
| 80 | 1.2.8.1.1 | Монтаж колонн одноэтажных и многоэтажных зданий и крановых эстакад высотой: до 25 м составного сечения массой до 5,0 т | 1d | 2026-02-18 | 2026-02-18 | 76 | 93d | 0d | finish no earlier than 2026-01-08 |  |
| 81 | 1.2.8.2 | **Балки перекрытий и фермы ФП1** | 1d | 2026-02-19 | 2026-02-19 |  | 93d |  |  | 350.06h |
| 82 | 1.2.8.2.1 | Монтаж балок, ригелей перекрытия, покрытия и под установку оборудования многоэтажных зданий при высоте здания: до 25 м | 1d | 2026-02-19 | 2026-02-19 | 80 | 93d | 0d | finish no earlier than 2025-08-28 | 350.06h |
| 83 | 1.2.8.3 | **Связи горизонт. и вертик.** | 1d | 2026-02-19 | 2026-02-19 |  | 88d |  |  |  |
| 84 | 1.2.8.3.1 | Монтаж связей и распорок из одиночных и парных уголков, гнутосварных профилей для пролетов: до 24 м при высоте здания до 25 м | 1d | 2026-02-19 | 2026-02-19 | 82SS | 88d | 0d | start no earlier than 2026-01-10 |  |
| 85 | 1.2.8.4 | **Установка С-элемента** | 2d | 2026-02-20 | 2026-02-21 |  | 88d |  |  |  |
| 86 | 1.2.8.4.1 | Монтаж балок, ригелей перекрытия, покрытия и под установку оборудования многоэтажных зданий при высоте здания: до 25 м | 2d | 2026-02-20 | 2026-02-21 | 84 | 88d | 0d | finish no earlier than 2026-01-11 |  |
| 87 | 1.2.8.5 | **Прогоны покрытия** | 1d | 2026-02-22 | 2026-02-22 |  | 88d |  |  |  |
| 88 | 1.2.8.5.1 | Монтаж балок, ригелей перекрытия, покрытия и под установку оборудования многоэтажных зданий при высоте здания: до 25 м | 1d | 2026-02-22 | 2026-02-22 | 86 | 88d | 0d | finish no earlier than 2026-01-12 |  |
| 89 | 1.2.8.6 | **Стеновой фахверк** | 1d | 2026-02-22 | 2026-02-22 |  | 90d |  |  |  |
| 90 | 1.2.8.6.1 | Монтаж фахверка | 1d | 2026-02-22 | 2026-02-22 | 86 | 90d |  | start no earlier than 2026-01-09 |  |
| 91 | 1.2.9 | **Ось 7-8** | 5d | 2026-02-23 | 2026-02-27 |  | 84d |  |  | 350.06h |
| 92 | 1.2.9.1 | **Колонны** | 1d | 2026-02-23 | 2026-02-23 |  | 88d |  |  |  |
| 93 | 1.2.9.1.1 | Монтаж колонн одноэтажных и многоэтажных зданий и крановых эстакад высотой: до 25 м составного сечения массой до 5,0 т | 1d | 2026-02-23 | 2026-02-23 | 88 | 88d | 0d | finish no earlier than 2026-01-08 |  |
| 94 | 1.2.9.2 | **Балки перекрытий и фермы ФП1** | 1d | 2026-02-24 | 2026-02-24 |  | 88d |  |  | 350.06h |
| 95 | 1.2.9.2.1 | Монтаж балок, ригелей перекрытия, покрытия и под установку оборудования многоэтажных зданий при высоте здания: до 25 м | 1d | 2026-02-24 | 2026-02-24 | 93 | 88d | 0d | finish no earlier than 2025-08-28 | 350.06h |
| 96 | 1.2.9.3 | **Связи горизонт. и вертик.** | 1d | 2026-02-24 | 2026-02-24 |  | 83d |  |  |  |
| 97 | 1.2.9.3.1 | Монтаж связей и распорок из одиночных и парных уголков, гнутосварных профилей для пролетов: до 24 м при высоте здания до 25 м | 1d | 2026-02-24 | 2026-02-24 | 95SS | 83d | 0d | start no earlier than 2026-01-10 |  |

| ID | WBS | Task | Duration | Start | Finish | Predecessors | Total slack | Free slack | Constraint | Work |
| --- | --- | --- | --- | --- | --- | --- | --- | --- | --- | --- |
| 98 | 1.2.9.4 | **Установка С-элемента** | 2d | 2026-02-25 | 2026-02-26 |  | 83d |  |  |  |
| 99 | 1.2.9.4.1 | Монтаж балок, ригелей перекрытия, покрытия и под установку оборудования многоэтажных зданий при высоте здания: до 25 м | 2d | 2026-02-25 | 2026-02-26 | 97 | 83d | 0d | finish no earlier than 2026-01-11 |  |
| 100 | 1.2.9.5 | **Прогоны покрытия** | 1d | 2026-02-27 | 2026-02-27 |  | 83d |  |  |  |
| 101 | 1.2.9.5.1 | Монтаж балок, ригелей перекрытия, покрытия и под установку оборудования многоэтажных зданий при высоте здания: до 25 м | 1d | 2026-02-27 | 2026-02-27 | 99 | 83d | 0d | finish no earlier than 2026-01-12 |  |
| 102 | 1.2.9.6 | **Стеновой фахверк** | 1d | 2026-02-27 | 2026-02-27 |  | 85d |  |  |  |
| 103 | 1.2.9.6.1 | Монтаж фахверка | 1d | 2026-02-27 | 2026-02-27 | 99 | 85d |  | start no earlier than 2026-01-09 |  |
| 104 | 1.2.10 | **Ось 8-9** | 5d | 2026-02-28 | 2026-03-04 |  | 66d |  |  | 350.06h |
| 105 | 1.2.10.1 | **Колонны** | 1d | 2026-02-28 | 2026-02-28 |  | 83d |  |  |  |
| 106 | 1.2.10.1.1 | Монтаж колонн одноэтажных и многоэтажных зданий и крановых эстакад высотой: до 25 м составного сечения массой до 5,0 т | 1d | 2026-02-28 | 2026-02-28 | 101 | 83d | 0d | finish no earlier than 2026-01-08 |  |
| 107 | 1.2.10.2 | **Балки перекрытий и фермы ФП1** | 1d | 2026-03-01 | 2026-03-01 |  | 83d |  |  | 350.06h |
| 108 | 1.2.10.2.1 | Монтаж балок, ригелей перекрытия, покрытия и под установку оборудования многоэтажных зданий при высоте здания: до 25 м | 1d | 2026-03-01 | 2026-03-01 | 106 | 83d | 0d | finish no earlier than 2025-08-28 | 350.06h |
| 109 | 1.2.10.3 | **Связи горизонт. и вертик.** | 1d | 2026-03-01 | 2026-03-01 |  | 65d |  |  |  |
| 110 | 1.2.10.3.1 | Монтаж связей и распорок из одиночных и парных уголков, гнутосварных профилей для пролетов: до 24 м при высоте здания до 25 м | 1d | 2026-03-01 | 2026-03-01 | 108SS | 65d | 0d | start no earlier than 2026-01-10 |  |
| 111 | 1.2.10.4 | **Установка С-элемента** | 2d | 2026-03-02 | 2026-03-03 |  | 65d |  |  |  |
| 112 | 1.2.10.4.1 | Монтаж балок, ригелей перекрытия, покрытия и под установку оборудования многоэтажных зданий при высоте здания: до 25 м | 2d | 2026-03-02 | 2026-03-03 | 110 | 65d | 0d | finish no earlier than 2026-01-11 |  |
| 113 | 1.2.10.5 | **Прогоны покрытия** | 1d | 2026-03-04 | 2026-03-04 |  | 65d |  |  |  |
| 114 | 1.2.10.5.1 | Монтаж балок, ригелей перекрытия, покрытия и под установку оборудования многоэтажных зданий при высоте здания: до 25 м | 1d | 2026-03-04 | 2026-03-04 | 112 | 65d | 0d | finish no earlier than 2026-01-12 |  |
| 115 | 1.2.10.6 | **Стеновой фахверк** | 1d | 2026-03-04 | 2026-03-04 |  | 65d |  |  |  |
| 116 | 1.2.10.6.1 | Монтаж фахверка | 1d | 2026-03-04 | 2026-03-04 | 112 | 65d | 0d | start no earlier than 2026-01-09 |  |
| 117 | 1.2.11 | **Настил** | 15d | 2026-03-05 | 2026-03-19 |  | 65d |  |  | 160h |
| 118 | 1.2.11.1 | Монтаж кровельного покрытия: из профилированного листа при высоте здания до 25 м + огрождение | 15d | 2026-03-05 | 2026-03-19 | 114 | 65d |  | start no earlier than 2025-08-27 | 80h |
| 119 | 1.2.11.2 | Монтаж ограждающих конструкций стен: из профилированного листа при высоте здания до 30 м (10% на подрезку) | 15d | 2026-03-05 | 2026-03-19 | 116 | 65d |  | start no earlier than 2026-01-09 | 80h |
| 120 | 1.2.11.3 | Монтаж лестниц | 7d | 2026-03-10 | 2026-03-16 | 77 | 68d |  |  |  |
| 121 | 1.2.12 | **Опоры под оборудование ЗД1-ЗД3** | 7d | 2026-03-10 | 2026-03-16 |  | 68d |  |  |  |
| 122 | 1.2.12.1 | Монтаж металлоконструкций постаментов под технологическое оборудование | 7d | 2026-03-10 | 2026-03-16 | 77 | 68d |  | start no earlier than 2025-09-01 |  |

| ID | WBS | Task | Duration | Start | Finish | Predecessors | Total slack | Free slack | Constraint | Work |
| --- | --- | --- | --- | --- | --- | --- | --- | --- | --- | --- |
| 123 | 1.3 | **ОЧЕРЕДЬ 2** | 48d | 2026-03-05 | 2026-04-21 |  | 32d |  |  | 2960.48h |
| 124 | 1.3.1 | **Ось 9-10** | 5d | 2026-03-05 | 2026-03-09 |  | 75d |  |  | 350.06h |
| 125 | 1.3.1.1 | **Колонны** | 1d | 2026-03-05 | 2026-03-05 |  | 78d |  |  |  |
| 126 | 1.3.1.1.1 | Монтаж колонн одноэтажных и многоэтажных зданий и крановых эстакад высотой: до 25 м составного сечения массой до 5,0 т | 1d | 2026-03-05 | 2026-03-05 | 114 | 78d | 0d | finish no earlier than 2026-01-08 |  |
| 127 | 1.3.1.2 | **Балки перекрытий и фермы ФП1** | 1d | 2026-03-06 | 2026-03-06 |  | 78d |  |  | 350.06h |
| 128 | 1.3.1.2.1 | Монтаж балок, ригелей перекрытия, покрытия и под установку оборудования многоэтажных зданий при высоте здания: до 25 м | 1d | 2026-03-06 | 2026-03-06 | 126 | 78d | 0d | finish no earlier than 2025-08-28 | 350.06h |
| 129 | 1.3.1.3 | **Связи горизонт. и вертик.** | 1d | 2026-03-06 | 2026-03-06 |  | 74d |  |  |  |
| 130 | 1.3.1.3.1 | Монтаж связей и распорок из одиночных и парных уголков, гнутосварных профилей для пролетов: до 24 м при высоте здания до 25 м | 1d | 2026-03-06 | 2026-03-06 | 128SS | 74d | 0d | start no earlier than 2026-01-10 |  |
| 131 | 1.3.1.4 | **Установка С-элемента** | 2d | 2026-03-07 | 2026-03-08 |  | 74d | 0d |  |  |
| 132 | 1.3.1.4.1 | Монтаж балок, ригелей перекрытия, покрытия и под установку оборудования многоэтажных зданий при высоте здания: до 25 м | 2d | 2026-03-07 | 2026-03-08 | 130 | 74d | 0d | finish no earlier than 2026-01-11 |  |
| 133 | 1.3.1.5 | **Прогоны покрытия** | 1d | 2026-03-09 | 2026-03-09 |  | 74d |  |  |  |
| 134 | 1.3.1.5.1 | Монтаж балок, ригелей перекрытия, покрытия и под установку оборудования многоэтажных зданий при высоте здания: до 25 м | 1d | 2026-03-09 | 2026-03-09 | 132 | 74d | 0d | finish no earlier than 2026-01-12 |  |
| 135 | 1.3.1.6 | **Стеновой фахверк** | 1d | 2026-03-09 | 2026-03-09 |  | 75d |  |  |  |
| 136 | 1.3.1.6.1 | Монтаж фахверка | 1d | 2026-03-09 | 2026-03-09 | 131 | 75d |  | start no earlier than 2026-01-09 |  |
| 137 | 1.3.2 | **Ось 10-11** | 4d | 2026-03-10 | 2026-03-13 |  | 70d |  |  | 350.06h |
| 138 | 1.3.2.1 | **Колонны** | 1d | 2026-03-10 | 2026-03-10 |  | 74d |  |  |  |
| 139 | 1.3.2.1.1 | Монтаж колонн одноэтажных и многоэтажных зданий и крановых эстакад высотой: до 25 м составного сечения массой до 5,0 т | 1d | 2026-03-10 | 2026-03-10 | 134 | 74d | 0d | finish no earlier than 2026-01-08 |  |
| 140 | 1.3.2.2 | **Балки перекрытий и фермы ФП1** | 1d | 2026-03-10 | 2026-03-10 |  | 74d |  |  | 350.06h |
| 141 | 1.3.2.2.1 | Монтаж балок, ригелей перекрытия, покрытия и под установку оборудования многоэтажных зданий при высоте здания: до 25 м | 1d | 2026-03-10 | 2026-03-10 | 139SS | 74d | 0d | finish no earlier than 2025-08-28 | 350.06h |
| 142 | 1.3.2.3 | **Связи горизонт. и вертик.** | 1d | 2026-03-10 | 2026-03-10 |  | 70d |  |  |  |
| 143 | 1.3.2.3.1 | Монтаж связей и распорок из одиночных и парных уголков, гнутосварных профилей для пролетов: до 24 м при высоте здания до 25 м | 1d | 2026-03-10 | 2026-03-10 | 141SS | 70d | 0d | start no earlier than 2026-01-10 |  |
| 144 | 1.3.2.4 | **Установка С-элемента** | 2d | 2026-03-11 | 2026-03-12 |  | 70d |  |  |  |
| 145 | 1.3.2.4.1 | Монтаж балок, ригелей перекрытия, покрытия и под установку оборудования многоэтажных зданий при высоте здания: до 25 м | 2d | 2026-03-11 | 2026-03-12 | 143 | 70d | 0d | finish no earlier than 2026-01-11 |  |
| 146 | 1.3.2.5 | **Прогоны покрытия** | 1d | 2026-03-13 | 2026-03-13 |  | 70d |  |  |  |
| 147 | 1.3.2.5.1 | Монтаж балок, ригелей перекрытия, покрытия и под установку оборудования многоэтажных зданий при высоте здания: до 25 м | 1d | 2026-03-13 | 2026-03-13 | 145 | 70d | 0d | finish no earlier than 2026-01-12 |  |

| ID | WBS | Task | Duration | Start | Finish | Predecessors | Total slack | Free slack | Constraint | Work |
| --- | --- | --- | --- | --- | --- | --- | --- | --- | --- | --- |
| 148 | 1.3.2.6 | **Стеновой фахверк** | 1d | 2026-03-13 | 2026-03-13 |  | 71d |  |  |  |
| 149 | 1.3.2.6.1 | Монтаж фахверка | 1d | 2026-03-13 | 2026-03-13 | 145 | 71d |  | start no earlier than 2026-01-09 |  |
| 150 | 1.3.3 | **Ось 11-12** | 4d | 2026-03-14 | 2026-03-17 |  | 66d |  |  | 350.06h |
| 151 | 1.3.3.1 | **Колонны** | 1d | 2026-03-14 | 2026-03-14 |  | 70d |  |  |  |
| 152 | 1.3.3.1.1 | Монтаж колонн одноэтажных и многоэтажных зданий и крановых эстакад высотой: до 25 м составного сечения массой до 5,0 т | 1d | 2026-03-14 | 2026-03-14 | 147 | 70d | 0d | finish no earlier than 2026-01-08 |  |
| 153 | 1.3.3.2 | **Балки перекрытий и фермы ФП1** | 1d | 2026-03-14 | 2026-03-14 |  | 70d |  |  | 350.06h |
| 154 | 1.3.3.2.1 | Монтаж балок, ригелей перекрытия, покрытия и под установку оборудования многоэтажных зданий при высоте здания: до 25 м | 1d | 2026-03-14 | 2026-03-14 | 152SS | 70d | 0d | finish no earlier than 2025-08-28 | 350.06h |
| 155 | 1.3.3.3 | **Связи горизонт. и вертик.** | 1d | 2026-03-14 | 2026-03-14 |  | 66d |  |  |  |
| 156 | 1.3.3.3.1 | Монтаж связей и распорок из одиночных и парных уголков, гнутосварных профилей для пролетов: до 24 м при высоте здания до 25 м | 1d | 2026-03-14 | 2026-03-14 | 154SS | 66d | 0d | start no earlier than 2026-01-10 |  |
| 157 | 1.3.3.4 | **Установка С-элемента** | 2d | 2026-03-15 | 2026-03-16 |  | 66d |  |  |  |
| 158 | 1.3.3.4.1 | Монтаж балок, ригелей перекрытия, покрытия и под установку оборудования многоэтажных зданий при высоте здания: до 25 м | 2d | 2026-03-15 | 2026-03-16 | 156 | 66d | 0d | finish no earlier than 2026-01-11 |  |
| 159 | 1.3.3.5 | **Прогоны покрытия** | 1d | 2026-03-17 | 2026-03-17 |  | 66d |  |  |  |
| 160 | 1.3.3.5.1 | Монтаж балок, ригелей перекрытия, покрытия и под установку оборудования многоэтажных зданий при высоте здания: до 25 м | 1d | 2026-03-17 | 2026-03-17 | 158 | 66d | 0d | finish no earlier than 2026-01-12 |  |
| 161 | 1.3.3.6 | **Стеновой фахверк** | 1d | 2026-03-17 | 2026-03-17 |  | 67d |  |  |  |
| 162 | 1.3.3.6.1 | Монтаж фахверка | 1d | 2026-03-17 | 2026-03-17 | 158 | 67d |  | start no earlier than 2026-01-09 |  |
| 163 | 1.3.4 | **Ось 12-13** | 4d | 2026-03-18 | 2026-03-21 |  | 62d |  |  | 350.06h |
| 164 | 1.3.4.1 | **Колонны** | 1d | 2026-03-18 | 2026-03-18 |  | 66d |  |  |  |
| 165 | 1.3.4.1.1 | Монтаж колонн одноэтажных и многоэтажных зданий и крановых эстакад высотой: до 25 м составного сечения массой до 5,0 т | 1d | 2026-03-18 | 2026-03-18 | 160 | 66d | 0d | finish no earlier than 2026-01-08 |  |
| 166 | 1.3.4.2 | **Балки перекрытий и фермы ФП1** | 1d | 2026-03-18 | 2026-03-18 |  | 66d |  |  | 350.06h |
| 167 | 1.3.4.2.1 | Монтаж балок, ригелей перекрытия, покрытия и под установку оборудования многоэтажных зданий при высоте здания: до 25 м | 1d | 2026-03-18 | 2026-03-18 | 165SS | 66d | 0d | finish no earlier than 2025-08-28 | 350.06h |
| 168 | 1.3.4.3 | **Связи горизонт. и вертик.** | 1d | 2026-03-18 | 2026-03-18 |  | 62d |  |  |  |
| 169 | 1.3.4.3.1 | Монтаж связей и распорок из одиночных и парных уголков, гнутосварных профилей для пролетов: до 24 м при высоте здания до 25 м | 1d | 2026-03-18 | 2026-03-18 | 167SS | 62d | 0d | start no earlier than 2026-01-10 |  |
| 170 | 1.3.4.4 | **Установка С-элемента** | 2d | 2026-03-19 | 2026-03-20 |  | 62d |  |  |  |
| 171 | 1.3.4.4.1 | Монтаж балок, ригелей перекрытия, покрытия и под установку оборудования многоэтажных зданий при высоте здания: до 25 м | 2d | 2026-03-19 | 2026-03-20 | 169 | 62d | 0d | finish no earlier than 2026-01-11 |  |

| ID | WBS | Task | Duration | Start | Finish | Predecessors | Total slack | Free slack | Constraint | Work |
| --- | --- | --- | --- | --- | --- | --- | --- | --- | --- | --- |
| 172 | 1.3.4.5 | **Прогоны покрытия** | 1d | 2026-03-21 | 2026-03-21 |  | 62d |  |  |  |
| 173 | 1.3.4.5.1 | Монтаж балок, ригелей перекрытия, покрытия и под установку оборудования многоэтажных зданий при высоте здания: до 25 м | 1d | 2026-03-21 | 2026-03-21 | 171 | 62d | 0d | finish no earlier than 2026-01-12 |  |
| 174 | 1.3.4.6 | **Стеновой фахверк** | 1d | 2026-03-21 | 2026-03-21 |  | 63d |  |  |  |
| 175 | 1.3.4.6.1 | Монтаж фахверка | 1d | 2026-03-21 | 2026-03-21 | 171 | 63d |  | start no earlier than 2026-01-09 |  |
| 176 | 1.3.5 | **Ось 13-14** | 5d | 2026-03-22 | 2026-03-26 |  | 32d |  |  | 350.06h |
| 177 | 1.3.5.1 | **Колонны** | 1d | 2026-03-22 | 2026-03-22 |  | 62d |  |  |  |
| 178 | 1.3.5.1.1 | Монтаж колонн одноэтажных и многоэтажных зданий и крановых эстакад высотой: до 25 м составного сечения массой до 5,0 т | 1d | 2026-03-22 | 2026-03-22 | 173 | 62d | 0d | finish no earlier than 2026-01-08 |  |
| 179 | 1.3.5.2 | **Балки перекрытий и фермы ФП1** | 1d | 2026-03-22 | 2026-03-22 |  | 62d |  |  | 350.06h |
| 180 | 1.3.5.2.1 | Монтаж балок, ригелей перекрытия, покрытия и под установку оборудования многоэтажных зданий при высоте здания: до 25 м | 1d | 2026-03-22 | 2026-03-22 | 178SS | 62d | 0d | finish no earlier than 2025-08-28 | 350.06h |
| 181 | 1.3.5.3 | **Связи горизонт. и вертик.** | 1d | 2026-03-22 | 2026-03-22 |  | 32d |  |  |  |
| 182 | 1.3.5.3.1 | Монтаж связей и распорок из одиночных и парных уголков, гнутосварных профилей для пролетов: до 24 м при высоте здания до 25 м | 1d | 2026-03-22 | 2026-03-22 | 180SS | 32d | 0d | start no earlier than 2026-01-10 |  |
| 183 | 1.3.5.4 | **Установка С-элемента** | 2d | 2026-03-23 | 2026-03-24 |  | 32d |  |  |  |
| 184 | 1.3.5.4.1 | Монтаж балок, ригелей перекрытия, покрытия и под установку оборудования многоэтажных зданий при высоте здания: до 25 м | 2d | 2026-03-23 | 2026-03-24 | 182 | 32d | 0d | finish no earlier than 2026-01-11 |  |
| 185 | 1.3.5.5 | **Прогоны покрытия** | 1d | 2026-03-25 | 2026-03-25 |  | 32d |  |  |  |
| 186 | 1.3.5.5.1 | Монтаж балок, ригелей перекрытия, покрытия и под установку оборудования многоэтажных зданий при высоте здания: до 25 м | 1d | 2026-03-25 | 2026-03-25 | 184 | 32d | 0d | finish no earlier than 2026-01-12 |  |
| 187 | 1.3.5.6 | **Стеновой фахверк** | 1d | 2026-03-26 | 2026-03-26 |  | 58d |  |  |  |
| 188 | 1.3.5.6.1 | Монтаж фахверка | 1d | 2026-03-26 | 2026-03-26 | 186 | 58d |  | start no earlier than 2026-01-09 |  |
| 189 | 1.3.6 | Монтаж площадок с настилом и ограждением из листовой, рифленой, просечной и круглой стали | 20d | 2026-03-26 | 2026-04-14 | 186 | 32d | 0d |  |  |
| 190 | 1.3.7 | **Ось 14-15** | 4d | 2026-03-26 | 2026-03-29 |  | 54d |  |  | 350.06h |
| 191 | 1.3.7.1 | **Колонны** | 1d | 2026-03-26 | 2026-03-26 |  | 58d |  |  |  |
| 192 | 1.3.7.1.1 | Монтаж колонн одноэтажных и многоэтажных зданий и крановых эстакад высотой: до 25 м составного сечения массой до 5,0 т | 1d | 2026-03-26 | 2026-03-26 | 186 | 58d | 0d | finish no earlier than 2026-01-08 |  |
| 193 | 1.3.7.2 | **Балки перекрытий и фермы ФП1** | 1d | 2026-03-26 | 2026-03-26 |  | 58d |  |  | 350.06h |
| 194 | 1.3.7.2.1 | Монтаж балок, ригелей перекрытия, покрытия и под установку оборудования многоэтажных зданий при высоте здания: до 25 м | 1d | 2026-03-26 | 2026-03-26 | 192SS | 58d | 0d | finish no earlier than 2025-08-28 | 350.06h |
| 195 | 1.3.7.3 | **Связи горизонт. и вертик.** | 1d | 2026-03-26 | 2026-03-26 |  | 54d |  |  |  |
| 196 | 1.3.7.3.1 | Монтаж связей и распорок из одиночных и парных уголков, гнутосварных профилей для пролетов: до 24 м при высоте здания до 25 м | 1d | 2026-03-26 | 2026-03-26 | 194SS | 54d | 0d | start no earlier than 2026-01-10 |  |

| ID | WBS | Task | Duration | Start | Finish | Predecessors | Total slack | Free slack | Constraint | Work |
| --- | --- | --- | --- | --- | --- | --- | --- | --- | --- | --- |
| 197 | 1.3.7.4 | **Установка С-элемента** | 2d | 2026-03-27 | 2026-03-28 |  | 54d |  |  |  |
| 198 | 1.3.7.4.1 | Монтаж балок, ригелей перекрытия, покрытия и под установку оборудования многоэтажных зданий при высоте здания: до 25 м | 2d | 2026-03-27 | 2026-03-28 | 196 | 54d | 0d | finish no earlier than 2026-01-11 |  |
| 199 | 1.3.7.5 | **Прогоны покрытия** | 1d | 2026-03-29 | 2026-03-29 |  | 54d |  |  |  |
| 200 | 1.3.7.5.1 | Монтаж балок, ригелей перекрытия, покрытия и под установку оборудования многоэтажных зданий при высоте здания: до 25 м | 1d | 2026-03-29 | 2026-03-29 | 198 | 54d | 0d | finish no earlier than 2026-01-12 |  |
| 201 | 1.3.7.6 | **Стеновой фахверк** | 1d | 2026-03-29 | 2026-03-29 |  | 55d |  |  |  |
| 202 | 1.3.7.6.1 | Монтаж фахверка | 1d | 2026-03-29 | 2026-03-29 | 198 | 55d |  | start no earlier than 2026-01-09 |  |
| 203 | 1.3.8 | **Ось 15-16** | 4d | 2026-03-30 | 2026-04-02 |  | 50d |  |  | 350.06h |
| 204 | 1.3.8.1 | **Колонны** | 1d | 2026-03-30 | 2026-03-30 |  | 54d |  |  |  |
| 205 | 1.3.8.1.1 | Монтаж колонн одноэтажных и многоэтажных зданий и крановых эстакад высотой: до 25 м составного сечения массой до 5,0 т | 1d | 2026-03-30 | 2026-03-30 | 200 | 54d | 0d | finish no earlier than 2026-01-08 |  |
| 206 | 1.3.8.2 | **Балки перекрытий и фермы ФП1** | 1d | 2026-03-30 | 2026-03-30 |  | 54d |  |  | 350.06h |
| 207 | 1.3.8.2.1 | Монтаж балок, ригелей перекрытия, покрытия и под установку оборудования многоэтажных зданий при высоте здания: до 25 м | 1d | 2026-03-30 | 2026-03-30 | 205SS | 54d | 0d | finish no earlier than 2025-08-28 | 350.06h |
| 208 | 1.3.8.3 | **Связи горизонт. и вертик.** | 1d | 2026-03-30 | 2026-03-30 |  | 50d |  |  |  |
| 209 | 1.3.8.3.1 | Монтаж связей и распорок из одиночных и парных уголков, гнутосварных профилей для пролетов: до 24 м при высоте здания до 25 м | 1d | 2026-03-30 | 2026-03-30 | 207SS | 50d | 0d | start no earlier than 2026-01-10 |  |
| 210 | 1.3.8.4 | **Установка С-элемента** | 2d | 2026-03-31 | 2026-04-01 |  | 50d |  |  |  |
| 211 | 1.3.8.4.1 | Монтаж балок, ригелей перекрытия, покрытия и под установку оборудования многоэтажных зданий при высоте здания: до 25 м | 2d | 2026-03-31 | 2026-04-01 | 209 | 50d | 0d | finish no earlier than 2026-01-11 |  |
| 212 | 1.3.8.5 | **Прогоны покрытия** | 1d | 2026-04-02 | 2026-04-02 |  | 50d |  |  |  |
| 213 | 1.3.8.5.1 | Монтаж балок, ригелей перекрытия, покрытия и под установку оборудования многоэтажных зданий при высоте здания: до 25 м | 1d | 2026-04-02 | 2026-04-02 | 211 | 50d | 0d | finish no earlier than 2026-01-12 |  |
| 214 | 1.3.8.6 | **Стеновой фахверк** | 1d | 2026-04-02 | 2026-04-02 |  | 51d |  |  |  |
| 215 | 1.3.8.6.1 | Монтаж фахверка | 1d | 2026-04-02 | 2026-04-02 | 211 | 51d |  | start no earlier than 2026-01-09 |  |
| 216 | 1.3.9 | **Ось 16-17** | 4d | 2026-04-03 | 2026-04-06 |  | 32d |  |  | 350.06h |
| 217 | 1.3.9.1 | **Колонны** | 1d | 2026-04-03 | 2026-04-03 |  | 50d |  |  |  |
| 218 | 1.3.9.1.1 | Монтаж колонн одноэтажных и многоэтажных зданий и крановых эстакад высотой: до 25 м составного сечения массой до 5,0 т | 1d | 2026-04-03 | 2026-04-03 | 213 | 50d | 0d | finish no earlier than 2026-01-08 |  |
| 219 | 1.3.9.2 | **Балки перекрытий и фермы ФП1** | 1d | 2026-04-03 | 2026-04-03 |  | 50d |  |  | 350.06h |
| 220 | 1.3.9.2.1 | Монтаж балок, ригелей перекрытия, покрытия и под установку оборудования многоэтажных зданий при высоте здания: до 25 м | 1d | 2026-04-03 | 2026-04-03 | 218SS | 50d | 0d | finish no earlier than 2025-08-28 | 350.06h |

| ID | WBS | Task | Duration | Start | Finish | Predecessors | Total slack | Free slack | Constraint | Work |
| --- | --- | --- | --- | --- | --- | --- | --- | --- | --- | --- |
| 221 | 1.3.9.3 | **Связи горизонт. и вертик.** | 1d | 2026-04-03 | 2026-04-03 |  | 32d |  |  |  |
| 222 | 1.3.9.3.1 | Монтаж связей и распорок из одиночных и парных уголков, гнутосварных профилей для пролетов: до 24 м при высоте здания до 25 м | 1d | 2026-04-03 | 2026-04-03 | 220SS | 32d | 0d | start no earlier than 2026-01-10 |  |
| 223 | 1.3.9.4 | **Установка С-элемента** | 2d | 2026-04-04 | 2026-04-05 |  | 32d |  |  |  |
| 224 | 1.3.9.4.1 | Монтаж балок, ригелей перекрытия, покрытия и под установку оборудования многоэтажных зданий при высоте здания: до 25 м | 2d | 2026-04-04 | 2026-04-05 | 222 | 32d | 0d | finish no earlier than 2026-01-11 |  |
| 225 | 1.3.9.5 | **Прогоны покрытия** | 1d | 2026-04-06 | 2026-04-06 |  | 32d |  |  |  |
| 226 | 1.3.9.5.1 | Монтаж балок, ригелей перекрытия, покрытия и под установку оборудования многоэтажных зданий при высоте здания: до 25 м | 1d | 2026-04-06 | 2026-04-06 | 224 | 32d | 0d | finish no earlier than 2026-01-12 |  |
| 227 | 1.3.9.6 | **Стеновой фахверк** | 1d | 2026-04-06 | 2026-04-06 |  | 32d |  |  |  |
| 228 | 1.3.9.6.1 | Монтаж фахверка | 1d | 2026-04-06 | 2026-04-06 | 224 | 32d | 0d | start no earlier than 2026-01-09 |  |
| 229 | 1.3.10 | **Настил** | 15d | 2026-04-07 | 2026-04-21 |  | 32d |  |  | 160h |
| 230 | 1.3.10.1 | Монтаж кровельного покрытия: из профилированного листа при высоте здания до 25 м | 15d | 2026-04-07 | 2026-04-21 | 226 | 32d |  | start no earlier than 2025-08-27 | 80h |
| 231 | 1.3.10.2 | Монтаж ограждающих конструкций стен: из профилированного листа при высоте здания до 30 м (10% на подрезку) | 15d | 2026-04-07 | 2026-04-21 | 228 | 32d |  | start no earlier than 2026-01-09 | 80h |
| 232 | 1.3.10.3 | Монтаж лестниц | 7d | 2026-04-15 | 2026-04-21 | 189 | 32d |  |  |  |
| 233 | 1.3.11 | **Опоры под оборудование ЗД1-ЗД3** | 7d | 2026-04-15 | 2026-04-21 |  | 32d |  |  |  |
| 234 | 1.3.11.1 | Монтаж металлоконструкций постаментов под технологическое оборудование | 7d | 2026-04-15 | 2026-04-21 | 189 | 32d |  | start no earlier than 2025-09-01 |  |
| 235 | 1.4 | **ОЧЕРЕДЬ 3** | 47d | 2026-04-07 | 2026-05-23 |  | 0d |  |  | 2960.48h |
| 236 | 1.4.1 | **Ось 17-18** | 4d | 2026-04-07 | 2026-04-10 |  | 42d |  |  | 350.06h |
| 237 | 1.4.1.1 | **Колонны** | 1d | 2026-04-07 | 2026-04-07 |  | 46d |  |  |  |
| 238 | 1.4.1.1.1 | Монтаж колонн одноэтажных и многоэтажных зданий и крановых эстакад высотой: до 25 м составного сечения массой до 5,0 т | 1d | 2026-04-07 | 2026-04-07 | 226 | 46d | 0d | finish no earlier than 2026-01-08 |  |
| 239 | 1.4.1.2 | **Балки перекрытий и фермы ФП1** | 1d | 2026-04-07 | 2026-04-07 |  | 46d |  |  | 350.06h |
| 240 | 1.4.1.2.1 | Монтаж балок, ригелей перекрытия, покрытия и под установку оборудования многоэтажных зданий при высоте здания: до 25 м | 1d | 2026-04-07 | 2026-04-07 | 238SS | 46d | 0d | finish no earlier than 2025-08-28 | 350.06h |
| 241 | 1.4.1.3 | **Связи горизонт. и вертик.** | 1d | 2026-04-07 | 2026-04-07 |  | 42d |  |  |  |
| 242 | 1.4.1.3.1 | Монтаж связей и распорок из одиночных и парных уголков, гнутосварных профилей для пролетов: до 24 м при высоте здания до 25 м | 1d | 2026-04-07 | 2026-04-07 | 240SS | 42d | 0d | start no earlier than 2026-01-10 |  |
| 243 | 1.4.1.4 | **Установка С-элемента** | 2d | 2026-04-08 | 2026-04-09 |  | 42d |  |  |  |
| 244 | 1.4.1.4.1 | Монтаж балок, ригелей перекрытия, покрытия и под установку оборудования многоэтажных зданий при высоте здания: до 25 м | 2d | 2026-04-08 | 2026-04-09 | 242 | 42d | 0d | finish no earlier than 2026-01-11 |  |

| ID | WBS | Task | Duration | Start | Finish | Predecessors | Total slack | Free slack | Constraint | Work |
| --- | --- | --- | --- | --- | --- | --- | --- | --- | --- | --- |
| 245 | 1.4.1.5 | **Прогоны покрытия** | 1d | 2026-04-10 | 2026-04-10 |  | 42d |  |  |  |
| 246 | 1.4.1.5.1 | Монтаж балок, ригелей перекрытия, покрытия и под установку оборудования многоэтажных зданий при высоте здания: до 25 м | 1d | 2026-04-10 | 2026-04-10 | 244 | 42d | 0d | finish no earlier than 2026-01-12 |  |
| 247 | 1.4.1.6 | **Стеновой фахверк** | 1d | 2026-04-10 | 2026-04-10 |  | 43d |  |  |  |
| 248 | 1.4.1.6.1 | Монтаж фахверка | 1d | 2026-04-10 | 2026-04-10 | 244 | 43d |  | start no earlier than 2026-01-09 |  |
| 249 | 1.4.2 | **Ось 18-19** | 4d | 2026-04-11 | 2026-04-14 |  | 38d |  |  | 350.06h |
| 250 | 1.4.2.1 | **Колонны** | 1d | 2026-04-11 | 2026-04-11 |  | 42d |  |  |  |
| 251 | 1.4.2.1.1 | Монтаж колонн одноэтажных и многоэтажных зданий и крановых эстакад высотой: до 25 м составного сечения массой до 5,0 т | 1d | 2026-04-11 | 2026-04-11 | 246 | 42d | 0d | finish no earlier than 2026-01-08 |  |
| 252 | 1.4.2.2 | **Балки перекрытий и фермы ФП1** | 1d | 2026-04-11 | 2026-04-11 |  | 42d |  |  | 350.06h |
| 253 | 1.4.2.2.1 | Монтаж балок, ригелей перекрытия, покрытия и под установку оборудования многоэтажных зданий при высоте здания: до 25 м | 1d | 2026-04-11 | 2026-04-11 | 251SS | 42d | 0d | finish no earlier than 2025-08-28 | 350.06h |
| 254 | 1.4.2.3 | **Связи горизонт. и вертик.** | 1d | 2026-04-11 | 2026-04-11 |  | 38d |  |  |  |
| 255 | 1.4.2.3.1 | Монтаж связей и распорок из одиночных и парных уголков, гнутосварных профилей для пролетов: до 24 м при высоте здания до 25 м | 1d | 2026-04-11 | 2026-04-11 | 253SS | 38d | 0d | start no earlier than 2026-01-10 |  |
| 256 | 1.4.2.4 | **Установка С-элемента** | 2d | 2026-04-12 | 2026-04-13 |  | 38d |  |  |  |
| 257 | 1.4.2.4.1 | Монтаж балок, ригелей перекрытия, покрытия и под установку оборудования многоэтажных зданий при высоте здания: до 25 м | 2d | 2026-04-12 | 2026-04-13 | 255 | 38d | 0d | finish no earlier than 2026-01-11 |  |
| 258 | 1.4.2.5 | **Прогоны покрытия** | 1d | 2026-04-14 | 2026-04-14 |  | 38d |  |  |  |
| 259 | 1.4.2.5.1 | Монтаж балок, ригелей перекрытия, покрытия и под установку оборудования многоэтажных зданий при высоте здания: до 25 м | 1d | 2026-04-14 | 2026-04-14 | 257 | 38d | 0d | finish no earlier than 2026-01-12 |  |
| 260 | 1.4.2.6 | **Стеновой фахверк** | 1d | 2026-04-14 | 2026-04-14 |  | 39d |  |  |  |
| 261 | 1.4.2.6.1 | Монтаж фахверка | 1d | 2026-04-14 | 2026-04-14 | 257 | 39d |  | start no earlier than 2026-01-09 |  |
| 262 | 1.4.3 | **Ось 19-20** | 4d | 2026-04-15 | 2026-04-18 |  | 34d |  |  | 350.06h |
| 263 | 1.4.3.1 | **Колонны** | 1d | 2026-04-15 | 2026-04-15 |  | 38d |  |  |  |
| 264 | 1.4.3.1.1 | Монтаж колонн одноэтажных и многоэтажных зданий и крановых эстакад высотой: до 25 м составного сечения массой до 5,0 т | 1d | 2026-04-15 | 2026-04-15 | 259 | 38d | 0d | finish no earlier than 2026-01-08 |  |
| 265 | 1.4.3.2 | **Балки перекрытий и фермы ФП1** | 1d | 2026-04-15 | 2026-04-15 |  | 38d |  |  | 350.06h |
| 266 | 1.4.3.2.1 | Монтаж балок, ригелей перекрытия, покрытия и под установку оборудования многоэтажных зданий при высоте здания: до 25 м | 1d | 2026-04-15 | 2026-04-15 | 264SS | 38d | 0d | finish no earlier than 2025-08-28 | 350.06h |
| 267 | 1.4.3.3 | **Связи горизонт. и вертик.** | 1d | 2026-04-15 | 2026-04-15 |  | 34d |  |  |  |
| 268 | 1.4.3.3.1 | Монтаж связей и распорок из одиночных и парных уголков, гнутосварных профилей для пролетов: до 24 м при высоте здания до 25 м | 1d | 2026-04-15 | 2026-04-15 | 266SS | 34d | 0d | start no earlier than 2026-01-10 |  |

| ID | WBS | Task | Duration | Start | Finish | Predecessors | Total slack | Free slack | Constraint | Work |
| --- | --- | --- | --- | --- | --- | --- | --- | --- | --- | --- |
| 269 | 1.4.3.4 | **Установка С-элемента** | 2d | 2026-04-16 | 2026-04-17 |  | 34d |  |  |  |
| 270 | 1.4.3.4.1 | Монтаж балок, ригелей перекрытия, покрытия и под установку оборудования многоэтажных зданий при высоте здания: до 25 м | 2d | 2026-04-16 | 2026-04-17 | 268 | 34d | 0d | finish no earlier than 2026-01-11 |  |
| 271 | 1.4.3.5 | **Прогоны покрытия** | 1d | 2026-04-18 | 2026-04-18 |  | 34d |  |  |  |
| 272 | 1.4.3.5.1 | Монтаж балок, ригелей перекрытия, покрытия и под установку оборудования многоэтажных зданий при высоте здания: до 25 м | 1d | 2026-04-18 | 2026-04-18 | 270 | 34d | 0d | finish no earlier than 2026-01-12 |  |
| 273 | 1.4.3.6 | **Стеновой фахверк** | 1d | 2026-04-18 | 2026-04-18 |  | 35d |  |  |  |
| 274 | 1.4.3.6.1 | Монтаж фахверка | 1d | 2026-04-18 | 2026-04-18 | 270 | 35d |  | start no earlier than 2026-01-09 |  |
| 275 | 1.4.4 | **Ось 20-21** | 4d | 2026-04-19 | 2026-04-22 |  | 30d |  |  | 350.06h |
| 276 | 1.4.4.1 | **Колонны** | 1d | 2026-04-19 | 2026-04-19 |  | 34d |  |  |  |
| 277 | 1.4.4.1.1 | Монтаж колонн одноэтажных и многоэтажных зданий и крановых эстакад высотой: до 25 м составного сечения массой до 5,0 т | 1d | 2026-04-19 | 2026-04-19 | 272 | 34d | 0d | finish no earlier than 2026-01-08 |  |
| 278 | 1.4.4.2 | **Балки перекрытий и фермы ФП1** | 1d | 2026-04-19 | 2026-04-19 |  | 34d |  |  | 350.06h |
| 279 | 1.4.4.2.1 | Монтаж балок, ригелей перекрытия, покрытия и под установку оборудования многоэтажных зданий при высоте здания: до 25 м | 1d | 2026-04-19 | 2026-04-19 | 277SS | 34d | 0d | finish no earlier than 2025-08-28 | 350.06h |
| 280 | 1.4.4.3 | **Связи горизонт. и вертик.** | 1d | 2026-04-19 | 2026-04-19 |  | 30d |  |  |  |
| 281 | 1.4.4.3.1 | Монтаж связей и распорок из одиночных и парных уголков, гнутосварных профилей для пролетов: до 24 м при высоте здания до 25 м | 1d | 2026-04-19 | 2026-04-19 | 279SS | 30d | 0d | start no earlier than 2026-01-10 |  |
| 282 | 1.4.4.4 | **Установка С-элемента** | 2d | 2026-04-20 | 2026-04-21 |  | 30d |  |  |  |
| 283 | 1.4.4.4.1 | Монтаж балок, ригелей перекрытия, покрытия и под установку оборудования многоэтажных зданий при высоте здания: до 25 м | 2d | 2026-04-20 | 2026-04-21 | 281 | 30d | 0d | finish no earlier than 2026-01-11 |  |
| 284 | 1.4.4.5 | **Прогоны покрытия** | 1d | 2026-04-22 | 2026-04-22 |  | 30d |  |  |  |
| 285 | 1.4.4.5.1 | Монтаж балок, ригелей перекрытия, покрытия и под установку оборудования многоэтажных зданий при высоте здания: до 25 м | 1d | 2026-04-22 | 2026-04-22 | 283 | 30d | 0d | finish no earlier than 2026-01-12 |  |
| 286 | 1.4.4.6 | **Стеновой фахверк** | 1d | 2026-04-20 | 2026-04-20 |  | 33d |  |  |  |
| 287 | 1.4.4.6.1 | Монтаж фахверка | 1d | 2026-04-20 | 2026-04-20 | 281 | 33d |  | start no earlier than 2026-01-09 |  |
| 288 | 1.4.5 | **Ось 21-22** | 4d | 2026-04-23 | 2026-04-26 |  | 0d |  |  | 350.06h |
| 289 | 1.4.5.1 | **Колонны** | 1d | 2026-04-23 | 2026-04-23 |  | 30d |  |  |  |
| 290 | 1.4.5.1.1 | Монтаж колонн одноэтажных и многоэтажных зданий и крановых эстакад высотой: до 25 м составного сечения массой до 5,0 т | 1d | 2026-04-23 | 2026-04-23 | 285 | 30d | 0d | finish no earlier than 2026-01-08 |  |
| 291 | 1.4.5.2 | **Балки перекрытий и фермы ФП1** | 1d | 2026-04-23 | 2026-04-23 |  | 30d |  |  | 350.06h |
| 292 | 1.4.5.2.1 | Монтаж балок, ригелей перекрытия, покрытия и под установку оборудования многоэтажных зданий при высоте здания: до 25 м | 1d | 2026-04-23 | 2026-04-23 | 290SS | 30d | 0d | finish no earlier than 2025-08-28 | 350.06h |

| ID | WBS | Task | Duration | Start | Finish | Predecessors | Total slack | Free slack | Constraint | Work |
| --- | --- | --- | --- | --- | --- | --- | --- | --- | --- | --- |
| 293 | 1.4.5.3 | **Связи горизонт. и вертик.** | 1d | 2026-04-23 | 2026-04-23 |  | 0d |  |  |  |
| 294 | 1.4.5.3.1 | Монтаж связей и распорок из одиночных и парных уголков, гнутосварных профилей для пролетов: до 24 м при высоте здания до 25 м | 1d | 2026-04-23 | 2026-04-23 | 292SS | 0d |  | start no earlier than 2026-01-10 |  |
| 295 | 1.4.5.4 | **Установка С-элемента** | 2d | 2026-04-24 | 2026-04-25 |  | 0d |  |  |  |
| 296 | 1.4.5.4.1 | Монтаж балок, ригелей перекрытия, покрытия и под установку оборудования многоэтажных зданий при высоте здания: до 25 м | 2d | 2026-04-24 | 2026-04-25 | 294 | 0d |  | finish no earlier than 2026-01-11 |  |
| 297 | 1.4.5.5 | **Прогоны покрытия** | 1d | 2026-04-26 | 2026-04-26 |  | 0d |  |  |  |
| 298 | 1.4.5.5.1 | Монтаж балок, ригелей перекрытия, покрытия и под установку оборудования многоэтажных зданий при высоте здания: до 25 м | 1d | 2026-04-26 | 2026-04-26 | 296 | 0d |  | finish no earlier than 2026-01-12 |  |
| 299 | 1.4.5.6 | **Стеновой фахверк** | 1d | 2026-04-26 | 2026-04-26 |  | 27d |  |  |  |
| 300 | 1.4.5.6.1 | Монтаж фахверка | 1d | 2026-04-26 | 2026-04-26 | 296 | 27d |  | start no earlier than 2026-01-09 |  |
| 301 | 1.4.6 | Монтаж площадок с настилом и ограждением из листовой, рифленой, просечной и круглой стали | 20d | 2026-04-27 | 2026-05-16 | 298 | 0d |  |  |  |
| 302 | 1.4.7 | **Ось 22-23** | 4d | 2026-04-27 | 2026-04-30 |  | 22d |  |  | 350.06h |
| 303 | 1.4.7.1 | **Колонны** | 1d | 2026-04-27 | 2026-04-27 |  | 26d |  |  |  |
| 304 | 1.4.7.1.1 | Монтаж колонн одноэтажных и многоэтажных зданий и крановых эстакад высотой: до 25 м составного сечения массой до 5,0 т | 1d | 2026-04-27 | 2026-04-27 | 298 | 26d | 0d | finish no earlier than 2026-01-08 |  |
| 305 | 1.4.7.2 | **Балки перекрытий и фермы ФП1** | 1d | 2026-04-27 | 2026-04-27 |  | 26d |  |  | 350.06h |
| 306 | 1.4.7.2.1 | Монтаж балок, ригелей перекрытия, покрытия и под установку оборудования многоэтажных зданий при высоте здания: до 25 м | 1d | 2026-04-27 | 2026-04-27 | 304SS | 26d | 0d | finish no earlier than 2025-08-28 | 350.06h |
| 307 | 1.4.7.3 | **Связи горизонт. и вертик.** | 1d | 2026-04-27 | 2026-04-27 |  | 22d |  |  |  |
| 308 | 1.4.7.3.1 | Монтаж связей и распорок из одиночных и парных уголков, гнутосварных профилей для пролетов: до 24 м при высоте здания до 25 м | 1d | 2026-04-27 | 2026-04-27 | 306SS | 22d | 0d | start no earlier than 2026-01-10 |  |
| 309 | 1.4.7.4 | **Установка С-элемента** | 2d | 2026-04-28 | 2026-04-29 |  | 22d |  |  |  |
| 310 | 1.4.7.4.1 | Монтаж балок, ригелей перекрытия, покрытия и под установку оборудования многоэтажных зданий при высоте здания: до 25 м | 2d | 2026-04-28 | 2026-04-29 | 308 | 22d | 0d | finish no earlier than 2026-01-11 |  |
| 311 | 1.4.7.5 | **Прогоны покрытия** | 1d | 2026-04-30 | 2026-04-30 |  | 22d |  |  |  |
| 312 | 1.4.7.5.1 | Монтаж балок, ригелей перекрытия, покрытия и под установку оборудования многоэтажных зданий при высоте здания: до 25 м | 1d | 2026-04-30 | 2026-04-30 | 310 | 22d | 0d | finish no earlier than 2026-01-12 |  |
| 313 | 1.4.7.6 | **Стеновой фахверк** | 1d | 2026-04-30 | 2026-04-30 |  | 23d |  |  |  |
| 314 | 1.4.7.6.1 | Монтаж фахверка | 1d | 2026-04-30 | 2026-04-30 | 310 | 23d |  | start no earlier than 2026-01-09 |  |
| 315 | 1.4.8 | **Ось 23-24** | 4d | 2026-05-01 | 2026-05-04 |  | 19d |  |  | 350.06h |
| 316 | 1.4.8.1 | **Колонны** | 1d | 2026-05-01 | 2026-05-01 |  | 22d |  |  |  |
| 317 | 1.4.8.1.1 | Монтаж колонн одноэтажных и многоэтажных зданий и крановых эстакад высотой: до 25 м составного сечения массой до 5,0 т | 1d | 2026-05-01 | 2026-05-01 | 312 | 22d | 0d | finish no earlier than 2026-01-08 |  |

| ID | WBS | Task | Duration | Start | Finish | Predecessors | Total slack | Free slack | Constraint | Work |
| --- | --- | --- | --- | --- | --- | --- | --- | --- | --- | --- |
| 318 | 1.4.8.2 | **Балки перекрытий и фермы ФП1** | 1d | 2026-05-01 | 2026-05-01 |  | 22d |  |  | 350.06h |
| 319 | 1.4.8.2.1 | Монтаж балок, ригелей перекрытия, покрытия и под установку оборудования многоэтажных зданий при высоте здания: до 25 м | 1d | 2026-05-01 | 2026-05-01 | 317SS | 22d | 0d | finish no earlier than 2025-08-28 | 350.06h |
| 320 | 1.4.8.3 | **Связи горизонт. и вертик.** | 1d | 2026-05-01 | 2026-05-01 |  | 19d |  |  |  |
| 321 | 1.4.8.3.1 | Монтаж связей и распорок из одиночных и парных уголков, гнутосварных профилей для пролетов: до 24 м при высоте здания до 25 м | 1d | 2026-05-01 | 2026-05-01 | 319SS | 19d | 0d | start no earlier than 2026-01-10 |  |
| 322 | 1.4.8.4 | **Установка С-элемента** | 2d | 2026-05-02 | 2026-05-03 |  | 19d |  |  |  |
| 323 | 1.4.8.4.1 | Монтаж балок, ригелей перекрытия, покрытия и под установку оборудования многоэтажных зданий при высоте здания: до 25 м | 2d | 2026-05-02 | 2026-05-03 | 321 | 19d | 0d | finish no earlier than 2026-01-11 |  |
| 324 | 1.4.8.5 | **Прогоны покрытия** | 1d | 2026-05-04 | 2026-05-04 |  | 19d |  |  |  |
| 325 | 1.4.8.5.1 | Монтаж балок, ригелей перекрытия, покрытия и под установку оборудования многоэтажных зданий при высоте здания: до 25 м | 1d | 2026-05-04 | 2026-05-04 | 323 | 19d |  | finish no earlier than 2026-01-12 |  |
| 326 | 1.4.8.6 | **Стеновой фахверк** | 1d | 2026-05-04 | 2026-05-04 |  | 19d |  |  |  |
| 327 | 1.4.8.6.1 | Монтаж фахверка | 1d | 2026-05-04 | 2026-05-04 | 323 | 19d |  | start no earlier than 2026-01-09 |  |
| 328 | 1.4.9 | **Ось 24-25** | 4d | 2026-05-01 | 2026-05-04 |  | 4d |  |  | 350.06h |
| 329 | 1.4.9.1 | **Колонны** | 1d | 2026-05-01 | 2026-05-01 |  | 22d |  |  |  |
| 330 | 1.4.9.1.1 | Монтаж колонн одноэтажных и многоэтажных зданий и крановых эстакад высотой: до 25 м составного сечения массой до 5,0 т | 1d | 2026-05-01 | 2026-05-01 | 312 | 22d | 0d | finish no earlier than 2026-01-08 |  |
| 331 | 1.4.9.2 | **Балки перекрытий и фермы ФП1** | 1d | 2026-05-01 | 2026-05-01 |  | 22d |  |  | 350.06h |
| 332 | 1.4.9.2.1 | Монтаж балок, ригелей перекрытия, покрытия и под установку оборудования многоэтажных зданий при высоте здания: до 25 м | 1d | 2026-05-01 | 2026-05-01 | 330SS | 22d | 0d | finish no earlier than 2025-08-28 | 350.06h |
| 333 | 1.4.9.3 | **Связи горизонт. и вертик.** | 1d | 2026-05-01 | 2026-05-01 |  | 4d |  |  |  |
| 334 | 1.4.9.3.1 | Монтаж связей и распорок из одиночных и парных уголков, гнутосварных профилей для пролетов: до 24 м при высоте здания до 25 м | 1d | 2026-05-01 | 2026-05-01 | 332SS | 4d | 0d | start no earlier than 2026-01-10 |  |
| 335 | 1.4.9.4 | **Установка С-элемента** | 2d | 2026-05-02 | 2026-05-03 |  | 4d |  |  |  |
| 336 | 1.4.9.4.1 | Монтаж балок, ригелей перекрытия, покрытия и под установку оборудования многоэтажных зданий при высоте здания: до 25 м | 2d | 2026-05-02 | 2026-05-03 | 334 | 4d | 0d | finish no earlier than 2026-01-11 |  |
| 337 | 1.4.9.5 | **Прогоны покрытия** | 1d | 2026-05-04 | 2026-05-04 |  | 4d |  |  |  |
| 338 | 1.4.9.5.1 | Монтаж балок, ригелей перекрытия, покрытия и под установку оборудования многоэтажных зданий при высоте здания: до 25 м | 1d | 2026-05-04 | 2026-05-04 | 336 | 4d | 0d | finish no earlier than 2026-01-12 |  |
| 339 | 1.4.9.6 | **Стеновой фахверк** | 1d | 2026-05-04 | 2026-05-04 |  | 4d |  |  |  |
| 340 | 1.4.9.6.1 | Монтаж фахверка | 1d | 2026-05-04 | 2026-05-04 | 336 | 4d | 0d | start no earlier than 2026-01-09 |  |
| 341 | 1.4.10 | **Настил** | 19d | 2026-05-05 | 2026-05-23 |  | 0d |  |  | 160h |
| 342 | 1.4.10.1 | Монтаж кровельного покрытия: из профилированного листа при высоте здания до 25 м | 15d | 2026-05-05 | 2026-05-19 | 338 | 4d |  | start no earlier than 2025-08-27 | 80h |
| 343 | 1.4.10.2 | Монтаж ограждающих конструкций стен: из профилированного листа при высоте здания до 30 м (10% на подрезку) | 15d | 2026-05-05 | 2026-05-19 | 340 | 4d |  | start no earlier than 2026-01-09 | 80h |
| 344 | 1.4.10.3 | Монтаж лестниц | 7d | 2026-05-17 | 2026-05-23 | 301 | 0d |  |  |  |

| ID | WBS | Task | Duration | Start | Finish | Predecessors | Total slack | Free slack | Constraint | Work |
| --- | --- | --- | --- | --- | --- | --- | --- | --- | --- | --- |
| 345 | 1.4.11 | **Опоры под оборудование ЗД1-ЗД3** | 7d | 2026-05-17 | 2026-05-23 |  | 0d |  |  |  |
| 346 | 1.4.11.1 | Монтаж металлоконструкций постаментов под технологическое оборудование | 7d | 2026-05-17 | 2026-05-23 | 301 | 0d |  | start no earlier than 2025-09-01 |  |
| 347 | 1.5 | **ОЧЕРЕДЬ 5** | 47d | 2026-03-09 | 2026-04-24 |  | 29d |  |  | 2610.42h |
| 348 | 1.5.1 | **Ось 40-41** | 4d | 2026-03-09 | 2026-03-12 |  | 71d |  |  | 350.06h |
| 349 | 1.5.1.1 | **Колонны** | 1d | 2026-03-09 | 2026-03-09 |  | 75d |  |  |  |
| 350 | 1.5.1.1.1 | Монтаж колонн одноэтажных и многоэтажных зданий и крановых эстакад высотой: до 25 м составного сечения массой до 5,0 т | 1d | 2026-03-09 | 2026-03-09 | 2SS+9d | 75d | 0d | finish no earlier than 2026-01-08 |  |
| 351 | 1.5.1.2 | **Балки перекрытий и фермы ФП1** | 1d | 2026-03-09 | 2026-03-09 |  | 75d |  |  | 350.06h |
| 352 | 1.5.1.2.1 | Монтаж балок, ригелей перекрытия, покрытия и под установку оборудования многоэтажных зданий при высоте здания: до 25 м | 1d | 2026-03-09 | 2026-03-09 | 350SS | 75d | 0d | finish no earlier than 2025-08-28 | 350.06h |
| 353 | 1.5.1.3 | **Связи горизонт. и вертик.** | 1d | 2026-03-09 | 2026-03-09 |  | 71d |  |  |  |
| 354 | 1.5.1.3.1 | Монтаж связей и распорок из одиночных и парных уголков, гнутосварных профилей для пролетов: до 24 м при высоте здания до 25 м | 1d | 2026-03-09 | 2026-03-09 | 352SS | 71d | 0d | start no earlier than 2026-01-10 |  |
| 355 | 1.5.1.4 | **Установка С-элемента** | 2d | 2026-03-10 | 2026-03-11 |  | 71d |  |  |  |
| 356 | 1.5.1.4.1 | Монтаж балок, ригелей перекрытия, покрытия и под установку оборудования многоэтажных зданий при высоте здания: до 25 м | 2d | 2026-03-10 | 2026-03-11 | 354 | 71d | 0d | finish no earlier than 2026-01-11 |  |
| 357 | 1.5.1.5 | **Прогоны покрытия** | 1d | 2026-03-12 | 2026-03-12 |  | 71d |  |  |  |
| 358 | 1.5.1.5.1 | Монтаж балок, ригелей перекрытия, покрытия и под установку оборудования многоэтажных зданий при высоте здания: до 25 м | 1d | 2026-03-12 | 2026-03-12 | 356 | 71d | 0d | finish no earlier than 2026-01-12 |  |
| 359 | 1.5.1.6 | **Стеновой фахверк** | 1d | 2026-03-12 | 2026-03-12 |  | 72d |  |  |  |
| 360 | 1.5.1.6.1 | Монтаж фахверка | 1d | 2026-03-12 | 2026-03-12 | 356 | 72d |  | start no earlier than 2026-01-09 |  |
| 361 | 1.5.2 | **Ось 39-40** | 4d | 2026-03-13 | 2026-03-16 |  | 67d |  |  | 350.06h |
| 362 | 1.5.2.1 | **Колонны** | 1d | 2026-03-13 | 2026-03-13 |  | 71d |  |  |  |
| 363 | 1.5.2.1.1 | Монтаж колонн одноэтажных и многоэтажных зданий и крановых эстакад высотой: до 25 м составного сечения массой до 5,0 т | 1d | 2026-03-13 | 2026-03-13 | 358 | 71d | 0d | finish no earlier than 2026-01-08 |  |
| 364 | 1.5.2.2 | **Балки перекрытий и фермы ФП1** | 1d | 2026-03-13 | 2026-03-13 |  | 71d |  |  | 350.06h |
| 365 | 1.5.2.2.1 | Монтаж балок, ригелей перекрытия, покрытия и под установку оборудования многоэтажных зданий при высоте здания: до 25 м | 1d | 2026-03-13 | 2026-03-13 | 363SS | 71d | 0d | finish no earlier than 2025-08-28 | 350.06h |
| 366 | 1.5.2.3 | **Связи горизонт. и вертик.** | 1d | 2026-03-13 | 2026-03-13 |  | 67d |  |  |  |
| 367 | 1.5.2.3.1 | Монтаж связей и распорок из одиночных и парных уголков, гнутосварных профилей для пролетов: до 24 м при высоте здания до 25 м | 1d | 2026-03-13 | 2026-03-13 | 365SS | 67d | 0d | start no earlier than 2026-01-10 |  |
| 368 | 1.5.2.4 | **Установка С-элемента** | 2d | 2026-03-14 | 2026-03-15 |  | 67d |  |  |  |
| 369 | 1.5.2.4.1 | Монтаж балок, ригелей перекрытия, покрытия и под установку оборудования многоэтажных зданий при высоте здания: до 25 м | 2d | 2026-03-14 | 2026-03-15 | 367 | 67d | 0d | finish no earlier than 2026-01-11 |  |

| ID | WBS | Task | Duration | Start | Finish | Predecessors | Total slack | Free slack | Constraint | Work |
| --- | --- | --- | --- | --- | --- | --- | --- | --- | --- | --- |
| 370 | 1.5.2.5 | **Прогоны покрытия** | 1d | 2026-03-16 | 2026-03-16 |  | 67d |  |  |  |
| 371 | 1.5.2.5.1 | Монтаж балок, ригелей перекрытия, покрытия и под установку оборудования многоэтажных зданий при высоте здания: до 25 м | 1d | 2026-03-16 | 2026-03-16 | 369 | 67d | 0d | finish no earlier than 2026-01-12 |  |
| 372 | 1.5.2.6 | **Стеновой фахверк** | 1d | 2026-03-16 | 2026-03-16 |  | 68d |  |  |  |
| 373 | 1.5.2.6.1 | Монтаж фахверка | 1d | 2026-03-16 | 2026-03-16 | 369 | 68d |  | start no earlier than 2026-01-09 |  |
| 374 | 1.5.3 | **Ось 38-39** | 4d | 2026-03-17 | 2026-03-20 |  | 63d |  |  | 350.06h |
| 375 | 1.5.3.1 | **Колонны** | 1d | 2026-03-17 | 2026-03-17 |  | 67d |  |  |  |
| 376 | 1.5.3.1.1 | Монтаж колонн одноэтажных и многоэтажных зданий и крановых эстакад высотой: до 25 м составного сечения массой до 5,0 т | 1d | 2026-03-17 | 2026-03-17 | 371 | 67d | 0d | finish no earlier than 2026-01-08 |  |
| 377 | 1.5.3.2 | **Балки перекрытий и фермы ФП1** | 1d | 2026-03-17 | 2026-03-17 |  | 67d |  |  | 350.06h |
| 378 | 1.5.3.2.1 | Монтаж балок, ригелей перекрытия, покрытия и под установку оборудования многоэтажных зданий при высоте здания: до 25 м | 1d | 2026-03-17 | 2026-03-17 | 376SS | 67d | 0d | finish no earlier than 2025-08-28 | 350.06h |
| 379 | 1.5.3.3 | **Связи горизонт. и вертик.** | 1d | 2026-03-17 | 2026-03-17 |  | 63d |  |  |  |
| 380 | 1.5.3.3.1 | Монтаж связей и распорок из одиночных и парных уголков, гнутосварных профилей для пролетов: до 24 м при высоте здания до 25 м | 1d | 2026-03-17 | 2026-03-17 | 378SS | 63d | 0d | start no earlier than 2026-01-10 |  |
| 381 | 1.5.3.4 | **Установка С-элемента** | 2d | 2026-03-18 | 2026-03-19 |  | 63d |  |  |  |
| 382 | 1.5.3.4.1 | Монтаж балок, ригелей перекрытия, покрытия и под установку оборудования многоэтажных зданий при высоте здания: до 25 м | 2d | 2026-03-18 | 2026-03-19 | 380 | 63d | 0d | finish no earlier than 2026-01-11 |  |
| 383 | 1.5.3.5 | **Прогоны покрытия** | 1d | 2026-03-20 | 2026-03-20 |  | 63d |  |  |  |
| 384 | 1.5.3.5.1 | Монтаж балок, ригелей перекрытия, покрытия и под установку оборудования многоэтажных зданий при высоте здания: до 25 м | 1d | 2026-03-20 | 2026-03-20 | 382 | 63d | 0d | finish no earlier than 2026-01-12 |  |
| 385 | 1.5.3.6 | **Стеновой фахверк** | 1d | 2026-03-20 | 2026-03-20 |  | 64d |  |  |  |
| 386 | 1.5.3.6.1 | Монтаж фахверка | 1d | 2026-03-20 | 2026-03-20 | 382 | 64d |  | start no earlier than 2026-01-09 |  |
| 387 | 1.5.4 | **Ось 37-38** | 4d | 2026-03-21 | 2026-03-24 |  | 59d |  |  | 350.06h |
| 388 | 1.5.4.1 | **Колонны** | 1d | 2026-03-21 | 2026-03-21 |  | 63d |  |  |  |
| 389 | 1.5.4.1.1 | Монтаж колонн одноэтажных и многоэтажных зданий и крановых эстакад высотой: до 25 м составного сечения массой до 5,0 т | 1d | 2026-03-21 | 2026-03-21 | 384 | 63d | 0d | finish no earlier than 2026-01-08 |  |
| 390 | 1.5.4.2 | **Балки перекрытий и фермы ФП1** | 1d | 2026-03-21 | 2026-03-21 |  | 63d |  |  | 350.06h |
| 391 | 1.5.4.2.1 | Монтаж балок, ригелей перекрытия, покрытия и под установку оборудования многоэтажных зданий при высоте здания: до 25 м | 1d | 2026-03-21 | 2026-03-21 | 389SS | 63d | 0d | finish no earlier than 2025-08-28 | 350.06h |
| 392 | 1.5.4.3 | **Связи горизонт. и вертик.** | 1d | 2026-03-21 | 2026-03-21 |  | 59d |  |  |  |
| 393 | 1.5.4.3.1 | Монтаж связей и распорок из одиночных и парных уголков, гнутосварных профилей для пролетов: до 24 м при высоте здания до 25 м | 1d | 2026-03-21 | 2026-03-21 | 391SS | 59d | 0d | start no earlier than 2026-01-10 |  |

| ID | WBS | Task | Duration | Start | Finish | Predecessors | Total slack | Free slack | Constraint | Work |
| --- | --- | --- | --- | --- | --- | --- | --- | --- | --- | --- |
| 394 | 1.5.4.4 | **Установка С-элемента** | 2d | 2026-03-22 | 2026-03-23 |  | 59d |  |  |  |
| 395 | 1.5.4.4.1 | Монтаж балок, ригелей перекрытия, покрытия и под установку оборудования многоэтажных зданий при высоте здания: до 25 м | 2d | 2026-03-22 | 2026-03-23 | 393 | 59d | 0d | finish no earlier than 2026-01-11 |  |
| 396 | 1.5.4.5 | **Прогоны покрытия** | 1d | 2026-03-24 | 2026-03-24 |  | 59d |  |  |  |
| 397 | 1.5.4.5.1 | Монтаж балок, ригелей перекрытия, покрытия и под установку оборудования многоэтажных зданий при высоте здания: до 25 м | 1d | 2026-03-24 | 2026-03-24 | 395 | 59d | 0d | finish no earlier than 2026-01-12 |  |
| 398 | 1.5.4.6 | **Стеновой фахверк** | 1d | 2026-03-24 | 2026-03-24 |  | 60d |  |  |  |
| 399 | 1.5.4.6.1 | Монтаж фахверка | 1d | 2026-03-24 | 2026-03-24 | 395 | 60d |  | start no earlier than 2026-01-09 |  |
| 400 | 1.5.5 | **Ось 36-37** | 4d | 2026-03-25 | 2026-03-28 |  | 29d |  |  | 350.06h |
| 401 | 1.5.5.1 | **Колонны** | 1d | 2026-03-25 | 2026-03-25 |  | 59d |  |  |  |
| 402 | 1.5.5.1.1 | Монтаж колонн одноэтажных и многоэтажных зданий и крановых эстакад высотой: до 25 м составного сечения массой до 5,0 т | 1d | 2026-03-25 | 2026-03-25 | 397 | 59d | 0d | finish no earlier than 2026-01-08 |  |
| 403 | 1.5.5.2 | **Балки перекрытий и фермы ФП1** | 1d | 2026-03-25 | 2026-03-25 |  | 59d |  |  | 350.06h |
| 404 | 1.5.5.2.1 | Монтаж балок, ригелей перекрытия, покрытия и под установку оборудования многоэтажных зданий при высоте здания: до 25 м | 1d | 2026-03-25 | 2026-03-25 | 402SS | 59d | 0d | finish no earlier than 2025-08-28 | 350.06h |
| 405 | 1.5.5.3 | **Связи горизонт. и вертик.** | 1d | 2026-03-25 | 2026-03-25 |  | 29d |  |  |  |
| 406 | 1.5.5.3.1 | Монтаж связей и распорок из одиночных и парных уголков, гнутосварных профилей для пролетов: до 24 м при высоте здания до 25 м | 1d | 2026-03-25 | 2026-03-25 | 404SS | 29d | 0d | start no earlier than 2026-01-10 |  |
| 407 | 1.5.5.4 | **Установка С-элемента** | 2d | 2026-03-26 | 2026-03-27 |  | 29d |  |  |  |
| 408 | 1.5.5.4.1 | Монтаж балок, ригелей перекрытия, покрытия и под установку оборудования многоэтажных зданий при высоте здания: до 25 м | 2d | 2026-03-26 | 2026-03-27 | 406 | 29d | 0d | finish no earlier than 2026-01-11 |  |
| 409 | 1.5.5.5 | **Прогоны покрытия** | 1d | 2026-03-28 | 2026-03-28 |  | 29d |  |  |  |
| 410 | 1.5.5.5.1 | Монтаж балок, ригелей перекрытия, покрытия и под установку оборудования многоэтажных зданий при высоте здания: до 25 м | 1d | 2026-03-28 | 2026-03-28 | 408 | 29d | 0d | finish no earlier than 2026-01-12 |  |
| 411 | 1.5.5.6 | **Стеновой фахверк** | 1d | 2026-03-28 | 2026-03-28 |  | 56d |  |  |  |
| 412 | 1.5.5.6.1 | Монтаж фахверка | 1d | 2026-03-28 | 2026-03-28 | 408 | 56d |  | start no earlier than 2026-01-09 |  |
| 413 | 1.5.6 | Монтаж площадок с настилом и ограждением из листовой, рифленой, просечной и круглой стали | 20d | 2026-03-29 | 2026-04-17 | 410 | 29d | 0d |  |  |
| 414 | 1.5.7 | **Ось 35-36** | 4d | 2026-03-29 | 2026-04-01 |  | 51d |  |  | 350.06h |
| 415 | 1.5.7.1 | **Колонны** | 1d | 2026-03-29 | 2026-03-29 |  | 55d |  |  |  |
| 416 | 1.5.7.1.1 | Монтаж колонн одноэтажных и многоэтажных зданий и крановых эстакад высотой: до 25 м составного сечения массой до 5,0 т | 1d | 2026-03-29 | 2026-03-29 | 410 | 55d | 0d | finish no earlier than 2026-01-08 |  |
| 417 | 1.5.7.2 | **Балки перекрытий и фермы ФП1** | 1d | 2026-03-29 | 2026-03-29 |  | 55d |  |  | 350.06h |
| 418 | 1.5.7.2.1 | Монтаж балок, ригелей перекрытия, покрытия и под установку оборудования многоэтажных зданий при высоте здания: до 25 м | 1d | 2026-03-29 | 2026-03-29 | 416SS | 55d | 0d | finish no earlier than 2025-08-28 | 350.06h |

| ID | WBS | Task | Duration | Start | Finish | Predecessors | Total slack | Free slack | Constraint | Work |
| --- | --- | --- | --- | --- | --- | --- | --- | --- | --- | --- |
| 419 | 1.5.7.3 | **Связи горизонт. и вертик.** | 1d | 2026-03-29 | 2026-03-29 |  | 51d |  |  |  |
| 420 | 1.5.7.3.1 | Монтаж связей и распорок из одиночных и парных уголков, гнутосварных профилей для пролетов: до 24 м при высоте здания до 25 м | 1d | 2026-03-29 | 2026-03-29 | 418SS | 51d | 0d | start no earlier than 2026-01-10 |  |
| 421 | 1.5.7.4 | **Установка С-элемента** | 2d | 2026-03-30 | 2026-03-31 |  | 51d |  |  |  |
| 422 | 1.5.7.4.1 | Монтаж балок, ригелей перекрытия, покрытия и под установку оборудования многоэтажных зданий при высоте здания: до 25 м | 2d | 2026-03-30 | 2026-03-31 | 420 | 51d | 0d | finish no earlier than 2026-01-11 |  |
| 423 | 1.5.7.5 | **Прогоны покрытия** | 1d | 2026-04-01 | 2026-04-01 |  | 52d |  |  |  |
| 424 | 1.5.7.5.1 | Монтаж балок, ригелей перекрытия, покрытия и под установку оборудования многоэтажных зданий при высоте здания: до 25 м | 1d | 2026-04-01 | 2026-04-01 | 422 | 52d |  | finish no earlier than 2026-01-12 |  |
| 425 | 1.5.7.6 | **Стеновой фахверк** | 1d | 2026-04-01 | 2026-04-01 |  | 51d | 0d |  |  |
| 426 | 1.5.7.6.1 | Монтаж фахверка | 1d | 2026-04-01 | 2026-04-01 | 422 | 51d |  | start no earlier than 2026-01-09 |  |
| 427 | 1.5.8 | **Ось 33-35** | 4d | 2026-04-02 | 2026-04-05 |  | 33d |  |  | 350.06h |
| 428 | 1.5.8.1 | **Колонны** | 1d | 2026-04-02 | 2026-04-02 |  | 51d |  |  |  |
| 429 | 1.5.8.1.1 | Монтаж колонн одноэтажных и многоэтажных зданий и крановых эстакад высотой: до 25 м составного сечения массой до 5,0 т | 1d | 2026-04-02 | 2026-04-02 | 425 | 51d | 0d | finish no earlier than 2026-01-08 |  |
| 430 | 1.5.8.2 | **Балки перекрытий и фермы ФП1** | 1d | 2026-04-02 | 2026-04-02 |  | 51d |  |  | 350.06h |
| 431 | 1.5.8.2.1 | Монтаж балок, ригелей перекрытия, покрытия и под установку оборудования многоэтажных зданий при высоте здания: до 25 м | 1d | 2026-04-02 | 2026-04-02 | 429SS | 51d | 0d | finish no earlier than 2025-08-28 | 350.06h |
| 432 | 1.5.8.3 | **Связи горизонт. и вертик.** | 1d | 2026-04-02 | 2026-04-02 |  | 33d |  |  |  |
| 433 | 1.5.8.3.1 | Монтаж связей и распорок из одиночных и парных уголков, гнутосварных профилей для пролетов: до 24 м при высоте здания до 25 м | 1d | 2026-04-02 | 2026-04-02 | 431SS | 33d | 0d | start no earlier than 2026-01-10 |  |
| 434 | 1.5.8.4 | **Установка С-элемента** | 2d | 2026-04-03 | 2026-04-04 |  | 33d |  |  |  |
| 435 | 1.5.8.4.1 | Монтаж балок, ригелей перекрытия, покрытия и под установку оборудования многоэтажных зданий при высоте здания: до 25 м | 2d | 2026-04-03 | 2026-04-04 | 433 | 33d | 0d | finish no earlier than 2026-01-11 |  |
| 436 | 1.5.8.5 | **Прогоны покрытия** | 1d | 2026-04-05 | 2026-04-05 |  | 33d |  |  |  |
| 437 | 1.5.8.5.1 | Монтаж балок, ригелей перекрытия, покрытия и под установку оборудования многоэтажных зданий при высоте здания: до 25 м | 1d | 2026-04-05 | 2026-04-05 | 435 | 33d | 0d | finish no earlier than 2026-01-12 |  |
| 438 | 1.5.8.6 | **Стеновой фахверк** | 1d | 2026-04-05 | 2026-04-05 |  | 33d |  |  |  |
| 439 | 1.5.8.6.1 | Монтаж фахверка | 1d | 2026-04-05 | 2026-04-05 | 435 | 33d | 0d | start no earlier than 2026-01-09 |  |
| 440 | 1.5.9 | **Настил** | 19d | 2026-04-06 | 2026-04-24 |  | 29d |  |  | 160h |
| 441 | 1.5.9.1 | Монтаж кровельного покрытия: из профилированного листа при высоте здания до 25 м | 15d | 2026-04-06 | 2026-04-20 | 437 | 33d |  | start no earlier than 2025-08-27 | 80h |
| 442 | 1.5.9.2 | Монтаж ограждающих конструкций стен: из профилированного листа при высоте здания до 30 м (10% на подрезку) | 15d | 2026-04-06 | 2026-04-20 | 439 | 33d |  | start no earlier than 2026-01-09 | 80h |
| 443 | 1.5.9.3 | Монтаж лестниц | 7d | 2026-04-18 | 2026-04-24 | 413 | 29d |  |  |  |

| ID | WBS | Task | Duration | Start | Finish | Predecessors | Total slack | Free slack | Constraint | Work |
| --- | --- | --- | --- | --- | --- | --- | --- | --- | --- | --- |
| 444 | 1.5.10 | **Опоры под оборудование ЗД1-ЗД3** | 7d | 2026-04-18 | 2026-04-24 |  | 29d |  |  |  |
| 445 | 1.5.10.1 | Монтаж металлоконструкций постаментов под технологическое оборудование | 7d | 2026-04-18 | 2026-04-24 | 413 | 29d |  | start no earlier than 2025-09-01 |  |
| 446 | 1.6 | **ОЧЕРЕДЬ 4** | 47d | 2026-04-05 | 2026-05-21 |  | 2d |  |  | 2960.48h |
| 447 | 1.6.1 | **Ось 32-33** | 4d | 2026-04-05 | 2026-04-08 |  | 44d |  |  | 350.06h |
| 448 | 1.6.1.1 | **Колонны** | 1d | 2026-04-05 | 2026-04-05 |  | 48d |  |  |  |
| 449 | 1.6.1.1.1 | Монтаж колонн одноэтажных и многоэтажных зданий и крановых эстакад высотой: до 25 м составного сечения массой до 5,0 т | 1d | 2026-04-05 | 2026-04-05 | 435 | 48d | 0d | finish no earlier than 2026-01-08 |  |
| 450 | 1.6.1.2 | **Балки перекрытий и фермы ФП1** | 1d | 2026-04-05 | 2026-04-05 |  | 48d |  |  | 350.06h |
| 451 | 1.6.1.2.1 | Монтаж балок, ригелей перекрытия, покрытия и под установку оборудования многоэтажных зданий при высоте здания: до 25 м | 1d | 2026-04-05 | 2026-04-05 | 449SS | 48d | 0d | finish no earlier than 2025-08-28 | 350.06h |
| 452 | 1.6.1.3 | **Связи горизонт. и вертик.** | 1d | 2026-04-05 | 2026-04-05 |  | 44d |  |  |  |
| 453 | 1.6.1.3.1 | Монтаж связей и распорок из одиночных и парных уголков, гнутосварных профилей для пролетов: до 24 м при высоте здания до 25 м | 1d | 2026-04-05 | 2026-04-05 | 451SS | 44d | 0d | start no earlier than 2026-01-10 |  |
| 454 | 1.6.1.4 | **Установка С-элемента** | 2d | 2026-04-06 | 2026-04-07 |  | 44d |  |  |  |
| 455 | 1.6.1.4.1 | Монтаж балок, ригелей перекрытия, покрытия и под установку оборудования многоэтажных зданий при высоте здания: до 25 м | 2d | 2026-04-06 | 2026-04-07 | 453 | 44d | 0d | finish no earlier than 2026-01-11 |  |
| 456 | 1.6.1.5 | **Прогоны покрытия** | 1d | 2026-04-08 | 2026-04-08 |  | 44d |  |  |  |
| 457 | 1.6.1.5.1 | Монтаж балок, ригелей перекрытия, покрытия и под установку оборудования многоэтажных зданий при высоте здания: до 25 м | 1d | 2026-04-08 | 2026-04-08 | 455 | 44d | 0d | finish no earlier than 2026-01-12 |  |
| 458 | 1.6.1.6 | **Стеновой фахверк** | 1d | 2026-04-08 | 2026-04-08 |  | 45d |  |  |  |
| 459 | 1.6.1.6.1 | Монтаж фахверка | 1d | 2026-04-08 | 2026-04-08 | 455 | 45d |  | start no earlier than 2026-01-09 |  |
| 460 | 1.6.2 | **Ось 31-32** | 4d | 2026-04-09 | 2026-04-12 |  | 40d |  |  | 350.06h |
| 461 | 1.6.2.1 | **Колонны** | 1d | 2026-04-09 | 2026-04-09 |  | 44d |  |  |  |
| 462 | 1.6.2.1.1 | Монтаж колонн одноэтажных и многоэтажных зданий и крановых эстакад высотой: до 25 м составного сечения массой до 5,0 т | 1d | 2026-04-09 | 2026-04-09 | 457 | 44d | 0d | finish no earlier than 2026-01-08 |  |
| 463 | 1.6.2.2 | **Балки перекрытий и фермы ФП1** | 1d | 2026-04-09 | 2026-04-09 |  | 44d |  |  | 350.06h |
| 464 | 1.6.2.2.1 | Монтаж балок, ригелей перекрытия, покрытия и под установку оборудования многоэтажных зданий при высоте здания: до 25 м | 1d | 2026-04-09 | 2026-04-09 | 462SS | 44d | 0d | finish no earlier than 2025-08-28 | 350.06h |
| 465 | 1.6.2.3 | **Связи горизонт. и вертик.** | 1d | 2026-04-09 | 2026-04-09 |  | 40d |  |  |  |
| 466 | 1.6.2.3.1 | Монтаж связей и распорок из одиночных и парных уголков, гнутосварных профилей для пролетов: до 24 м при высоте здания до 25 м | 1d | 2026-04-09 | 2026-04-09 | 464SS | 40d | 0d | start no earlier than 2026-01-10 |  |
| 467 | 1.6.2.4 | **Установка С-элемента** | 2d | 2026-04-10 | 2026-04-11 |  | 40d |  |  |  |
| 468 | 1.6.2.4.1 | Монтаж балок, ригелей перекрытия, покрытия и под установку оборудования многоэтажных зданий при высоте здания: до 25 м | 2d | 2026-04-10 | 2026-04-11 | 466 | 40d | 0d | finish no earlier than 2026-01-11 |  |

| ID | WBS | Task | Duration | Start | Finish | Predecessors | Total slack | Free slack | Constraint | Work |
| --- | --- | --- | --- | --- | --- | --- | --- | --- | --- | --- |
| 469 | 1.6.2.5 | **Прогоны покрытия** | 1d | 2026-04-12 | 2026-04-12 |  | 40d |  |  |  |
| 470 | 1.6.2.5.1 | Монтаж балок, ригелей перекрытия, покрытия и под установку оборудования многоэтажных зданий при высоте здания: до 25 м | 1d | 2026-04-12 | 2026-04-12 | 468 | 40d | 0d | finish no earlier than 2026-01-12 |  |
| 471 | 1.6.2.6 | **Стеновой фахверк** | 1d | 2026-04-12 | 2026-04-12 |  | 41d |  |  |  |
| 472 | 1.6.2.6.1 | Монтаж фахверка | 1d | 2026-04-12 | 2026-04-12 | 468 | 41d |  | start no earlier than 2026-01-09 |  |
| 473 | 1.6.3 | **Ось 30-31** | 4d | 2026-04-13 | 2026-04-16 |  | 36d |  |  | 350.06h |
| 474 | 1.6.3.1 | **Колонны** | 1d | 2026-04-13 | 2026-04-13 |  | 40d |  |  |  |
| 475 | 1.6.3.1.1 | Монтаж колонн одноэтажных и многоэтажных зданий и крановых эстакад высотой: до 25 м составного сечения массой до 5,0 т | 1d | 2026-04-13 | 2026-04-13 | 470 | 40d | 0d | finish no earlier than 2026-01-08 |  |
| 476 | 1.6.3.2 | **Балки перекрытий и фермы ФП1** | 1d | 2026-04-13 | 2026-04-13 |  | 40d |  |  | 350.06h |
| 477 | 1.6.3.2.1 | Монтаж балок, ригелей перекрытия, покрытия и под установку оборудования многоэтажных зданий при высоте здания: до 25 м | 1d | 2026-04-13 | 2026-04-13 | 475SS | 40d | 0d | finish no earlier than 2025-08-28 | 350.06h |
| 478 | 1.6.3.3 | **Связи горизонт. и вертик.** | 1d | 2026-04-13 | 2026-04-13 |  | 36d |  |  |  |
| 479 | 1.6.3.3.1 | Монтаж связей и распорок из одиночных и парных уголков, гнутосварных профилей для пролетов: до 24 м при высоте здания до 25 м | 1d | 2026-04-13 | 2026-04-13 | 477SS | 36d | 0d | start no earlier than 2026-01-10 |  |
| 480 | 1.6.3.4 | **Установка С-элемента** | 2d | 2026-04-14 | 2026-04-15 |  | 36d |  |  |  |
| 481 | 1.6.3.4.1 | Монтаж балок, ригелей перекрытия, покрытия и под установку оборудования многоэтажных зданий при высоте здания: до 25 м | 2d | 2026-04-14 | 2026-04-15 | 479 | 36d | 0d | finish no earlier than 2026-01-11 |  |
| 482 | 1.6.3.5 | **Прогоны покрытия** | 1d | 2026-04-16 | 2026-04-16 |  | 36d |  |  |  |
| 483 | 1.6.3.5.1 | Монтаж балок, ригелей перекрытия, покрытия и под установку оборудования многоэтажных зданий при высоте здания: до 25 м | 1d | 2026-04-16 | 2026-04-16 | 481 | 36d | 0d | finish no earlier than 2026-01-12 |  |
| 484 | 1.6.3.6 | **Стеновой фахверк** | 1d | 2026-04-16 | 2026-04-16 |  | 37d |  |  |  |
| 485 | 1.6.3.6.1 | Монтаж фахверка | 1d | 2026-04-16 | 2026-04-16 | 481 | 37d |  | start no earlier than 2026-01-09 |  |
| 486 | 1.6.4 | **Ось 29-30** | 4d | 2026-04-17 | 2026-04-20 |  | 32d |  |  | 350.06h |
| 487 | 1.6.4.1 | **Колонны** | 1d | 2026-04-17 | 2026-04-17 |  | 36d |  |  |  |
| 488 | 1.6.4.1.1 | Монтаж колонн одноэтажных и многоэтажных зданий и крановых эстакад высотой: до 25 м составного сечения массой до 5,0 т | 1d | 2026-04-17 | 2026-04-17 | 483 | 36d | 0d | finish no earlier than 2026-01-08 |  |
| 489 | 1.6.4.2 | **Балки перекрытий и фермы ФП1** | 1d | 2026-04-17 | 2026-04-17 |  | 36d |  |  | 350.06h |
| 490 | 1.6.4.2.1 | Монтаж балок, ригелей перекрытия, покрытия и под установку оборудования многоэтажных зданий при высоте здания: до 25 м | 1d | 2026-04-17 | 2026-04-17 | 488SS | 36d | 0d | finish no earlier than 2025-08-28 | 350.06h |
| 491 | 1.6.4.3 | **Связи горизонт. и вертик.** | 1d | 2026-04-17 | 2026-04-17 |  | 32d |  |  |  |
| 492 | 1.6.4.3.1 | Монтаж связей и распорок из одиночных и парных уголков, гнутосварных профилей для пролетов: до 24 м при высоте здания до 25 м | 1d | 2026-04-17 | 2026-04-17 | 490SS | 32d | 0d | start no earlier than 2026-01-10 |  |

| ID | WBS | Task | Duration | Start | Finish | Predecessors | Total slack | Free slack | Constraint | Work |
| --- | --- | --- | --- | --- | --- | --- | --- | --- | --- | --- |
| 493 | 1.6.4.4 | **Установка С-элемента** | 2d | 2026-04-18 | 2026-04-19 |  | 32d |  |  |  |
| 494 | 1.6.4.4.1 | Монтаж балок, ригелей перекрытия, покрытия и под установку оборудования многоэтажных зданий при высоте здания: до 25 м | 2d | 2026-04-18 | 2026-04-19 | 492 | 32d | 0d | finish no earlier than 2026-01-11 |  |
| 495 | 1.6.4.5 | **Прогоны покрытия** | 1d | 2026-04-20 | 2026-04-20 |  | 32d |  |  |  |
| 496 | 1.6.4.5.1 | Монтаж балок, ригелей перекрытия, покрытия и под установку оборудования многоэтажных зданий при высоте здания: до 25 м | 1d | 2026-04-20 | 2026-04-20 | 494 | 32d | 0d | finish no earlier than 2026-01-12 |  |
| 497 | 1.6.4.6 | **Стеновой фахверк** | 1d | 2026-04-20 | 2026-04-20 |  | 33d |  |  |  |
| 498 | 1.6.4.6.1 | Монтаж фахверка | 1d | 2026-04-20 | 2026-04-20 | 494 | 33d |  | start no earlier than 2026-01-09 |  |
| 499 | 1.6.5 | **Ось 28-29** | 4d | 2026-04-21 | 2026-04-24 |  | 2d |  |  | 350.06h |
| 500 | 1.6.5.1 | **Колонны** | 1d | 2026-04-21 | 2026-04-21 |  | 32d |  |  |  |
| 501 | 1.6.5.1.1 | Монтаж колонн одноэтажных и многоэтажных зданий и крановых эстакад высотой: до 25 м составного сечения массой до 5,0 т | 1d | 2026-04-21 | 2026-04-21 | 496 | 32d | 0d | finish no earlier than 2026-01-08 |  |
| 502 | 1.6.5.2 | **Балки перекрытий и фермы ФП1** | 1d | 2026-04-21 | 2026-04-21 |  | 32d |  |  | 350.06h |
| 503 | 1.6.5.2.1 | Монтаж балок, ригелей перекрытия, покрытия и под установку оборудования многоэтажных зданий при высоте здания: до 25 м | 1d | 2026-04-21 | 2026-04-21 | 501SS | 32d | 0d | finish no earlier than 2025-08-28 | 350.06h |
| 504 | 1.6.5.3 | **Связи горизонт. и вертик.** | 1d | 2026-04-21 | 2026-04-21 |  | 2d |  |  |  |
| 505 | 1.6.5.3.1 | Монтаж связей и распорок из одиночных и парных уголков, гнутосварных профилей для пролетов: до 24 м при высоте здания до 25 м | 1d | 2026-04-21 | 2026-04-21 | 503SS | 2d | 0d | start no earlier than 2026-01-10 |  |
| 506 | 1.6.5.4 | **Установка С-элемента** | 2d | 2026-04-22 | 2026-04-23 |  | 2d |  |  |  |
| 507 | 1.6.5.4.1 | Монтаж балок, ригелей перекрытия, покрытия и под установку оборудования многоэтажных зданий при высоте здания: до 25 м | 2d | 2026-04-22 | 2026-04-23 | 505 | 2d | 0d | finish no earlier than 2026-01-11 |  |
| 508 | 1.6.5.5 | **Прогоны покрытия** | 1d | 2026-04-24 | 2026-04-24 |  | 2d |  |  |  |
| 509 | 1.6.5.5.1 | Монтаж балок, ригелей перекрытия, покрытия и под установку оборудования многоэтажных зданий при высоте здания: до 25 м | 1d | 2026-04-24 | 2026-04-24 | 507 | 2d | 0d | finish no earlier than 2026-01-12 |  |
| 510 | 1.6.5.6 | **Стеновой фахверк** | 1d | 2026-04-24 | 2026-04-24 |  | 29d |  |  |  |
| 511 | 1.6.5.6.1 | Монтаж фахверка | 1d | 2026-04-24 | 2026-04-24 | 507 | 29d |  | start no earlier than 2026-01-09 |  |
| 512 | 1.6.6 | Монтаж площадок с настилом и ограждением из листовой, рифленой, просечной и круглой стали | 20d | 2026-04-25 | 2026-05-14 | 509 | 2d | 0d |  |  |
| 513 | 1.6.7 | **Ось 27-28** | 4d | 2026-04-25 | 2026-04-28 |  | 24d |  |  | 350.06h |
| 514 | 1.6.7.1 | **Колонны** | 1d | 2026-04-25 | 2026-04-25 |  | 28d |  |  |  |
| 515 | 1.6.7.1.1 | Монтаж колонн одноэтажных и многоэтажных зданий и крановых эстакад высотой: до 25 м составного сечения массой до 5,0 т | 1d | 2026-04-25 | 2026-04-25 | 509 | 28d | 0d | finish no earlier than 2026-01-08 |  |
| 516 | 1.6.7.2 | **Балки перекрытий и фермы ФП1** | 1d | 2026-04-25 | 2026-04-25 |  | 28d |  |  | 350.06h |
| 517 | 1.6.7.2.1 | Монтаж балок, ригелей перекрытия, покрытия и под установку оборудования многоэтажных зданий при высоте здания: до 25 м | 1d | 2026-04-25 | 2026-04-25 | 515SS | 28d | 0d | finish no earlier than 2025-08-28 | 350.06h |

| ID | WBS | Task | Duration | Start | Finish | Predecessors | Total slack | Free slack | Constraint | Work |
| --- | --- | --- | --- | --- | --- | --- | --- | --- | --- | --- |
| 518 | 1.6.7.3 | **Связи горизонт. и вертик.** | 1d | 2026-04-25 | 2026-04-25 |  | 24d |  |  |  |
| 519 | 1.6.7.3.1 | Монтаж связей и распорок из одиночных и парных уголков, гнутосварных профилей для пролетов: до 24 м при высоте здания до 25 м | 1d | 2026-04-25 | 2026-04-25 | 517SS | 24d | 0d | start no earlier than 2026-01-10 |  |
| 520 | 1.6.7.4 | **Установка С-элемента** | 2d | 2026-04-26 | 2026-04-27 |  | 24d |  |  |  |
| 521 | 1.6.7.4.1 | Монтаж балок, ригелей перекрытия, покрытия и под установку оборудования многоэтажных зданий при высоте здания: до 25 м | 2d | 2026-04-26 | 2026-04-27 | 519 | 24d | 0d | finish no earlier than 2026-01-11 |  |
| 522 | 1.6.7.5 | **Прогоны покрытия** | 1d | 2026-04-28 | 2026-04-28 |  | 24d |  |  |  |
| 523 | 1.6.7.5.1 | Монтаж балок, ригелей перекрытия, покрытия и под установку оборудования многоэтажных зданий при высоте здания: до 25 м | 1d | 2026-04-28 | 2026-04-28 | 521 | 24d | 0d | finish no earlier than 2026-01-12 |  |
| 524 | 1.6.7.6 | **Стеновой фахверк** | 1d | 2026-04-28 | 2026-04-28 |  | 25d |  |  |  |
| 525 | 1.6.7.6.1 | Монтаж фахверка | 1d | 2026-04-28 | 2026-04-28 | 521 | 25d |  | start no earlier than 2026-01-09 |  |
| 526 | 1.6.8 | **Ось 26-27** | 4d | 2026-04-29 | 2026-05-02 |  | 20d |  |  | 350.06h |
| 527 | 1.6.8.1 | **Колонны** | 1d | 2026-04-29 | 2026-04-29 |  | 24d |  |  |  |
| 528 | 1.6.8.1.1 | Монтаж колонн одноэтажных и многоэтажных зданий и крановых эстакад высотой: до 25 м составного сечения массой до 5,0 т | 1d | 2026-04-29 | 2026-04-29 | 523 | 24d | 0d | finish no earlier than 2026-01-08 |  |
| 529 | 1.6.8.2 | **Балки перекрытий и фермы ФП1** | 1d | 2026-04-29 | 2026-04-29 |  | 24d |  |  | 350.06h |
| 530 | 1.6.8.2.1 | Монтаж балок, ригелей перекрытия, покрытия и под установку оборудования многоэтажных зданий при высоте здания: до 25 м | 1d | 2026-04-29 | 2026-04-29 | 528SS | 24d | 0d | finish no earlier than 2025-08-28 | 350.06h |
| 531 | 1.6.8.3 | **Связи горизонт. и вертик.** | 1d | 2026-04-29 | 2026-04-29 |  | 20d |  |  |  |
| 532 | 1.6.8.3.1 | Монтаж связей и распорок из одиночных и парных уголков, гнутосварных профилей для пролетов: до 24 м при высоте здания до 25 м | 1d | 2026-04-29 | 2026-04-29 | 530SS | 20d | 0d | start no earlier than 2026-01-10 |  |
| 533 | 1.6.8.4 | **Установка С-элемента** | 2d | 2026-04-30 | 2026-05-01 |  | 20d |  |  |  |
| 534 | 1.6.8.4.1 | Монтаж балок, ригелей перекрытия, покрытия и под установку оборудования многоэтажных зданий при высоте здания: до 25 м | 2d | 2026-04-30 | 2026-05-01 | 532 | 20d | 0d | finish no earlier than 2026-01-11 |  |
| 535 | 1.6.8.5 | **Прогоны покрытия** | 1d | 2026-05-02 | 2026-05-02 |  | 20d |  |  |  |
| 536 | 1.6.8.5.1 | Монтаж балок, ригелей перекрытия, покрытия и под установку оборудования многоэтажных зданий при высоте здания: до 25 м | 1d | 2026-05-02 | 2026-05-02 | 534 | 20d | 0d | finish no earlier than 2026-01-12 |  |
| 537 | 1.6.8.6 | **Стеновой фахверк** | 1d | 2026-05-02 | 2026-05-02 |  | 21d |  |  |  |
| 538 | 1.6.8.6.1 | Монтаж фахверка | 1d | 2026-05-02 | 2026-05-02 | 534 | 21d |  | start no earlier than 2026-01-09 |  |
| 539 | 1.6.9 | **Ось 25-26** | 4d | 2026-05-03 | 2026-05-06 |  | 2d |  |  | 350.06h |
| 540 | 1.6.9.1 | **Колонны** | 1d | 2026-05-03 | 2026-05-03 |  | 20d |  |  |  |
| 541 | 1.6.9.1.1 | Монтаж колонн одноэтажных и многоэтажных зданий и крановых эстакад высотой: до 25 м составного сечения массой до 5,0 т | 1d | 2026-05-03 | 2026-05-03 | 536 | 20d | 0d | finish no earlier than 2026-01-08 |  |

| ID | WBS | Task | Duration | Start | Finish | Predecessors | Total slack | Free slack | Constraint | Work |
| --- | --- | --- | --- | --- | --- | --- | --- | --- | --- | --- |
| 542 | 1.6.9.2 | **Балки перекрытий и фермы ФП1** | 1d | 2026-05-03 | 2026-05-03 |  | 20d |  |  | 350.06h |
| 543 | 1.6.9.2.1 | Монтаж балок, ригелей перекрытия, покрытия и под установку оборудования многоэтажных зданий при высоте здания: до 25 м | 1d | 2026-05-03 | 2026-05-03 | 541SS | 20d | 0d | finish no earlier than 2025-08-28 | 350.06h |
| 544 | 1.6.9.3 | **Связи горизонт. и вертик.** | 1d | 2026-05-03 | 2026-05-03 |  | 2d |  |  |  |
| 545 | 1.6.9.3.1 | Монтаж связей и распорок из одиночных и парных уголков, гнутосварных профилей для пролетов: до 24 м при высоте здания до 25 м | 1d | 2026-05-03 | 2026-05-03 | 543SS | 2d | 0d | start no earlier than 2026-01-10 |  |
| 546 | 1.6.9.4 | **Установка С-элемента** | 2d | 2026-05-04 | 2026-05-05 |  | 2d |  |  |  |
| 547 | 1.6.9.4.1 | Монтаж балок, ригелей перекрытия, покрытия и под установку оборудования многоэтажных зданий при высоте здания: до 25 м | 2d | 2026-05-04 | 2026-05-05 | 545 | 2d | 0d | finish no earlier than 2026-01-11 |  |
| 548 | 1.6.9.5 | **Прогоны покрытия** | 1d | 2026-05-06 | 2026-05-06 |  | 2d |  |  |  |
| 549 | 1.6.9.5.1 | Монтаж балок, ригелей перекрытия, покрытия и под установку оборудования многоэтажных зданий при высоте здания: до 25 м | 1d | 2026-05-06 | 2026-05-06 | 547 | 2d | 0d | finish no earlier than 2026-01-12 |  |
| 550 | 1.6.9.6 | **Стеновой фахверк** | 1d | 2026-05-06 | 2026-05-06 |  | 2d |  |  |  |
| 551 | 1.6.9.6.1 | Монтаж фахверка | 1d | 2026-05-06 | 2026-05-06 | 547 | 2d | 0d | start no earlier than 2026-01-09 |  |
| 552 | 1.6.10 | **Настил** | 15d | 2026-05-07 | 2026-05-21 |  | 2d |  |  | 160h |
| 553 | 1.6.10.1 | Монтаж кровельного покрытия: из профилированного листа при высоте здания до 25 м | 15d | 2026-05-07 | 2026-05-21 | 549 | 2d |  | start no earlier than 2025-08-27 | 80h |
| 554 | 1.6.10.2 | Монтаж ограждающих конструкций стен: из профилированного листа при высоте здания до 30 м (10% на подрезку) | 15d | 2026-05-07 | 2026-05-21 | 551 | 2d |  | start no earlier than 2026-01-09 | 80h |
| 555 | 1.6.10.3 | Монтаж лестниц | 7d | 2026-05-15 | 2026-05-21 | 512 | 2d |  |  |  |
| 556 | 1.6.11 | **Опоры под оборудование ЗД1-ЗД3** | 7d | 2026-05-15 | 2026-05-21 |  | 2d |  |  |  |
| 557 | 1.6.11.1 | Монтаж металлоконструкций постаментов под технологическое оборудование | 7d | 2026-05-15 | 2026-05-21 | 512 | 2d |  | start no earlier than 2025-09-01 |  |
