Schedule from MS Project, 2026-02-09 to 2026-02-26.
Microsoft

## Calendars

- Стандартный: Mon-Sun 09:00-13:00, 14:00-18:00.

## Schedule

| ID | WBS | Task | Duration | Start | Finish | Predecessors | Total slack | Constraint |
| --- | --- | --- | --- | --- | --- | --- | --- | --- |
| 1 | 1 | **Конвейерная галерея. Очередь 1** | 18d | 2026-02-09 | 2026-02-26 |  | 0d |  |
| 2 | 1.1 | **оси 1-5** | 1d | 2026-02-09 | 2026-02-09 |  | 0d |  |
| 3 | 1.1.1 | Монтаж С элементов по осям 4,5;5 | 1d | 2026-02-09 | 2026-02-09 |  | 0d | start no earlier than 2026-02-09 |
| 4 | 1.2 | **оси 5-6** | 6d | 2026-02-10 | 2026-02-15 |  | 0d |  |
| 5 | 1.2.1 | Монтаж колонн оси 6+ ферма и ригеля с диагоналями | 1d | 2026-02-10 | 2026-02-10 | 3 | 0d | start no earlier than 2026-02-10 |
| 6 | 1.2.2 | Монтаж С элементов по оси 5,5 с обвязкой | 1d | 2026-02-11 | 2026-02-11 | 5 | 0d | start no earlier than 2026-02-11 |
| 7 | 1.2.3 | Обвязка 5,5-6 | 1d | 2026-02-12 | 2026-02-12 | 6 | 0d | start no earlier than 2026-02-12 |
| 8 | 1.2.4 | Монтаж С элемента по оси 6 с обвязкой | 1d | 2026-02-13 | 2026-02-13 | 7 | 0d | start no earlier than 2026-02-13 |
| 9 | 1.2.5 | Обвязка 5-6 | 1d | 2026-02-14 | 2026-02-14 | 8 | 0d | start no earlier than 2026-02-14 |
| 10 | 1.2.6 | Обвязка 5-6 | 1d | 2026-02-15 | 2026-02-15 | 9 | 0d | start no earlier than 2026-02-15 |
| 11 | 1.3 | **оси 6-7** | 3d | 2026-02-16 | 2026-02-18 |  | 0d |  |
| 12 | 1.3.1 | Монтаж колонн и фермы по оси 7 | 1d | 2026-02-16 | 2026-02-16 | 10 | 0d | start no earlier than 2026-02-16 |
| 13 | 1.3.2 | Монтаж С элементов по оси 6,5 с обвязкой | 1d | 2026-02-17 | 2026-02-17 | 12 | 0d | start no earlier than 2026-02-17 |
| 14 | 1.3.3 | Монтаж С элементов по оси 7 с обвязкой | 1d | 2026-02-18 | 2026-02-18 | 13 | 0d | start no earlier than 2026-02-18 |
| 15 | 1.4 | **оси 7-8** | 4d | 2026-02-19 | 2026-02-22 |  | 0d |  |
| 16 | 1.4.1 | Монтаж колонн и фермы по оси 8 | 1d | 2026-02-19 | 2026-02-19 | 14 | 0d | start no earlier than 2026-02-19 |
| 17 | 1.4.2 | Монтаж С элемента по оси 7,5 с обвязкой | 1d | 2026-02-20 | 2026-02-20 | 16 | 0d | start no earlier than 2026-02-20 |
| 18 | 1.4.3 | Монтаж С элемента по осис 8 с обвязкой | 1d | 2026-02-21 | 2026-02-21 | 17 | 0d | start no earlier than 2026-02-21 |
| 19 | 1.4.4 | Обвязка 7-8 | 1d | 2026-02-22 | 2026-02-22 | 18 | 0d | start no earlier than 2026-02-22 |
| 20 | 1.5 | **оси 8-9** | 4d | 2026-02-23 | 2026-02-26 |  | 0d |  |
| 21 | 1.5.1 | Монтаж колонн и фермы ось 9 | 1d | 2026-02-23 | 2026-02-23 | 19 | 0d | start no earlier than 2026-02-23 |
| 22 | 1.5.2 | Монтаж С элементов по оси 8,5 с обвязкой | 1d | 2026-02-24 | 2026-02-24 | 21 | 0d | start no earlier than 2026-02-24 |
| 23 | 1.5.3 | Монтаж С элементов по оси 8,5 с обвязкой | 1d | 2026-02-25 | 2026-02-25 | 22 | 0d | start no earlier than 2026-02-25 |
| 24 | 1.5.4 | Монтаж С элементов по оси 9 с обвязкой | 1d | 2026-02-26 | 2026-02-26 | 23 | 0d | start no earlier than 2026-02-26 |
