Schedule from MS Project, 2026-01-05 to 2026-06-08.
Microsoft

## Calendars

- Стандартный: Mon-Sun 09:00-13:00, 14:00-18:00.

## Schedule

| ID | WBS | Task | Type | Duration | Start | Finish | Predecessors | Total slack | Free slack | Constraint | Work |
| --- | --- | --- | --- | --- | --- | --- | --- | --- | --- | --- | --- |
| 1 | 1 | **КГ3** |  | 155d | 2026-01-05 | 2026-06-08 |  | 0d |  |  | 14452.3h |
| 2 | 1.1 | Поставка оставшегося металла | milestone | 0d | 2026-02-28 | 2026-02-28 |  | 91d | 0d | start no earlier than 2026-02-28 |  |
| 3 | 1.2 | **ОЧЕРЕДЬ 1** |  | 79d | 2026-01-05 | 2026-03-24 |  | 76d |  |  | 2960.48h |
| 4 | 1.2.1 | **Ось 1** |  | 5d | 2026-01-05 | 2026-01-09 |  | 136d |  |  |  |
| 5 | 1.2.1.1 | Поставка материалов | milestone | 0d | 2026-01-05 | 2026-01-05 |  | 155d |  |  |  |
| 6 | 1.2.1.2 | **Колонны** |  | 1d | 2026-01-05 | 2026-01-05 |  | 136d |  |  |  |
| 7 | 1.2.1.2.1 | Монтаж колонн одноэтажных и многоэтажных зданий и крановых эстакад высотой: до 25 м составного сечения массой до 5,0 т |  | 1d | 2026-01-05 | 2026-01-05 |  | 136d | 0d | start no earlier than 2026-01-05 |  |
| 8 | 1.2.1.3 | **Связи горизонт. и вертик.** |  | 1d | 2026-01-06 | 2026-01-06 |  | 136d |  |  |  |
| 9 | 1.2.1.3.1 | Монтаж связей и распорок из одиночных и парных уголков, гнутосварных профилей для пролетов: до 24 м при высоте здания до 25 м |  | 1d | 2026-01-06 | 2026-01-06 | 7 | 136d | 0d | start no earlier than 2026-01-06 |  |
| 10 | 1.2.1.4 | **Установка О-элемента** |  | 2d | 2026-01-07 | 2026-01-08 |  | 136d |  |  |  |
| 11 | 1.2.1.4.1 | Монтаж балок, ригелей перекрытия, покрытия и под установку оборудования многоэтажных зданий при высоте здания: до 25 м |  | 2d | 2026-01-07 | 2026-01-08 | 9 | 136d | 0d | start no earlier than 2026-01-06 |  |
| 12 | 1.2.1.5 | **Стеновой фахверк** |  | 1d | 2026-01-09 | 2026-01-09 |  | 136d |  |  |  |
| 13 | 1.2.1.5.1 | Монтаж фахверка |  | 1d | 2026-01-09 | 2026-01-09 | 11 | 136d | 0d | start no earlier than 2026-01-08 |  |
| 14 | 1.2.2 | **Ось 1-2** |  | 6d | 2026-01-10 | 2026-01-15 |  | 136d |  |  | 350.06h |
| 15 | 1.2.2.1 | **Колонны** |  | 1d | 2026-01-10 | 2026-01-10 |  | 136d |  |  |  |
| 16 | 1.2.2.1.1 | Монтаж колонн одноэтажных и многоэтажных зданий и крановых эстакад высотой: до 25 м составного сечения массой до 5,0 т |  | 1d | 2026-01-10 | 2026-01-10 | 13 | 136d | 0d | finish no earlier than 2026-01-07 |  |
| 17 | 1.2.2.2 | **Балки перекрытий и фермы ФП1** |  | 1d | 2026-01-10 | 2026-01-10 |  | 149d |  |  | 350.06h |
| 18 | 1.2.2.2.1 | Монтаж балок, ригелей перекрытия, покрытия и под установку оборудования многоэтажных зданий при высоте здания: до 25 м |  | 1d | 2026-01-10 | 2026-01-10 | 16SS | 149d | 13d | finish no earlier than 2025-08-28 | 350.06h |
| 19 | 1.2.2.3 | **Связи горизонт. и вертик.** |  | 1d | 2026-01-11 | 2026-01-11 |  | 136d |  |  |  |
| 20 | 1.2.2.3.1 | Монтаж связей и распорок из одиночных и парных уголков, гнутосварных профилей для пролетов: до 24 м при высоте здания до 25 м |  | 1d | 2026-01-11 | 2026-01-11 | 16 | 136d | 0d | start no earlier than 2026-01-10 |  |
| 21 | 1.2.2.4 | **Установка О-элемента** |  | 2d | 2026-01-12 | 2026-01-13 |  | 136d |  |  |  |
| 22 | 1.2.2.4.1 | Монтаж балок, ригелей перекрытия, покрытия и под установку оборудования многоэтажных зданий при высоте здания: до 25 м |  | 2d | 2026-01-12 | 2026-01-13 | 20 | 136d | 0d | start no earlier than 2026-01-07 |  |
| 23 | 1.2.2.5 | **Прогоны покрытия** |  | 2d | 2026-01-14 | 2026-01-15 |  | 136d |  |  |  |
| 24 | 1.2.2.5.1 | Монтаж балок, ригелей перекрытия, покрытия и под установку оборудования многоэтажных зданий при высоте здания: до 25 м |  | 2d | 2026-01-14 | 2026-01-15 | 22 | 136d | 0d | start no earlier than 2026-01-10 |  |

| ID | WBS | Task | Duration | Start | Finish | Predecessors | Total slack | Free slack | Constraint | Work |
| --- | --- | --- | --- | --- | --- | --- | --- | --- | --- | --- |
| 25 | 1.2.2.6 | **Стеновой фахверк** | 1d | 2026-01-12 | 2026-01-12 |  | 147d |  |  |  |
| 26 | 1.2.2.6.1 | Монтаж фахверка | 1d | 2026-01-12 | 2026-01-12 | 20 | 147d |  | start no earlier than 2026-01-09 |  |
| 27 | 1.2.3 | **Ось 2-3** | 6d | 2026-01-16 | 2026-01-21 |  | 136d |  |  | 350.06h |
| 28 | 1.2.3.1 | **Колонны** | 1d | 2026-01-16 | 2026-01-16 |  | 136d |  |  |  |
| 29 | 1.2.3.1.1 | Монтаж колонн одноэтажных и многоэтажных зданий и крановых эстакад высотой: до 25 м составного сечения массой до 5,0 т | 1d | 2026-01-16 | 2026-01-16 | 24 | 136d | 0d | finish no earlier than 2026-01-08 |  |
| 30 | 1.2.3.2 | **Балки перекрытий и фермы ФП1** | 1d | 2026-01-16 | 2026-01-16 |  | 143d |  |  | 350.06h |
| 31 | 1.2.3.2.1 | Монтаж балок, ригелей перекрытия, покрытия и под установку оборудования многоэтажных зданий при высоте здания: до 25 м | 1d | 2026-01-16 | 2026-01-16 | 29SS | 143d | 7d | finish no earlier than 2025-08-28 | 350.06h |
| 32 | 1.2.3.3 | **Связи горизонт. и вертик.** | 1d | 2026-01-17 | 2026-01-17 |  | 136d |  |  |  |
| 33 | 1.2.3.3.1 | Монтаж связей и распорок из одиночных и парных уголков, гнутосварных профилей для пролетов: до 24 м при высоте здания до 25 м | 1d | 2026-01-17 | 2026-01-17 | 29 | 136d | 0d | start no earlier than 2026-01-11 |  |
| 34 | 1.2.3.4 | **Установка О-элемента** | 2d | 2026-01-18 | 2026-01-19 |  | 136d |  |  |  |
| 35 | 1.2.3.4.1 | Монтаж балок, ригелей перекрытия, покрытия и под установку оборудования многоэтажных зданий при высоте здания: до 25 м | 2d | 2026-01-18 | 2026-01-19 | 33 | 136d | 0d | start no earlier than 2026-01-08 |  |
| 36 | 1.2.3.5 | **Прогоны покрытия** | 2d | 2026-01-20 | 2026-01-21 |  | 136d |  |  |  |
| 37 | 1.2.3.5.1 | Монтаж балок, ригелей перекрытия, покрытия и под установку оборудования многоэтажных зданий при высоте здания: до 25 м | 2d | 2026-01-20 | 2026-01-21 | 35 | 136d | 0d | start no earlier than 2026-01-10 |  |
| 38 | 1.2.3.6 | **Стеновой фахверк** | 1d | 2026-01-18 | 2026-01-18 |  | 141d |  |  |  |
| 39 | 1.2.3.6.1 | Монтаж фахверка | 1d | 2026-01-18 | 2026-01-18 | 33 | 141d |  | start no earlier than 2026-01-09 |  |
| 40 | 1.2.4 | **Ось 3-4** | 6d | 2026-01-22 | 2026-01-27 |  | 125d |  |  | 350.06h |
| 41 | 1.2.4.1 | **Колонны** | 1d | 2026-01-22 | 2026-01-22 |  | 136d |  |  |  |
| 42 | 1.2.4.1.1 | Монтаж колонн одноэтажных и многоэтажных зданий и крановых эстакад высотой: до 25 м составного сечения массой до 5,0 т | 1d | 2026-01-22 | 2026-01-22 | 37 | 136d | 0d | finish no earlier than 2026-01-08 |  |
| 43 | 1.2.4.2 | **Балки перекрытий и фермы ФП1** | 1d | 2026-01-23 | 2026-01-23 |  | 136d |  |  | 350.06h |
| 44 | 1.2.4.2.1 | Монтаж балок, ригелей перекрытия, покрытия и под установку оборудования многоэтажных зданий при высоте здания: до 25 м | 1d | 2026-01-23 | 2026-01-23 | 42 | 136d | 0d | finish no earlier than 2025-08-28 | 350.06h |
| 45 | 1.2.4.3 | **Связи горизонт. и вертик.** | 1d | 2026-01-23 | 2026-01-23 |  | 124d |  |  |  |
| 46 | 1.2.4.3.1 | Монтаж связей и распорок из одиночных и парных уголков, гнутосварных профилей для пролетов: до 24 м при высоте здания до 25 м | 1d | 2026-01-23 | 2026-01-23 | 44SS, 31SS, 18SS | 124d | 0d | start no earlier than 2026-01-10 |  |
| 47 | 1.2.4.4 | **Установка О-элемента** | 2d | 2026-01-24 | 2026-01-25 |  | 124d |  |  |  |
| 48 | 1.2.4.4.1 | Монтаж балок, ригелей перекрытия, покрытия и под установку оборудования многоэтажных зданий при высоте здания: до 25 м | 2d | 2026-01-24 | 2026-01-25 | 46 | 124d | 0d | finish no earlier than 2026-01-11 |  |

| ID | WBS | Task | Duration | Start | Finish | Predecessors | Total slack | Free slack | Constraint | Work |
| --- | --- | --- | --- | --- | --- | --- | --- | --- | --- | --- |
| 49 | 1.2.4.5 | **Прогоны покрытия** | 2d | 2026-01-26 | 2026-01-27 |  | 124d |  |  |  |
| 50 | 1.2.4.5.1 | Монтаж балок, ригелей перекрытия, покрытия и под установку оборудования многоэтажных зданий при высоте здания: до 25 м | 2d | 2026-01-26 | 2026-01-27 | 48 | 124d | 0d | finish no earlier than 2026-01-12 |  |
| 51 | 1.2.4.6 | **Стеновой фахверк** | 1d | 2026-01-24 | 2026-01-24 |  | 135d |  |  |  |
| 52 | 1.2.4.6.1 | Монтаж фахверка | 1d | 2026-01-24 | 2026-01-24 | 46 | 135d |  | start no earlier than 2026-01-09 |  |
| 53 | 1.2.5 | **Ось 4-5** | 17d | 2026-01-28 | 2026-02-13 |  | 115d |  |  | 350.06h |
| 54 | 1.2.5.1 | **Колонны** | 1d | 2026-01-28 | 2026-01-28 |  | 124d |  |  |  |
| 55 | 1.2.5.1.1 | Монтаж колонн одноэтажных и многоэтажных зданий и крановых эстакад высотой: до 25 м составного сечения массой до 5,0 т | 1d | 2026-01-28 | 2026-01-28 | 50 | 124d | 1d | start no earlier than 2026-01-26 |  |
| 56 | 1.2.5.2 | **Балки перекрытий и фермы ФП1** | 1d | 2026-01-30 | 2026-01-30 |  | 123d |  |  | 350.06h |
| 57 | 1.2.5.2.1 | Монтаж балок, ригелей перекрытия, покрытия и под установку оборудования многоэтажных зданий при высоте здания: до 25 м | 1d | 2026-01-30 | 2026-01-30 | 55 | 123d | 0d | start no earlier than 2026-01-30 | 350.06h |
| 58 | 1.2.5.3 | **Связи горизонт. и вертик.** | 1d | 2026-01-30 | 2026-01-30 |  | 123d |  |  |  |
| 59 | 1.2.5.3.1 | Монтаж связей и распорок из одиночных и парных уголков, гнутосварных профилей для пролетов: до 24 м при высоте здания до 25 м | 1d | 2026-01-30 | 2026-01-30 | 57SS | 123d | 10d | start no earlier than 2026-01-10 |  |
| 60 | 1.2.5.4 | **Установка С-элемента** | 2d | 2026-02-10 | 2026-02-11 |  | 113d |  |  |  |
| 61 | 1.2.5.4.1 | Монтаж балок, ригелей перекрытия, покрытия и под установку оборудования многоэтажных зданий при высоте здания: до 25 м | 2d | 2026-02-10 | 2026-02-11 | 59 | 113d | 0d | start no earlier than 2026-02-10 |  |
| 62 | 1.2.5.5 | **Прогоны покрытия** | 2d | 2026-02-12 | 2026-02-13 |  | 113d |  |  |  |
| 63 | 1.2.5.5.1 | Монтаж балок, ригелей перекрытия, покрытия и под установку оборудования многоэтажных зданий при высоте здания: до 25 м | 2d | 2026-02-12 | 2026-02-13 | 61 | 113d | 0d | finish no earlier than 2026-01-12 |  |
| 64 | 1.2.5.6 | **Стеновой фахверк** | 2d | 2026-02-12 | 2026-02-13 |  | 115d |  |  |  |
| 65 | 1.2.5.6.1 | Монтаж фахверка | 2d | 2026-02-12 | 2026-02-13 | 63SS | 115d |  | start no earlier than 2026-01-09 |  |
| 66 | 1.2.6 | **Ось 5-6** | 6d | 2026-02-14 | 2026-02-19 |  | 88d |  |  | 350.06h |
| 67 | 1.2.6.1 | **Колонны** | 1d | 2026-02-14 | 2026-02-14 |  | 113d |  |  |  |
| 68 | 1.2.6.1.1 | Монтаж колонн одноэтажных и многоэтажных зданий и крановых эстакад высотой: до 25 м составного сечения массой до 5,0 т | 1d | 2026-02-14 | 2026-02-14 | 63 | 113d | 0d | finish no earlier than 2026-01-08 |  |
| 69 | 1.2.6.2 | **Балки перекрытий и фермы ФП1** | 1d | 2026-02-15 | 2026-02-15 |  | 113d |  |  | 350.06h |
| 70 | 1.2.6.2.1 | Монтаж балок, ригелей перекрытия, покрытия и под установку оборудования многоэтажных зданий при высоте здания: до 25 м | 1d | 2026-02-15 | 2026-02-15 | 68 | 113d | 0d | finish no earlier than 2025-08-28 | 350.06h |
| 71 | 1.2.6.3 | **Связи горизонт. и вертик.** | 1d | 2026-02-15 | 2026-02-15 |  | 87d |  |  |  |
| 72 | 1.2.6.3.1 | Монтаж связей и распорок из одиночных и парных уголков, гнутосварных профилей для пролетов: до 24 м при высоте здания до 25 м | 1d | 2026-02-15 | 2026-02-15 | 70SS | 87d | 0d | start no earlier than 2026-01-10 |  |

| ID | WBS | Task | Duration | Start | Finish | Predecessors | Total slack | Free slack | Constraint | Work |
| --- | --- | --- | --- | --- | --- | --- | --- | --- | --- | --- |
| 73 | 1.2.6.4 | **Установка С-элемента** | 2d | 2026-02-16 | 2026-02-17 |  | 87d |  |  |  |
| 74 | 1.2.6.4.1 | Монтаж балок, ригелей перекрытия, покрытия и под установку оборудования многоэтажных зданий при высоте здания: до 25 м | 2d | 2026-02-16 | 2026-02-17 | 72 | 87d | 0d | finish no earlier than 2026-01-11 |  |
| 75 | 1.2.6.5 | **Прогоны покрытия** | 2d | 2026-02-18 | 2026-02-19 |  | 87d |  |  |  |
| 76 | 1.2.6.5.1 | Монтаж балок, ригелей перекрытия, покрытия и под установку оборудования многоэтажных зданий при высоте здания: до 25 м | 2d | 2026-02-18 | 2026-02-19 | 74 | 87d | 0d | finish no earlier than 2026-01-12 |  |
| 77 | 1.2.7 | Монтаж площадок с настилом и ограждением из листовой, рифленой, просечной и круглой стали | 15d | 2026-02-20 | 2026-03-06 | 76 | 87d | 0d |  |  |
| 78 | 1.2.8 | **Ось 6-7** | 6d | 2026-02-20 | 2026-02-25 |  | 102d |  |  | 350.06h |
| 79 | 1.2.8.1 | **Колонны** | 1d | 2026-02-20 | 2026-02-20 |  | 107d |  |  |  |
| 80 | 1.2.8.1.1 | Монтаж колонн одноэтажных и многоэтажных зданий и крановых эстакад высотой: до 25 м составного сечения массой до 5,0 т | 1d | 2026-02-20 | 2026-02-20 | 76 | 107d | 0d | finish no earlier than 2026-01-08 |  |
| 81 | 1.2.8.2 | **Балки перекрытий и фермы ФП1** | 1d | 2026-02-21 | 2026-02-21 |  | 107d |  |  | 350.06h |
| 82 | 1.2.8.2.1 | Монтаж балок, ригелей перекрытия, покрытия и под установку оборудования многоэтажных зданий при высоте здания: до 25 м | 1d | 2026-02-21 | 2026-02-21 | 80 | 107d | 0d | finish no earlier than 2025-08-28 | 350.06h |
| 83 | 1.2.8.3 | **Связи горизонт. и вертик.** | 1d | 2026-02-21 | 2026-02-21 |  | 101d |  |  |  |
| 84 | 1.2.8.3.1 | Монтаж связей и распорок из одиночных и парных уголков, гнутосварных профилей для пролетов: до 24 м при высоте здания до 25 м | 1d | 2026-02-21 | 2026-02-21 | 82SS | 101d | 0d | start no earlier than 2026-01-10 |  |
| 85 | 1.2.8.4 | **Установка С-элемента** | 2d | 2026-02-22 | 2026-02-23 |  | 101d |  |  |  |
| 86 | 1.2.8.4.1 | Монтаж балок, ригелей перекрытия, покрытия и под установку оборудования многоэтажных зданий при высоте здания: до 25 м | 2d | 2026-02-22 | 2026-02-23 | 84 | 101d | 0d | finish no earlier than 2026-01-11 |  |
| 87 | 1.2.8.5 | **Прогоны покрытия** | 2d | 2026-02-24 | 2026-02-25 |  | 101d |  |  |  |
| 88 | 1.2.8.5.1 | Монтаж балок, ригелей перекрытия, покрытия и под установку оборудования многоэтажных зданий при высоте здания: до 25 м | 2d | 2026-02-24 | 2026-02-25 | 86 | 101d | 0d | finish no earlier than 2026-01-12 |  |
| 89 | 1.2.8.6 | **Стеновой фахверк** | 2d | 2026-02-24 | 2026-02-25 |  | 103d |  |  |  |
| 90 | 1.2.8.6.1 | Монтаж фахверка | 2d | 2026-02-24 | 2026-02-25 | 86 | 103d |  | start no earlier than 2026-01-09 |  |
| 91 | 1.2.9 | **Ось 7-8** | 6d | 2026-02-26 | 2026-03-03 |  | 96d |  |  | 350.06h |
| 92 | 1.2.9.1 | **Колонны** | 1d | 2026-02-26 | 2026-02-26 |  | 101d |  |  |  |
| 93 | 1.2.9.1.1 | Монтаж колонн одноэтажных и многоэтажных зданий и крановых эстакад высотой: до 25 м составного сечения массой до 5,0 т | 1d | 2026-02-26 | 2026-02-26 | 88 | 101d | 0d | finish no earlier than 2026-01-08 |  |
| 94 | 1.2.9.2 | **Балки перекрытий и фермы ФП1** | 1d | 2026-02-27 | 2026-02-27 |  | 101d |  |  | 350.06h |
| 95 | 1.2.9.2.1 | Монтаж балок, ригелей перекрытия, покрытия и под установку оборудования многоэтажных зданий при высоте здания: до 25 м | 1d | 2026-02-27 | 2026-02-27 | 93 | 101d | 0d | finish no earlier than 2025-08-28 | 350.06h |
| 96 | 1.2.9.3 | **Связи горизонт. и вертик.** | 1d | 2026-02-27 | 2026-02-27 |  | 95d |  |  |  |
| 97 | 1.2.9.3.1 | Монтаж связей и распорок из одиночных и парных уголков, гнутосварных профилей для пролетов: до 24 м при высоте здания до 25 м | 1d | 2026-02-27 | 2026-02-27 | 95SS | 95d | 0d | start no earlier than 2026-01-10 |  |

| ID | WBS | Task | Duration | Start | Finish | Predecessors | Total slack | Free slack | Constraint | Work |
| --- | --- | --- | --- | --- | --- | --- | --- | --- | --- | --- |
| 98 | 1.2.9.4 | **Установка С-элемента** | 2d | 2026-02-28 | 2026-03-01 |  | 95d |  |  |  |
| 99 | 1.2.9.4.1 | Монтаж балок, ригелей перекрытия, покрытия и под установку оборудования многоэтажных зданий при высоте здания: до 25 м | 2d | 2026-02-28 | 2026-03-01 | 97 | 95d | 0d | finish no earlier than 2026-01-11 |  |
| 100 | 1.2.9.5 | **Прогоны покрытия** | 2d | 2026-03-02 | 2026-03-03 |  | 95d |  |  |  |
| 101 | 1.2.9.5.1 | Монтаж балок, ригелей перекрытия, покрытия и под установку оборудования многоэтажных зданий при высоте здания: до 25 м | 2d | 2026-03-02 | 2026-03-03 | 99 | 95d | 0d | finish no earlier than 2026-01-12 |  |
| 102 | 1.2.9.6 | **Стеновой фахверк** | 2d | 2026-03-02 | 2026-03-03 |  | 97d |  |  |  |
| 103 | 1.2.9.6.1 | Монтаж фахверка | 2d | 2026-03-02 | 2026-03-03 | 99 | 97d |  | start no earlier than 2026-01-09 |  |
| 104 | 1.2.10 | **Ось 8-9** | 6d | 2026-03-04 | 2026-03-09 |  | 77d |  |  | 350.06h |
| 105 | 1.2.10.1 | **Колонны** | 1d | 2026-03-04 | 2026-03-04 |  | 95d |  |  |  |
| 106 | 1.2.10.1.1 | Монтаж колонн одноэтажных и многоэтажных зданий и крановых эстакад высотой: до 25 м составного сечения массой до 5,0 т | 1d | 2026-03-04 | 2026-03-04 | 101 | 95d | 0d | finish no earlier than 2026-01-08 |  |
| 107 | 1.2.10.2 | **Балки перекрытий и фермы ФП1** | 1d | 2026-03-05 | 2026-03-05 |  | 95d |  |  | 350.06h |
| 108 | 1.2.10.2.1 | Монтаж балок, ригелей перекрытия, покрытия и под установку оборудования многоэтажных зданий при высоте здания: до 25 м | 1d | 2026-03-05 | 2026-03-05 | 106 | 95d | 0d | finish no earlier than 2025-08-28 | 350.06h |
| 109 | 1.2.10.3 | **Связи горизонт. и вертик.** | 1d | 2026-03-05 | 2026-03-05 |  | 76d |  |  |  |
| 110 | 1.2.10.3.1 | Монтаж связей и распорок из одиночных и парных уголков, гнутосварных профилей для пролетов: до 24 м при высоте здания до 25 м | 1d | 2026-03-05 | 2026-03-05 | 108SS | 76d | 0d | start no earlier than 2026-01-10 |  |
| 111 | 1.2.10.4 | **Установка С-элемента** | 2d | 2026-03-06 | 2026-03-07 |  | 76d |  |  |  |
| 112 | 1.2.10.4.1 | Монтаж балок, ригелей перекрытия, покрытия и под установку оборудования многоэтажных зданий при высоте здания: до 25 м | 2d | 2026-03-06 | 2026-03-07 | 110 | 76d | 0d | finish no earlier than 2026-01-11 |  |
| 113 | 1.2.10.5 | **Прогоны покрытия** | 2d | 2026-03-08 | 2026-03-09 |  | 76d |  |  |  |
| 114 | 1.2.10.5.1 | Монтаж балок, ригелей перекрытия, покрытия и под установку оборудования многоэтажных зданий при высоте здания: до 25 м | 2d | 2026-03-08 | 2026-03-09 | 112 | 76d | 0d | finish no earlier than 2026-01-12 |  |
| 115 | 1.2.10.6 | **Стеновой фахверк** | 2d | 2026-03-08 | 2026-03-09 |  | 76d |  |  |  |
| 116 | 1.2.10.6.1 | Монтаж фахверка | 2d | 2026-03-08 | 2026-03-09 | 112 | 76d | 0d | start no earlier than 2026-01-09 |  |
| 117 | 1.2.11 | **Профлист** | 18d | 2026-03-07 | 2026-03-24 |  | 76d |  |  | 160h |
| 118 | 1.2.11.1 | Монтаж кровельного покрытия: из профилированного листа при высоте здания до 25 м + огрождение | 15d | 2026-03-10 | 2026-03-24 | 114 | 76d |  | start no earlier than 2025-08-27 | 80h |
| 119 | 1.2.11.2 | Монтаж ограждающих конструкций стен: из профилированного листа при высоте здания до 30 м (10% на подрезку) | 15d | 2026-03-10 | 2026-03-24 | 116 | 76d |  | start no earlier than 2026-01-09 | 80h |
| 120 | 1.2.11.3 | Монтаж лестниц | 7d | 2026-03-07 | 2026-03-13 | 77 | 87d |  |  |  |
| 121 | 1.2.12 | **Опоры под оборудование ЗД1-ЗД3** | 7d | 2026-03-07 | 2026-03-13 |  | 87d |  |  |  |
| 122 | 1.2.12.1 | Монтаж металлоконструкций постаментов под технологическое оборудование | 7d | 2026-03-07 | 2026-03-13 | 77 | 87d |  | start no earlier than 2025-09-01 |  |

| ID | WBS | Task | Duration | Start | Finish | Predecessors | Total slack | Free slack | Constraint | Work |
| --- | --- | --- | --- | --- | --- | --- | --- | --- | --- | --- |
| 123 | 1.3 | **ОЧЕРЕДЬ 2** | 56d | 2026-03-10 | 2026-05-04 |  | 35d |  |  | 2960.48h |
| 124 | 1.3.1 | **Ось 9-10** | 6d | 2026-03-10 | 2026-03-15 |  | 85d |  |  | 350.06h |
| 125 | 1.3.1.1 | **Колонны** | 1d | 2026-03-10 | 2026-03-10 |  | 89d |  |  |  |
| 126 | 1.3.1.1.1 | Монтаж колонн одноэтажных и многоэтажных зданий и крановых эстакад высотой: до 25 м составного сечения массой до 5,0 т | 1d | 2026-03-10 | 2026-03-10 | 114 | 89d | 0d | finish no earlier than 2026-01-08 |  |
| 127 | 1.3.1.2 | **Балки перекрытий и фермы ФП1** | 1d | 2026-03-11 | 2026-03-11 |  | 89d |  |  | 350.06h |
| 128 | 1.3.1.2.1 | Монтаж балок, ригелей перекрытия, покрытия и под установку оборудования многоэтажных зданий при высоте здания: до 25 м | 1d | 2026-03-11 | 2026-03-11 | 126 | 89d | 0d | finish no earlier than 2025-08-28 | 350.06h |
| 129 | 1.3.1.3 | **Связи горизонт. и вертик.** | 1d | 2026-03-11 | 2026-03-11 |  | 84d |  |  |  |
| 130 | 1.3.1.3.1 | Монтаж связей и распорок из одиночных и парных уголков, гнутосварных профилей для пролетов: до 24 м при высоте здания до 25 м | 1d | 2026-03-11 | 2026-03-11 | 128SS | 84d | 0d | start no earlier than 2026-01-10 |  |
| 131 | 1.3.1.4 | **Установка С-элемента** | 2d | 2026-03-12 | 2026-03-13 |  | 84d | 0d |  |  |
| 132 | 1.3.1.4.1 | Монтаж балок, ригелей перекрытия, покрытия и под установку оборудования многоэтажных зданий при высоте здания: до 25 м | 2d | 2026-03-12 | 2026-03-13 | 130 | 84d | 0d | finish no earlier than 2026-01-11 |  |
| 133 | 1.3.1.5 | **Прогоны покрытия** | 2d | 2026-03-14 | 2026-03-15 |  | 84d |  |  |  |
| 134 | 1.3.1.5.1 | Монтаж балок, ригелей перекрытия, покрытия и под установку оборудования многоэтажных зданий при высоте здания: до 25 м | 2d | 2026-03-14 | 2026-03-15 | 132 | 84d | 0d | finish no earlier than 2026-01-12 |  |
| 135 | 1.3.1.6 | **Стеновой фахверк** | 2d | 2026-03-14 | 2026-03-15 |  | 85d |  |  |  |
| 136 | 1.3.1.6.1 | Монтаж фахверка | 2d | 2026-03-14 | 2026-03-15 | 131 | 85d |  | start no earlier than 2026-01-09 |  |
| 137 | 1.3.2 | **Ось 10-11** | 5d | 2026-03-16 | 2026-03-20 |  | 79d |  |  | 350.06h |
| 138 | 1.3.2.1 | **Колонны** | 1d | 2026-03-16 | 2026-03-16 |  | 84d |  |  |  |
| 139 | 1.3.2.1.1 | Монтаж колонн одноэтажных и многоэтажных зданий и крановых эстакад высотой: до 25 м составного сечения массой до 5,0 т | 1d | 2026-03-16 | 2026-03-16 | 134 | 84d | 0d | finish no earlier than 2026-01-08 |  |
| 140 | 1.3.2.2 | **Балки перекрытий и фермы ФП1** | 1d | 2026-03-16 | 2026-03-16 |  | 84d |  |  | 350.06h |
| 141 | 1.3.2.2.1 | Монтаж балок, ригелей перекрытия, покрытия и под установку оборудования многоэтажных зданий при высоте здания: до 25 м | 1d | 2026-03-16 | 2026-03-16 | 139SS | 84d | 0d | finish no earlier than 2025-08-28 | 350.06h |
| 142 | 1.3.2.3 | **Связи горизонт. и вертик.** | 1d | 2026-03-16 | 2026-03-16 |  | 79d |  |  |  |
| 143 | 1.3.2.3.1 | Монтаж связей и распорок из одиночных и парных уголков, гнутосварных профилей для пролетов: до 24 м при высоте здания до 25 м | 1d | 2026-03-16 | 2026-03-16 | 141SS | 79d | 0d | start no earlier than 2026-01-10 |  |
| 144 | 1.3.2.4 | **Установка С-элемента** | 2d | 2026-03-17 | 2026-03-18 |  | 79d |  |  |  |
| 145 | 1.3.2.4.1 | Монтаж балок, ригелей перекрытия, покрытия и под установку оборудования многоэтажных зданий при высоте здания: до 25 м | 2d | 2026-03-17 | 2026-03-18 | 143 | 79d | 0d | finish no earlier than 2026-01-11 |  |
| 146 | 1.3.2.5 | **Прогоны покрытия** | 2d | 2026-03-19 | 2026-03-20 |  | 79d |  |  |  |
| 147 | 1.3.2.5.1 | Монтаж балок, ригелей перекрытия, покрытия и под установку оборудования многоэтажных зданий при высоте здания: до 25 м | 2d | 2026-03-19 | 2026-03-20 | 145 | 79d | 0d | finish no earlier than 2026-01-12 |  |

| ID | WBS | Task | Duration | Start | Finish | Predecessors | Total slack | Free slack | Constraint | Work |
| --- | --- | --- | --- | --- | --- | --- | --- | --- | --- | --- |
| 148 | 1.3.2.6 | **Стеновой фахверк** | 2d | 2026-03-19 | 2026-03-20 |  | 80d |  |  |  |
| 149 | 1.3.2.6.1 | Монтаж фахверка | 2d | 2026-03-19 | 2026-03-20 | 145 | 80d |  | start no earlier than 2026-01-09 |  |
| 150 | 1.3.3 | **Ось 11-12** | 5d | 2026-03-21 | 2026-03-25 |  | 74d |  |  | 350.06h |
| 151 | 1.3.3.1 | **Колонны** | 1d | 2026-03-21 | 2026-03-21 |  | 79d |  |  |  |
| 152 | 1.3.3.1.1 | Монтаж колонн одноэтажных и многоэтажных зданий и крановых эстакад высотой: до 25 м составного сечения массой до 5,0 т | 1d | 2026-03-21 | 2026-03-21 | 147 | 79d | 0d | finish no earlier than 2026-01-08 |  |
| 153 | 1.3.3.2 | **Балки перекрытий и фермы ФП1** | 1d | 2026-03-21 | 2026-03-21 |  | 79d |  |  | 350.06h |
| 154 | 1.3.3.2.1 | Монтаж балок, ригелей перекрытия, покрытия и под установку оборудования многоэтажных зданий при высоте здания: до 25 м | 1d | 2026-03-21 | 2026-03-21 | 152SS | 79d | 0d | finish no earlier than 2025-08-28 | 350.06h |
| 155 | 1.3.3.3 | **Связи горизонт. и вертик.** | 1d | 2026-03-21 | 2026-03-21 |  | 74d |  |  |  |
| 156 | 1.3.3.3.1 | Монтаж связей и распорок из одиночных и парных уголков, гнутосварных профилей для пролетов: до 24 м при высоте здания до 25 м | 1d | 2026-03-21 | 2026-03-21 | 154SS | 74d | 0d | start no earlier than 2026-01-10 |  |
| 157 | 1.3.3.4 | **Установка С-элемента** | 2d | 2026-03-22 | 2026-03-23 |  | 74d |  |  |  |
| 158 | 1.3.3.4.1 | Монтаж балок, ригелей перекрытия, покрытия и под установку оборудования многоэтажных зданий при высоте здания: до 25 м | 2d | 2026-03-22 | 2026-03-23 | 156 | 74d | 0d | finish no earlier than 2026-01-11 |  |
| 159 | 1.3.3.5 | **Прогоны покрытия** | 2d | 2026-03-24 | 2026-03-25 |  | 74d |  |  |  |
| 160 | 1.3.3.5.1 | Монтаж балок, ригелей перекрытия, покрытия и под установку оборудования многоэтажных зданий при высоте здания: до 25 м | 2d | 2026-03-24 | 2026-03-25 | 158 | 74d | 0d | finish no earlier than 2026-01-12 |  |
| 161 | 1.3.3.6 | **Стеновой фахверк** | 2d | 2026-03-24 | 2026-03-25 |  | 75d |  |  |  |
| 162 | 1.3.3.6.1 | Монтаж фахверка | 2d | 2026-03-24 | 2026-03-25 | 158 | 75d |  | start no earlier than 2026-01-09 |  |
| 163 | 1.3.4 | **Ось 12-13** | 5d | 2026-03-26 | 2026-03-30 |  | 69d |  |  | 350.06h |
| 164 | 1.3.4.1 | **Колонны** | 1d | 2026-03-26 | 2026-03-26 |  | 74d |  |  |  |
| 165 | 1.3.4.1.1 | Монтаж колонн одноэтажных и многоэтажных зданий и крановых эстакад высотой: до 25 м составного сечения массой до 5,0 т | 1d | 2026-03-26 | 2026-03-26 | 160 | 74d | 0d | finish no earlier than 2026-01-08 |  |
| 166 | 1.3.4.2 | **Балки перекрытий и фермы ФП1** | 1d | 2026-03-26 | 2026-03-26 |  | 74d |  |  | 350.06h |
| 167 | 1.3.4.2.1 | Монтаж балок, ригелей перекрытия, покрытия и под установку оборудования многоэтажных зданий при высоте здания: до 25 м | 1d | 2026-03-26 | 2026-03-26 | 165SS | 74d | 0d | finish no earlier than 2025-08-28 | 350.06h |
| 168 | 1.3.4.3 | **Связи горизонт. и вертик.** | 1d | 2026-03-26 | 2026-03-26 |  | 69d |  |  |  |
| 169 | 1.3.4.3.1 | Монтаж связей и распорок из одиночных и парных уголков, гнутосварных профилей для пролетов: до 24 м при высоте здания до 25 м | 1d | 2026-03-26 | 2026-03-26 | 167SS | 69d | 0d | start no earlier than 2026-01-10 |  |
| 170 | 1.3.4.4 | **Установка С-элемента** | 2d | 2026-03-27 | 2026-03-28 |  | 69d |  |  |  |
| 171 | 1.3.4.4.1 | Монтаж балок, ригелей перекрытия, покрытия и под установку оборудования многоэтажных зданий при высоте здания: до 25 м | 2d | 2026-03-27 | 2026-03-28 | 169 | 69d | 0d | finish no earlier than 2026-01-11 |  |

| ID | WBS | Task | Duration | Start | Finish | Predecessors | Total slack | Free slack | Constraint | Work |
| --- | --- | --- | --- | --- | --- | --- | --- | --- | --- | --- |
| 172 | 1.3.4.5 | **Прогоны покрытия** | 2d | 2026-03-29 | 2026-03-30 |  | 69d |  |  |  |
| 173 | 1.3.4.5.1 | Монтаж балок, ригелей перекрытия, покрытия и под установку оборудования многоэтажных зданий при высоте здания: до 25 м | 2d | 2026-03-29 | 2026-03-30 | 171 | 69d | 0d | finish no earlier than 2026-01-12 |  |
| 174 | 1.3.4.6 | **Стеновой фахверк** | 2d | 2026-03-29 | 2026-03-30 |  | 70d |  |  |  |
| 175 | 1.3.4.6.1 | Монтаж фахверка | 2d | 2026-03-29 | 2026-03-30 | 171 | 70d |  | start no earlier than 2026-01-09 |  |
| 176 | 1.3.5 | **Ось 13-14** | 5d | 2026-03-31 | 2026-04-04 |  | 43d |  |  | 350.06h |
| 177 | 1.3.5.1 | **Колонны** | 1d | 2026-03-31 | 2026-03-31 |  | 69d |  |  |  |
| 178 | 1.3.5.1.1 | Монтаж колонн одноэтажных и многоэтажных зданий и крановых эстакад высотой: до 25 м составного сечения массой до 5,0 т | 1d | 2026-03-31 | 2026-03-31 | 173 | 69d | 0d | finish no earlier than 2026-01-08 |  |
| 179 | 1.3.5.2 | **Балки перекрытий и фермы ФП1** | 1d | 2026-03-31 | 2026-03-31 |  | 69d |  |  | 350.06h |
| 180 | 1.3.5.2.1 | Монтаж балок, ригелей перекрытия, покрытия и под установку оборудования многоэтажных зданий при высоте здания: до 25 м | 1d | 2026-03-31 | 2026-03-31 | 178SS | 69d | 0d | finish no earlier than 2025-08-28 | 350.06h |
| 181 | 1.3.5.3 | **Связи горизонт. и вертик.** | 1d | 2026-03-31 | 2026-03-31 |  | 43d |  |  |  |
| 182 | 1.3.5.3.1 | Монтаж связей и распорок из одиночных и парных уголков, гнутосварных профилей для пролетов: до 24 м при высоте здания до 25 м | 1d | 2026-03-31 | 2026-03-31 | 180SS | 43d | 0d | start no earlier than 2026-01-10 |  |
| 183 | 1.3.5.4 | **Установка С-элемента** | 2d | 2026-04-01 | 2026-04-02 |  | 43d |  |  |  |
| 184 | 1.3.5.4.1 | Монтаж балок, ригелей перекрытия, покрытия и под установку оборудования многоэтажных зданий при высоте здания: до 25 м | 2d | 2026-04-01 | 2026-04-02 | 182 | 43d | 0d | finish no earlier than 2026-01-11 |  |
| 185 | 1.3.5.5 | **Прогоны покрытия** | 2d | 2026-04-03 | 2026-04-04 |  | 43d |  |  |  |
| 186 | 1.3.5.5.1 | Монтаж балок, ригелей перекрытия, покрытия и под установку оборудования многоэтажных зданий при высоте здания: до 25 м | 2d | 2026-04-03 | 2026-04-04 | 184 | 43d | 0d | finish no earlier than 2026-01-12 |  |
| 187 | 1.3.5.6 | **Стеновой фахверк** | 2d | 2026-04-03 | 2026-04-04 |  | 65d |  |  |  |
| 188 | 1.3.5.6.1 | Монтаж фахверка | 2d | 2026-04-03 | 2026-04-04 | 186SS | 65d |  | start no earlier than 2026-01-09 |  |
| 189 | 1.3.6 | Монтаж площадок с настилом и ограждением из листовой, рифленой, просечной и круглой стали | 15d | 2026-04-05 | 2026-04-19 | 186 | 43d | 0d |  |  |
| 190 | 1.3.7 | **Ось 14-15** | 5d | 2026-04-05 | 2026-04-09 |  | 59d |  |  | 350.06h |
| 191 | 1.3.7.1 | **Колонны** | 1d | 2026-04-05 | 2026-04-05 |  | 64d |  |  |  |
| 192 | 1.3.7.1.1 | Монтаж колонн одноэтажных и многоэтажных зданий и крановых эстакад высотой: до 25 м составного сечения массой до 5,0 т | 1d | 2026-04-05 | 2026-04-05 | 186 | 64d | 0d | finish no earlier than 2026-01-08 |  |
| 193 | 1.3.7.2 | **Балки перекрытий и фермы ФП1** | 1d | 2026-04-05 | 2026-04-05 |  | 64d |  |  | 350.06h |
| 194 | 1.3.7.2.1 | Монтаж балок, ригелей перекрытия, покрытия и под установку оборудования многоэтажных зданий при высоте здания: до 25 м | 1d | 2026-04-05 | 2026-04-05 | 192SS | 64d | 0d | finish no earlier than 2025-08-28 | 350.06h |
| 195 | 1.3.7.3 | **Связи горизонт. и вертик.** | 1d | 2026-04-05 | 2026-04-05 |  | 59d |  |  |  |
| 196 | 1.3.7.3.1 | Монтаж связей и распорок из одиночных и парных уголков, гнутосварных профилей для пролетов: до 24 м при высоте здания до 25 м | 1d | 2026-04-05 | 2026-04-05 | 194SS | 59d | 0d | start no earlier than 2026-01-10 |  |

| ID | WBS | Task | Duration | Start | Finish | Predecessors | Total slack | Free slack | Constraint | Work |
| --- | --- | --- | --- | --- | --- | --- | --- | --- | --- | --- |
| 197 | 1.3.7.4 | **Установка С-элемента** | 2d | 2026-04-06 | 2026-04-07 |  | 59d |  |  |  |
| 198 | 1.3.7.4.1 | Монтаж балок, ригелей перекрытия, покрытия и под установку оборудования многоэтажных зданий при высоте здания: до 25 м | 2d | 2026-04-06 | 2026-04-07 | 196 | 59d | 0d | finish no earlier than 2026-01-11 |  |
| 199 | 1.3.7.5 | **Прогоны покрытия** | 2d | 2026-04-08 | 2026-04-09 |  | 59d |  |  |  |
| 200 | 1.3.7.5.1 | Монтаж балок, ригелей перекрытия, покрытия и под установку оборудования многоэтажных зданий при высоте здания: до 25 м | 2d | 2026-04-08 | 2026-04-09 | 198 | 59d | 0d | finish no earlier than 2026-01-12 |  |
| 201 | 1.3.7.6 | **Стеновой фахверк** | 2d | 2026-04-08 | 2026-04-09 |  | 60d |  |  |  |
| 202 | 1.3.7.6.1 | Монтаж фахверка | 2d | 2026-04-08 | 2026-04-09 | 198 | 60d |  | start no earlier than 2026-01-09 |  |
| 203 | 1.3.8 | **Ось 15-16** | 5d | 2026-04-10 | 2026-04-14 |  | 54d |  |  | 350.06h |
| 204 | 1.3.8.1 | **Колонны** | 1d | 2026-04-10 | 2026-04-10 |  | 59d |  |  |  |
| 205 | 1.3.8.1.1 | Монтаж колонн одноэтажных и многоэтажных зданий и крановых эстакад высотой: до 25 м составного сечения массой до 5,0 т | 1d | 2026-04-10 | 2026-04-10 | 200 | 59d | 0d | finish no earlier than 2026-01-08 |  |
| 206 | 1.3.8.2 | **Балки перекрытий и фермы ФП1** | 1d | 2026-04-10 | 2026-04-10 |  | 59d |  |  | 350.06h |
| 207 | 1.3.8.2.1 | Монтаж балок, ригелей перекрытия, покрытия и под установку оборудования многоэтажных зданий при высоте здания: до 25 м | 1d | 2026-04-10 | 2026-04-10 | 205SS | 59d | 0d | finish no earlier than 2025-08-28 | 350.06h |
| 208 | 1.3.8.3 | **Связи горизонт. и вертик.** | 1d | 2026-04-10 | 2026-04-10 |  | 54d |  |  |  |
| 209 | 1.3.8.3.1 | Монтаж связей и распорок из одиночных и парных уголков, гнутосварных профилей для пролетов: до 24 м при высоте здания до 25 м | 1d | 2026-04-10 | 2026-04-10 | 207SS | 54d | 0d | start no earlier than 2026-01-10 |  |
| 210 | 1.3.8.4 | **Установка С-элемента** | 2d | 2026-04-11 | 2026-04-12 |  | 54d |  |  |  |
| 211 | 1.3.8.4.1 | Монтаж балок, ригелей перекрытия, покрытия и под установку оборудования многоэтажных зданий при высоте здания: до 25 м | 2d | 2026-04-11 | 2026-04-12 | 209 | 54d | 0d | finish no earlier than 2026-01-11 |  |
| 212 | 1.3.8.5 | **Прогоны покрытия** | 2d | 2026-04-13 | 2026-04-14 |  | 54d |  |  |  |
| 213 | 1.3.8.5.1 | Монтаж балок, ригелей перекрытия, покрытия и под установку оборудования многоэтажных зданий при высоте здания: до 25 м | 2d | 2026-04-13 | 2026-04-14 | 211 | 54d | 0d | finish no earlier than 2026-01-12 |  |
| 214 | 1.3.8.6 | **Стеновой фахверк** | 2d | 2026-04-13 | 2026-04-14 |  | 55d |  |  |  |
| 215 | 1.3.8.6.1 | Монтаж фахверка | 2d | 2026-04-13 | 2026-04-14 | 211 | 55d |  | start no earlier than 2026-01-09 |  |
| 216 | 1.3.9 | **Ось 16-17** | 5d | 2026-04-15 | 2026-04-19 |  | 35d |  |  | 350.06h |
| 217 | 1.3.9.1 | **Колонны** | 1d | 2026-04-15 | 2026-04-15 |  | 54d |  |  |  |
| 218 | 1.3.9.1.1 | Монтаж колонн одноэтажных и многоэтажных зданий и крановых эстакад высотой: до 25 м составного сечения массой до 5,0 т | 1d | 2026-04-15 | 2026-04-15 | 213 | 54d | 0d | finish no earlier than 2026-01-08 |  |
| 219 | 1.3.9.2 | **Балки перекрытий и фермы ФП1** | 1d | 2026-04-15 | 2026-04-15 |  | 54d |  |  | 350.06h |
| 220 | 1.3.9.2.1 | Монтаж балок, ригелей перекрытия, покрытия и под установку оборудования многоэтажных зданий при высоте здания: до 25 м | 1d | 2026-04-15 | 2026-04-15 | 218SS | 54d | 0d | finish no earlier than 2025-08-28 | 350.06h |

| ID | WBS | Task | Duration | Start | Finish | Predecessors | Total slack | Free slack | Constraint | Work |
| --- | --- | --- | --- | --- | --- | --- | --- | --- | --- | --- |
| 221 | 1.3.9.3 | **Связи горизонт. и вертик.** | 1d | 2026-04-15 | 2026-04-15 |  | 35d |  |  |  |
| 222 | 1.3.9.3.1 | Монтаж связей и распорок из одиночных и парных уголков, гнутосварных профилей для пролетов: до 24 м при высоте здания до 25 м | 1d | 2026-04-15 | 2026-04-15 | 220SS | 35d | 0d | start no earlier than 2026-01-10 |  |
| 223 | 1.3.9.4 | **Установка С-элемента** | 2d | 2026-04-16 | 2026-04-17 |  | 35d |  |  |  |
| 224 | 1.3.9.4.1 | Монтаж балок, ригелей перекрытия, покрытия и под установку оборудования многоэтажных зданий при высоте здания: до 25 м | 2d | 2026-04-16 | 2026-04-17 | 222 | 35d | 0d | finish no earlier than 2026-01-11 |  |
| 225 | 1.3.9.5 | **Прогоны покрытия** | 2d | 2026-04-18 | 2026-04-19 |  | 35d |  |  |  |
| 226 | 1.3.9.5.1 | Монтаж балок, ригелей перекрытия, покрытия и под установку оборудования многоэтажных зданий при высоте здания: до 25 м | 2d | 2026-04-18 | 2026-04-19 | 224 | 35d | 0d | finish no earlier than 2026-01-12 |  |
| 227 | 1.3.9.6 | **Стеновой фахверк** | 2d | 2026-04-18 | 2026-04-19 |  | 35d |  |  |  |
| 228 | 1.3.9.6.1 | Монтаж фахверка | 2d | 2026-04-18 | 2026-04-19 | 224 | 35d | 0d | start no earlier than 2026-01-09 |  |
| 229 | 1.3.10 | **Профлист** | 15d | 2026-04-20 | 2026-05-04 |  | 35d |  |  | 160h |
| 230 | 1.3.10.1 | Монтаж кровельного покрытия: из профилированного листа при высоте здания до 25 м | 15d | 2026-04-20 | 2026-05-04 | 226 | 35d |  | start no earlier than 2025-08-27 | 80h |
| 231 | 1.3.10.2 | Монтаж ограждающих конструкций стен: из профилированного листа при высоте здания до 30 м (10% на подрезку) | 15d | 2026-04-20 | 2026-05-04 | 228 | 35d |  | start no earlier than 2026-01-09 | 80h |
| 232 | 1.3.10.3 | Монтаж лестниц | 7d | 2026-04-20 | 2026-04-26 | 189 | 43d |  |  |  |
| 233 | 1.3.11 | **Опоры под оборудование ЗД1-ЗД3** | 7d | 2026-04-20 | 2026-04-26 |  | 43d |  |  |  |
| 234 | 1.3.11.1 | Монтаж металлоконструкций постаментов под технологическое оборудование | 7d | 2026-04-20 | 2026-04-26 | 189 | 43d |  | start no earlier than 2025-09-01 |  |
| 235 | 1.4 | **ОЧЕРЕДЬ 3** | 50d | 2026-04-20 | 2026-06-08 |  | 0d |  |  | 2960.48h |
| 236 | 1.4.1 | **Ось 17-18** | 5d | 2026-04-20 | 2026-04-24 |  | 44d |  |  | 350.06h |
| 237 | 1.4.1.1 | **Колонны** | 1d | 2026-04-20 | 2026-04-20 |  | 49d |  |  |  |
| 238 | 1.4.1.1.1 | Монтаж колонн одноэтажных и многоэтажных зданий и крановых эстакад высотой: до 25 м составного сечения массой до 5,0 т | 1d | 2026-04-20 | 2026-04-20 | 226 | 49d | 0d | finish no earlier than 2026-01-08 |  |
| 239 | 1.4.1.2 | **Балки перекрытий и фермы ФП1** | 1d | 2026-04-20 | 2026-04-20 |  | 49d |  |  | 350.06h |
| 240 | 1.4.1.2.1 | Монтаж балок, ригелей перекрытия, покрытия и под установку оборудования многоэтажных зданий при высоте здания: до 25 м | 1d | 2026-04-20 | 2026-04-20 | 238SS | 49d | 0d | finish no earlier than 2025-08-28 | 350.06h |
| 241 | 1.4.1.3 | **Связи горизонт. и вертик.** | 1d | 2026-04-20 | 2026-04-20 |  | 44d |  |  |  |
| 242 | 1.4.1.3.1 | Монтаж связей и распорок из одиночных и парных уголков, гнутосварных профилей для пролетов: до 24 м при высоте здания до 25 м | 1d | 2026-04-20 | 2026-04-20 | 240SS | 44d | 0d | start no earlier than 2026-01-10 |  |
| 243 | 1.4.1.4 | **Установка С-элемента** | 2d | 2026-04-21 | 2026-04-22 |  | 44d |  |  |  |
| 244 | 1.4.1.4.1 | Монтаж балок, ригелей перекрытия, покрытия и под установку оборудования многоэтажных зданий при высоте здания: до 25 м | 2d | 2026-04-21 | 2026-04-22 | 242 | 44d | 0d | finish no earlier than 2026-01-11 |  |

| ID | WBS | Task | Duration | Start | Finish | Predecessors | Total slack | Free slack | Constraint | Work |
| --- | --- | --- | --- | --- | --- | --- | --- | --- | --- | --- |
| 245 | 1.4.1.5 | **Прогоны покрытия** | 2d | 2026-04-23 | 2026-04-24 |  | 44d |  |  |  |
| 246 | 1.4.1.5.1 | Монтаж балок, ригелей перекрытия, покрытия и под установку оборудования многоэтажных зданий при высоте здания: до 25 м | 2d | 2026-04-23 | 2026-04-24 | 244 | 44d | 0d | finish no earlier than 2026-01-12 |  |
| 247 | 1.4.1.6 | **Стеновой фахверк** | 2d | 2026-04-21 | 2026-04-22 |  | 47d |  |  |  |
| 248 | 1.4.1.6.1 | Монтаж фахверка | 2d | 2026-04-21 | 2026-04-22 | 244SS | 47d |  | start no earlier than 2026-01-09 |  |
| 249 | 1.4.2 | **Ось 18-19** | 5d | 2026-04-25 | 2026-04-29 |  | 39d |  |  | 350.06h |
| 250 | 1.4.2.1 | **Колонны** | 1d | 2026-04-25 | 2026-04-25 |  | 44d |  |  |  |
| 251 | 1.4.2.1.1 | Монтаж колонн одноэтажных и многоэтажных зданий и крановых эстакад высотой: до 25 м составного сечения массой до 5,0 т | 1d | 2026-04-25 | 2026-04-25 | 246 | 44d | 0d | finish no earlier than 2026-01-08 |  |
| 252 | 1.4.2.2 | **Балки перекрытий и фермы ФП1** | 1d | 2026-04-25 | 2026-04-25 |  | 44d |  |  | 350.06h |
| 253 | 1.4.2.2.1 | Монтаж балок, ригелей перекрытия, покрытия и под установку оборудования многоэтажных зданий при высоте здания: до 25 м | 1d | 2026-04-25 | 2026-04-25 | 251SS | 44d | 0d | finish no earlier than 2025-08-28 | 350.06h |
| 254 | 1.4.2.3 | **Связи горизонт. и вертик.** | 1d | 2026-04-25 | 2026-04-25 |  | 39d |  |  |  |
| 255 | 1.4.2.3.1 | Монтаж связей и распорок из одиночных и парных уголков, гнутосварных профилей для пролетов: до 24 м при высоте здания до 25 м | 1d | 2026-04-25 | 2026-04-25 | 253SS | 39d | 0d | start no earlier than 2026-01-10 |  |
| 256 | 1.4.2.4 | **Установка С-элемента** | 2d | 2026-04-26 | 2026-04-27 |  | 39d |  |  |  |
| 257 | 1.4.2.4.1 | Монтаж балок, ригелей перекрытия, покрытия и под установку оборудования многоэтажных зданий при высоте здания: до 25 м | 2d | 2026-04-26 | 2026-04-27 | 255 | 39d | 0d | finish no earlier than 2026-01-11 |  |
| 258 | 1.4.2.5 | **Прогоны покрытия** | 2d | 2026-04-28 | 2026-04-29 |  | 39d |  |  |  |
| 259 | 1.4.2.5.1 | Монтаж балок, ригелей перекрытия, покрытия и под установку оборудования многоэтажных зданий при высоте здания: до 25 м | 2d | 2026-04-28 | 2026-04-29 | 257 | 39d | 0d | finish no earlier than 2026-01-12 |  |
| 260 | 1.4.2.6 | **Стеновой фахверк** | 2d | 2026-04-26 | 2026-04-27 |  | 42d |  |  |  |
| 261 | 1.4.2.6.1 | Монтаж фахверка | 2d | 2026-04-26 | 2026-04-27 | 257SS | 42d |  | start no earlier than 2026-01-09 |  |
| 262 | 1.4.3 | **Ось 19-20** | 5d | 2026-04-30 | 2026-05-04 |  | 34d |  |  | 350.06h |
| 263 | 1.4.3.1 | **Колонны** | 1d | 2026-04-30 | 2026-04-30 |  | 39d |  |  |  |
| 264 | 1.4.3.1.1 | Монтаж колонн одноэтажных и многоэтажных зданий и крановых эстакад высотой: до 25 м составного сечения массой до 5,0 т | 1d | 2026-04-30 | 2026-04-30 | 259 | 39d | 0d | finish no earlier than 2026-01-08 |  |
| 265 | 1.4.3.2 | **Балки перекрытий и фермы ФП1** | 1d | 2026-04-30 | 2026-04-30 |  | 39d |  |  | 350.06h |
| 266 | 1.4.3.2.1 | Монтаж балок, ригелей перекрытия, покрытия и под установку оборудования многоэтажных зданий при высоте здания: до 25 м | 1d | 2026-04-30 | 2026-04-30 | 264SS | 39d | 0d | finish no earlier than 2025-08-28 | 350.06h |
| 267 | 1.4.3.3 | **Связи горизонт. и вертик.** | 1d | 2026-04-30 | 2026-04-30 |  | 34d |  |  |  |
| 268 | 1.4.3.3.1 | Монтаж связей и распорок из одиночных и парных уголков, гнутосварных профилей для пролетов: до 24 м при высоте здания до 25 м | 1d | 2026-04-30 | 2026-04-30 | 266SS | 34d | 0d | start no earlier than 2026-01-10 |  |

| ID | WBS | Task | Duration | Start | Finish | Predecessors | Total slack | Free slack | Constraint | Work |
| --- | --- | --- | --- | --- | --- | --- | --- | --- | --- | --- |
| 269 | 1.4.3.4 | **Установка С-элемента** | 2d | 2026-05-01 | 2026-05-02 |  | 34d |  |  |  |
| 270 | 1.4.3.4.1 | Монтаж балок, ригелей перекрытия, покрытия и под установку оборудования многоэтажных зданий при высоте здания: до 25 м | 2d | 2026-05-01 | 2026-05-02 | 268 | 34d | 0d | finish no earlier than 2026-01-11 |  |
| 271 | 1.4.3.5 | **Прогоны покрытия** | 2d | 2026-05-03 | 2026-05-04 |  | 34d |  |  |  |
| 272 | 1.4.3.5.1 | Монтаж балок, ригелей перекрытия, покрытия и под установку оборудования многоэтажных зданий при высоте здания: до 25 м | 2d | 2026-05-03 | 2026-05-04 | 270 | 34d | 0d | finish no earlier than 2026-01-12 |  |
| 273 | 1.4.3.6 | **Стеновой фахверк** | 2d | 2026-05-03 | 2026-05-04 |  | 35d |  |  |  |
| 274 | 1.4.3.6.1 | Монтаж фахверка | 2d | 2026-05-03 | 2026-05-04 | 272SS | 35d |  | start no earlier than 2026-01-09 |  |
| 275 | 1.4.4 | **Ось 20-21** | 5d | 2026-05-05 | 2026-05-09 |  | 29d |  |  | 350.06h |
| 276 | 1.4.4.1 | **Колонны** | 1d | 2026-05-05 | 2026-05-05 |  | 34d |  |  |  |
| 277 | 1.4.4.1.1 | Монтаж колонн одноэтажных и многоэтажных зданий и крановых эстакад высотой: до 25 м составного сечения массой до 5,0 т | 1d | 2026-05-05 | 2026-05-05 | 272 | 34d | 0d | finish no earlier than 2026-01-08 |  |
| 278 | 1.4.4.2 | **Балки перекрытий и фермы ФП1** | 1d | 2026-05-05 | 2026-05-05 |  | 34d |  |  | 350.06h |
| 279 | 1.4.4.2.1 | Монтаж балок, ригелей перекрытия, покрытия и под установку оборудования многоэтажных зданий при высоте здания: до 25 м | 1d | 2026-05-05 | 2026-05-05 | 277SS | 34d | 0d | finish no earlier than 2025-08-28 | 350.06h |
| 280 | 1.4.4.3 | **Связи горизонт. и вертик.** | 1d | 2026-05-05 | 2026-05-05 |  | 29d |  |  |  |
| 281 | 1.4.4.3.1 | Монтаж связей и распорок из одиночных и парных уголков, гнутосварных профилей для пролетов: до 24 м при высоте здания до 25 м | 1d | 2026-05-05 | 2026-05-05 | 279SS | 29d | 0d | start no earlier than 2026-01-10 |  |
| 282 | 1.4.4.4 | **Установка С-элемента** | 2d | 2026-05-06 | 2026-05-07 |  | 29d |  |  |  |
| 283 | 1.4.4.4.1 | Монтаж балок, ригелей перекрытия, покрытия и под установку оборудования многоэтажных зданий при высоте здания: до 25 м | 2d | 2026-05-06 | 2026-05-07 | 281 | 29d | 0d | finish no earlier than 2026-01-11 |  |
| 284 | 1.4.4.5 | **Прогоны покрытия** | 2d | 2026-05-08 | 2026-05-09 |  | 29d |  |  |  |
| 285 | 1.4.4.5.1 | Монтаж балок, ригелей перекрытия, покрытия и под установку оборудования многоэтажных зданий при высоте здания: до 25 м | 2d | 2026-05-08 | 2026-05-09 | 283 | 29d | 0d | finish no earlier than 2026-01-12 |  |
| 286 | 1.4.4.6 | **Стеновой фахверк** | 2d | 2026-05-06 | 2026-05-07 |  | 32d |  |  |  |
| 287 | 1.4.4.6.1 | Монтаж фахверка | 2d | 2026-05-06 | 2026-05-07 | 281 | 32d |  | start no earlier than 2026-01-09 |  |
| 288 | 1.4.5 | **Ось 21-22** | 5d | 2026-05-10 | 2026-05-14 |  | 3d |  |  | 350.06h |
| 289 | 1.4.5.1 | **Колонны** | 1d | 2026-05-10 | 2026-05-10 |  | 29d |  |  |  |
| 290 | 1.4.5.1.1 | Монтаж колонн одноэтажных и многоэтажных зданий и крановых эстакад высотой: до 25 м составного сечения массой до 5,0 т | 1d | 2026-05-10 | 2026-05-10 | 285 | 29d | 0d | finish no earlier than 2026-01-08 |  |
| 291 | 1.4.5.2 | **Балки перекрытий и фермы ФП1** | 1d | 2026-05-10 | 2026-05-10 |  | 29d |  |  | 350.06h |
| 292 | 1.4.5.2.1 | Монтаж балок, ригелей перекрытия, покрытия и под установку оборудования многоэтажных зданий при высоте здания: до 25 м | 1d | 2026-05-10 | 2026-05-10 | 290SS | 29d | 0d | finish no earlier than 2025-08-28 | 350.06h |

| ID | WBS | Task | Duration | Start | Finish | Predecessors | Total slack | Free slack | Constraint | Work |
| --- | --- | --- | --- | --- | --- | --- | --- | --- | --- | --- |
| 293 | 1.4.5.3 | **Связи горизонт. и вертик.** | 1d | 2026-05-10 | 2026-05-10 |  | 3d |  |  |  |
| 294 | 1.4.5.3.1 | Монтаж связей и распорок из одиночных и парных уголков, гнутосварных профилей для пролетов: до 24 м при высоте здания до 25 м | 1d | 2026-05-10 | 2026-05-10 | 292SS | 3d | 0d | start no earlier than 2026-01-10 |  |
| 295 | 1.4.5.4 | **Установка С-элемента** | 2d | 2026-05-11 | 2026-05-12 |  | 3d |  |  |  |
| 296 | 1.4.5.4.1 | Монтаж балок, ригелей перекрытия, покрытия и под установку оборудования многоэтажных зданий при высоте здания: до 25 м | 2d | 2026-05-11 | 2026-05-12 | 294 | 3d | 0d | finish no earlier than 2026-01-11 |  |
| 297 | 1.4.5.5 | **Прогоны покрытия** | 2d | 2026-05-13 | 2026-05-14 |  | 3d |  |  |  |
| 298 | 1.4.5.5.1 | Монтаж балок, ригелей перекрытия, покрытия и под установку оборудования многоэтажных зданий при высоте здания: до 25 м | 2d | 2026-05-13 | 2026-05-14 | 296 | 3d | 0d | finish no earlier than 2026-01-12 |  |
| 299 | 1.4.5.6 | **Стеновой фахверк** | 2d | 2026-05-13 | 2026-05-14 |  | 25d |  |  |  |
| 300 | 1.4.5.6.1 | Монтаж фахверка | 2d | 2026-05-13 | 2026-05-14 | 296 | 25d |  | start no earlier than 2026-01-09 |  |
| 301 | 1.4.6 | Монтаж площадок с настилом и ограждением из листовой, рифленой, просечной и круглой стали | 15d | 2026-05-15 | 2026-05-29 | 298 | 3d | 0d |  |  |
| 302 | 1.4.7 | **Ось 22-23** | 5d | 2026-05-15 | 2026-05-19 |  | 19d |  |  | 350.06h |
| 303 | 1.4.7.1 | **Колонны** | 1d | 2026-05-15 | 2026-05-15 |  | 24d |  |  |  |
| 304 | 1.4.7.1.1 | Монтаж колонн одноэтажных и многоэтажных зданий и крановых эстакад высотой: до 25 м составного сечения массой до 5,0 т | 1d | 2026-05-15 | 2026-05-15 | 298 | 24d | 0d | finish no earlier than 2026-01-08 |  |
| 305 | 1.4.7.2 | **Балки перекрытий и фермы ФП1** | 1d | 2026-05-15 | 2026-05-15 |  | 24d |  |  | 350.06h |
| 306 | 1.4.7.2.1 | Монтаж балок, ригелей перекрытия, покрытия и под установку оборудования многоэтажных зданий при высоте здания: до 25 м | 1d | 2026-05-15 | 2026-05-15 | 304SS | 24d | 0d | finish no earlier than 2025-08-28 | 350.06h |
| 307 | 1.4.7.3 | **Связи горизонт. и вертик.** | 1d | 2026-05-15 | 2026-05-15 |  | 19d |  |  |  |
| 308 | 1.4.7.3.1 | Монтаж связей и распорок из одиночных и парных уголков, гнутосварных профилей для пролетов: до 24 м при высоте здания до 25 м | 1d | 2026-05-15 | 2026-05-15 | 306SS | 19d | 0d | start no earlier than 2026-01-10 |  |
| 309 | 1.4.7.4 | **Установка С-элемента** | 2d | 2026-05-16 | 2026-05-17 |  | 19d |  |  |  |
| 310 | 1.4.7.4.1 | Монтаж балок, ригелей перекрытия, покрытия и под установку оборудования многоэтажных зданий при высоте здания: до 25 м | 2d | 2026-05-16 | 2026-05-17 | 308 | 19d | 0d | finish no earlier than 2026-01-11 |  |
| 311 | 1.4.7.5 | **Прогоны покрытия** | 2d | 2026-05-18 | 2026-05-19 |  | 19d |  |  |  |
| 312 | 1.4.7.5.1 | Монтаж балок, ригелей перекрытия, покрытия и под установку оборудования многоэтажных зданий при высоте здания: до 25 м | 2d | 2026-05-18 | 2026-05-19 | 310 | 19d | 0d | finish no earlier than 2026-01-12 |  |
| 313 | 1.4.7.6 | **Стеновой фахверк** | 2d | 2026-05-18 | 2026-05-19 |  | 20d |  |  |  |
| 314 | 1.4.7.6.1 | Монтаж фахверка | 2d | 2026-05-18 | 2026-05-19 | 312SS | 20d |  | start no earlier than 2026-01-09 |  |
| 315 | 1.4.8 | **Ось 23-24** | 5d | 2026-05-20 | 2026-05-24 |  | 15d |  |  | 350.06h |
| 316 | 1.4.8.1 | **Колонны** | 1d | 2026-05-20 | 2026-05-20 |  | 19d |  |  |  |
| 317 | 1.4.8.1.1 | Монтаж колонн одноэтажных и многоэтажных зданий и крановых эстакад высотой: до 25 м составного сечения массой до 5,0 т | 1d | 2026-05-20 | 2026-05-20 | 312 | 19d | 0d | finish no earlier than 2026-01-08 |  |

| ID | WBS | Task | Duration | Start | Finish | Predecessors | Total slack | Free slack | Constraint | Work |
| --- | --- | --- | --- | --- | --- | --- | --- | --- | --- | --- |
| 318 | 1.4.8.2 | **Балки перекрытий и фермы ФП1** | 1d | 2026-05-20 | 2026-05-20 |  | 19d |  |  | 350.06h |
| 319 | 1.4.8.2.1 | Монтаж балок, ригелей перекрытия, покрытия и под установку оборудования многоэтажных зданий при высоте здания: до 25 м | 1d | 2026-05-20 | 2026-05-20 | 317SS | 19d | 0d | finish no earlier than 2025-08-28 | 350.06h |
| 320 | 1.4.8.3 | **Связи горизонт. и вертик.** | 1d | 2026-05-20 | 2026-05-20 |  | 15d |  |  |  |
| 321 | 1.4.8.3.1 | Монтаж связей и распорок из одиночных и парных уголков, гнутосварных профилей для пролетов: до 24 м при высоте здания до 25 м | 1d | 2026-05-20 | 2026-05-20 | 319SS | 15d | 0d | start no earlier than 2026-01-10 |  |
| 322 | 1.4.8.4 | **Установка С-элемента** | 2d | 2026-05-21 | 2026-05-22 |  | 15d |  |  |  |
| 323 | 1.4.8.4.1 | Монтаж балок, ригелей перекрытия, покрытия и под установку оборудования многоэтажных зданий при высоте здания: до 25 м | 2d | 2026-05-21 | 2026-05-22 | 321 | 15d | 0d | finish no earlier than 2026-01-11 |  |
| 324 | 1.4.8.5 | **Прогоны покрытия** | 2d | 2026-05-23 | 2026-05-24 |  | 15d |  |  |  |
| 325 | 1.4.8.5.1 | Монтаж балок, ригелей перекрытия, покрытия и под установку оборудования многоэтажных зданий при высоте здания: до 25 м | 2d | 2026-05-23 | 2026-05-24 | 323 | 15d | 0d | finish no earlier than 2026-01-12 |  |
| 326 | 1.4.8.6 | **Стеновой фахверк** | 2d | 2026-05-23 | 2026-05-24 |  | 15d |  |  |  |
| 327 | 1.4.8.6.1 | Монтаж фахверка | 2d | 2026-05-23 | 2026-05-24 | 325SS | 15d |  | start no earlier than 2026-01-09 |  |
| 328 | 1.4.9 | **Ось 24-25** | 5d | 2026-05-20 | 2026-05-24 |  | 0d |  |  | 350.06h |
| 329 | 1.4.9.1 | **Колонны** | 1d | 2026-05-20 | 2026-05-20 |  | 19d |  |  |  |
| 330 | 1.4.9.1.1 | Монтаж колонн одноэтажных и многоэтажных зданий и крановых эстакад высотой: до 25 м составного сечения массой до 5,0 т | 1d | 2026-05-20 | 2026-05-20 | 312 | 19d | 0d | finish no earlier than 2026-01-08 |  |
| 331 | 1.4.9.2 | **Балки перекрытий и фермы ФП1** | 1d | 2026-05-20 | 2026-05-20 |  | 19d |  |  | 350.06h |
| 332 | 1.4.9.2.1 | Монтаж балок, ригелей перекрытия, покрытия и под установку оборудования многоэтажных зданий при высоте здания: до 25 м | 1d | 2026-05-20 | 2026-05-20 | 330SS | 19d | 0d | finish no earlier than 2025-08-28 | 350.06h |
| 333 | 1.4.9.3 | **Связи горизонт. и вертик.** | 1d | 2026-05-20 | 2026-05-20 |  | 0d |  |  |  |
| 334 | 1.4.9.3.1 | Монтаж связей и распорок из одиночных и парных уголков, гнутосварных профилей для пролетов: до 24 м при высоте здания до 25 м | 1d | 2026-05-20 | 2026-05-20 | 332SS | 0d |  | start no earlier than 2026-01-10 |  |
| 335 | 1.4.9.4 | **Установка С-элемента** | 2d | 2026-05-21 | 2026-05-22 |  | 0d |  |  |  |
| 336 | 1.4.9.4.1 | Монтаж балок, ригелей перекрытия, покрытия и под установку оборудования многоэтажных зданий при высоте здания: до 25 м | 2d | 2026-05-21 | 2026-05-22 | 334 | 0d |  | finish no earlier than 2026-01-11 |  |
| 337 | 1.4.9.5 | **Прогоны покрытия** | 2d | 2026-05-23 | 2026-05-24 |  | 0d |  |  |  |
| 338 | 1.4.9.5.1 | Монтаж балок, ригелей перекрытия, покрытия и под установку оборудования многоэтажных зданий при высоте здания: до 25 м | 2d | 2026-05-23 | 2026-05-24 | 336 | 0d |  | finish no earlier than 2026-01-12 |  |
| 339 | 1.4.9.6 | **Стеновой фахверк** | 2d | 2026-05-23 | 2026-05-24 |  | 0d |  |  |  |
| 340 | 1.4.9.6.1 | Монтаж фахверка | 2d | 2026-05-23 | 2026-05-24 | 338SS | 0d |  | start no earlier than 2026-01-09 |  |
| 341 | 1.4.10 | **Профлист** | 15d | 2026-05-25 | 2026-06-08 |  | 0d |  |  | 160h |
| 342 | 1.4.10.1 | Монтаж кровельного покрытия: из профилированного листа при высоте здания до 25 м | 15d | 2026-05-25 | 2026-06-08 | 338 | 0d |  | start no earlier than 2025-08-27 | 80h |
| 343 | 1.4.10.2 | Монтаж ограждающих конструкций стен: из профилированного листа при высоте здания до 30 м (10% на подрезку) | 15d | 2026-05-25 | 2026-06-08 | 340 | 0d |  | start no earlier than 2026-01-09 | 80h |
| 344 | 1.4.10.3 | Монтаж лестниц | 7d | 2026-05-30 | 2026-06-05 | 301 | 3d |  |  |  |

| ID | WBS | Task | Duration | Start | Finish | Predecessors | Total slack | Free slack | Constraint | Work |
| --- | --- | --- | --- | --- | --- | --- | --- | --- | --- | --- |
| 345 | 1.4.11 | **Опоры под оборудование ЗД1-ЗД3** | 7d | 2026-05-30 | 2026-06-05 |  | 3d |  |  |  |
| 346 | 1.4.11.1 | Монтаж металлоконструкций постаментов под технологическое оборудование | 7d | 2026-05-30 | 2026-06-05 | 301 | 3d |  | start no earlier than 2025-09-01 |  |
| 347 | 1.5 | **ОЧЕРЕДЬ 5** | 50d | 2026-03-09 | 2026-04-27 |  | 42d |  |  | 2610.42h |
| 348 | 1.5.1 | **Ось 40-41** | 5d | 2026-03-09 | 2026-03-13 |  | 86d |  |  | 350.06h |
| 349 | 1.5.1.1 | **Колонны** | 1d | 2026-03-09 | 2026-03-09 |  | 91d |  |  |  |
| 350 | 1.5.1.1.1 | Монтаж колонн одноэтажных и многоэтажных зданий и крановых эстакад высотой: до 25 м составного сечения массой до 5,0 т | 1d | 2026-03-09 | 2026-03-09 | 2SS+9d | 91d | 0d | finish no earlier than 2026-01-08 |  |
| 351 | 1.5.1.2 | **Балки перекрытий и фермы ФП1** | 1d | 2026-03-09 | 2026-03-09 |  | 91d |  |  | 350.06h |
| 352 | 1.5.1.2.1 | Монтаж балок, ригелей перекрытия, покрытия и под установку оборудования многоэтажных зданий при высоте здания: до 25 м | 1d | 2026-03-09 | 2026-03-09 | 350SS | 91d | 0d | finish no earlier than 2025-08-28 | 350.06h |
| 353 | 1.5.1.3 | **Связи горизонт. и вертик.** | 1d | 2026-03-09 | 2026-03-09 |  | 86d |  |  |  |
| 354 | 1.5.1.3.1 | Монтаж связей и распорок из одиночных и парных уголков, гнутосварных профилей для пролетов: до 24 м при высоте здания до 25 м | 1d | 2026-03-09 | 2026-03-09 | 352SS | 86d | 0d | start no earlier than 2026-01-10 |  |
| 355 | 1.5.1.4 | **Установка С-элемента** | 2d | 2026-03-10 | 2026-03-11 |  | 86d |  |  |  |
| 356 | 1.5.1.4.1 | Монтаж балок, ригелей перекрытия, покрытия и под установку оборудования многоэтажных зданий при высоте здания: до 25 м | 2d | 2026-03-10 | 2026-03-11 | 354 | 86d | 0d | finish no earlier than 2026-01-11 |  |
| 357 | 1.5.1.5 | **Прогоны покрытия** | 2d | 2026-03-12 | 2026-03-13 |  | 86d |  |  |  |
| 358 | 1.5.1.5.1 | Монтаж балок, ригелей перекрытия, покрытия и под установку оборудования многоэтажных зданий при высоте здания: до 25 м | 2d | 2026-03-12 | 2026-03-13 | 356 | 86d | 0d | finish no earlier than 2026-01-12 |  |
| 359 | 1.5.1.6 | **Стеновой фахверк** | 2d | 2026-03-12 | 2026-03-13 |  | 87d |  |  |  |
| 360 | 1.5.1.6.1 | Монтаж фахверка | 2d | 2026-03-12 | 2026-03-13 | 356 | 87d |  | start no earlier than 2026-01-09 |  |
| 361 | 1.5.2 | **Ось 39-40** | 5d | 2026-03-14 | 2026-03-18 |  | 81d |  |  | 350.06h |
| 362 | 1.5.2.1 | **Колонны** | 1d | 2026-03-14 | 2026-03-14 |  | 86d |  |  |  |
| 363 | 1.5.2.1.1 | Монтаж колонн одноэтажных и многоэтажных зданий и крановых эстакад высотой: до 25 м составного сечения массой до 5,0 т | 1d | 2026-03-14 | 2026-03-14 | 358 | 86d | 0d | finish no earlier than 2026-01-08 |  |
| 364 | 1.5.2.2 | **Балки перекрытий и фермы ФП1** | 1d | 2026-03-14 | 2026-03-14 |  | 86d |  |  | 350.06h |
| 365 | 1.5.2.2.1 | Монтаж балок, ригелей перекрытия, покрытия и под установку оборудования многоэтажных зданий при высоте здания: до 25 м | 1d | 2026-03-14 | 2026-03-14 | 363SS | 86d | 0d | finish no earlier than 2025-08-28 | 350.06h |
| 366 | 1.5.2.3 | **Связи горизонт. и вертик.** | 1d | 2026-03-14 | 2026-03-14 |  | 81d |  |  |  |
| 367 | 1.5.2.3.1 | Монтаж связей и распорок из одиночных и парных уголков, гнутосварных профилей для пролетов: до 24 м при высоте здания до 25 м | 1d | 2026-03-14 | 2026-03-14 | 365SS | 81d | 0d | start no earlier than 2026-01-10 |  |
| 368 | 1.5.2.4 | **Установка С-элемента** | 2d | 2026-03-15 | 2026-03-16 |  | 81d |  |  |  |
| 369 | 1.5.2.4.1 | Монтаж балок, ригелей перекрытия, покрытия и под установку оборудования многоэтажных зданий при высоте здания: до 25 м | 2d | 2026-03-15 | 2026-03-16 | 367 | 81d | 0d | finish no earlier than 2026-01-11 |  |

| ID | WBS | Task | Duration | Start | Finish | Predecessors | Total slack | Free slack | Constraint | Work |
| --- | --- | --- | --- | --- | --- | --- | --- | --- | --- | --- |
| 370 | 1.5.2.5 | **Прогоны покрытия** | 2d | 2026-03-17 | 2026-03-18 |  | 81d |  |  |  |
| 371 | 1.5.2.5.1 | Монтаж балок, ригелей перекрытия, покрытия и под установку оборудования многоэтажных зданий при высоте здания: до 25 м | 2d | 2026-03-17 | 2026-03-18 | 369 | 81d | 0d | finish no earlier than 2026-01-12 |  |
| 372 | 1.5.2.6 | **Стеновой фахверк** | 2d | 2026-03-17 | 2026-03-18 |  | 82d |  |  |  |
| 373 | 1.5.2.6.1 | Монтаж фахверка | 2d | 2026-03-17 | 2026-03-18 | 371SS | 82d |  | start no earlier than 2026-01-09 |  |
| 374 | 1.5.3 | **Ось 38-39** | 5d | 2026-03-19 | 2026-03-23 |  | 76d |  |  | 350.06h |
| 375 | 1.5.3.1 | **Колонны** | 1d | 2026-03-19 | 2026-03-19 |  | 81d |  |  |  |
| 376 | 1.5.3.1.1 | Монтаж колонн одноэтажных и многоэтажных зданий и крановых эстакад высотой: до 25 м составного сечения массой до 5,0 т | 1d | 2026-03-19 | 2026-03-19 | 371 | 81d | 0d | finish no earlier than 2026-01-08 |  |
| 377 | 1.5.3.2 | **Балки перекрытий и фермы ФП1** | 1d | 2026-03-19 | 2026-03-19 |  | 81d |  |  | 350.06h |
| 378 | 1.5.3.2.1 | Монтаж балок, ригелей перекрытия, покрытия и под установку оборудования многоэтажных зданий при высоте здания: до 25 м | 1d | 2026-03-19 | 2026-03-19 | 376SS | 81d | 0d | finish no earlier than 2025-08-28 | 350.06h |
| 379 | 1.5.3.3 | **Связи горизонт. и вертик.** | 1d | 2026-03-19 | 2026-03-19 |  | 76d |  |  |  |
| 380 | 1.5.3.3.1 | Монтаж связей и распорок из одиночных и парных уголков, гнутосварных профилей для пролетов: до 24 м при высоте здания до 25 м | 1d | 2026-03-19 | 2026-03-19 | 378SS | 76d | 0d | start no earlier than 2026-01-10 |  |
| 381 | 1.5.3.4 | **Установка С-элемента** | 2d | 2026-03-20 | 2026-03-21 |  | 76d |  |  |  |
| 382 | 1.5.3.4.1 | Монтаж балок, ригелей перекрытия, покрытия и под установку оборудования многоэтажных зданий при высоте здания: до 25 м | 2d | 2026-03-20 | 2026-03-21 | 380 | 76d | 0d | finish no earlier than 2026-01-11 |  |
| 383 | 1.5.3.5 | **Прогоны покрытия** | 2d | 2026-03-22 | 2026-03-23 |  | 76d |  |  |  |
| 384 | 1.5.3.5.1 | Монтаж балок, ригелей перекрытия, покрытия и под установку оборудования многоэтажных зданий при высоте здания: до 25 м | 2d | 2026-03-22 | 2026-03-23 | 382 | 76d | 0d | finish no earlier than 2026-01-12 |  |
| 385 | 1.5.3.6 | **Стеновой фахверк** | 2d | 2026-03-22 | 2026-03-23 |  | 77d |  |  |  |
| 386 | 1.5.3.6.1 | Монтаж фахверка | 2d | 2026-03-22 | 2026-03-23 | 384SS | 77d |  | start no earlier than 2026-01-09 |  |
| 387 | 1.5.4 | **Ось 37-38** | 5d | 2026-03-24 | 2026-03-28 |  | 71d |  |  | 350.06h |
| 388 | 1.5.4.1 | **Колонны** | 1d | 2026-03-24 | 2026-03-24 |  | 76d |  |  |  |
| 389 | 1.5.4.1.1 | Монтаж колонн одноэтажных и многоэтажных зданий и крановых эстакад высотой: до 25 м составного сечения массой до 5,0 т | 1d | 2026-03-24 | 2026-03-24 | 384 | 76d | 0d | finish no earlier than 2026-01-08 |  |
| 390 | 1.5.4.2 | **Балки перекрытий и фермы ФП1** | 1d | 2026-03-24 | 2026-03-24 |  | 76d |  |  | 350.06h |
| 391 | 1.5.4.2.1 | Монтаж балок, ригелей перекрытия, покрытия и под установку оборудования многоэтажных зданий при высоте здания: до 25 м | 1d | 2026-03-24 | 2026-03-24 | 389SS | 76d | 0d | finish no earlier than 2025-08-28 | 350.06h |
| 392 | 1.5.4.3 | **Связи горизонт. и вертик.** | 1d | 2026-03-24 | 2026-03-24 |  | 71d |  |  |  |
| 393 | 1.5.4.3.1 | Монтаж связей и распорок из одиночных и парных уголков, гнутосварных профилей для пролетов: до 24 м при высоте здания до 25 м | 1d | 2026-03-24 | 2026-03-24 | 391SS | 71d | 0d | start no earlier than 2026-01-10 |  |

| ID | WBS | Task | Duration | Start | Finish | Predecessors | Total slack | Free slack | Constraint | Work |
| --- | --- | --- | --- | --- | --- | --- | --- | --- | --- | --- |
| 394 | 1.5.4.4 | **Установка С-элемента** | 2d | 2026-03-25 | 2026-03-26 |  | 71d |  |  |  |
| 395 | 1.5.4.4.1 | Монтаж балок, ригелей перекрытия, покрытия и под установку оборудования многоэтажных зданий при высоте здания: до 25 м | 2d | 2026-03-25 | 2026-03-26 | 393 | 71d | 0d | finish no earlier than 2026-01-11 |  |
| 396 | 1.5.4.5 | **Прогоны покрытия** | 2d | 2026-03-27 | 2026-03-28 |  | 71d |  |  |  |
| 397 | 1.5.4.5.1 | Монтаж балок, ригелей перекрытия, покрытия и под установку оборудования многоэтажных зданий при высоте здания: до 25 м | 2d | 2026-03-27 | 2026-03-28 | 395 | 71d | 0d | finish no earlier than 2026-01-12 |  |
| 398 | 1.5.4.6 | **Стеновой фахверк** | 2d | 2026-03-27 | 2026-03-28 |  | 72d |  |  |  |
| 399 | 1.5.4.6.1 | Монтаж фахверка | 2d | 2026-03-27 | 2026-03-28 | 397SS | 72d |  | start no earlier than 2026-01-09 |  |
| 400 | 1.5.5 | **Ось 36-37** | 5d | 2026-03-29 | 2026-04-02 |  | 45d |  |  | 350.06h |
| 401 | 1.5.5.1 | **Колонны** | 1d | 2026-03-29 | 2026-03-29 |  | 71d |  |  |  |
| 402 | 1.5.5.1.1 | Монтаж колонн одноэтажных и многоэтажных зданий и крановых эстакад высотой: до 25 м составного сечения массой до 5,0 т | 1d | 2026-03-29 | 2026-03-29 | 397 | 71d | 0d | finish no earlier than 2026-01-08 |  |
| 403 | 1.5.5.2 | **Балки перекрытий и фермы ФП1** | 1d | 2026-03-29 | 2026-03-29 |  | 71d |  |  | 350.06h |
| 404 | 1.5.5.2.1 | Монтаж балок, ригелей перекрытия, покрытия и под установку оборудования многоэтажных зданий при высоте здания: до 25 м | 1d | 2026-03-29 | 2026-03-29 | 402SS | 71d | 0d | finish no earlier than 2025-08-28 | 350.06h |
| 405 | 1.5.5.3 | **Связи горизонт. и вертик.** | 1d | 2026-03-29 | 2026-03-29 |  | 45d |  |  |  |
| 406 | 1.5.5.3.1 | Монтаж связей и распорок из одиночных и парных уголков, гнутосварных профилей для пролетов: до 24 м при высоте здания до 25 м | 1d | 2026-03-29 | 2026-03-29 | 404SS | 45d | 0d | start no earlier than 2026-01-10 |  |
| 407 | 1.5.5.4 | **Установка С-элемента** | 2d | 2026-03-30 | 2026-03-31 |  | 45d |  |  |  |
| 408 | 1.5.5.4.1 | Монтаж балок, ригелей перекрытия, покрытия и под установку оборудования многоэтажных зданий при высоте здания: до 25 м | 2d | 2026-03-30 | 2026-03-31 | 406 | 45d | 0d | finish no earlier than 2026-01-11 |  |
| 409 | 1.5.5.5 | **Прогоны покрытия** | 2d | 2026-04-01 | 2026-04-02 |  | 45d |  |  |  |
| 410 | 1.5.5.5.1 | Монтаж балок, ригелей перекрытия, покрытия и под установку оборудования многоэтажных зданий при высоте здания: до 25 м | 2d | 2026-04-01 | 2026-04-02 | 408 | 45d | 0d | finish no earlier than 2026-01-12 |  |
| 411 | 1.5.5.6 | **Стеновой фахверк** | 2d | 2026-04-01 | 2026-04-02 |  | 67d |  |  |  |
| 412 | 1.5.5.6.1 | Монтаж фахверка | 2d | 2026-04-01 | 2026-04-02 | 410SS | 67d |  | start no earlier than 2026-01-09 |  |
| 413 | 1.5.6 | Монтаж площадок с настилом и ограждением из листовой, рифленой, просечной и круглой стали | 15d | 2026-04-03 | 2026-04-17 | 410 | 45d | 0d |  |  |
| 414 | 1.5.7 | **Ось 35-36** | 5d | 2026-04-03 | 2026-04-07 |  | 62d |  |  | 350.06h |
| 415 | 1.5.7.1 | **Колонны** | 1d | 2026-04-03 | 2026-04-03 |  | 66d |  |  |  |
| 416 | 1.5.7.1.1 | Монтаж колонн одноэтажных и многоэтажных зданий и крановых эстакад высотой: до 25 м составного сечения массой до 5,0 т | 1d | 2026-04-03 | 2026-04-03 | 410 | 66d | 0d | finish no earlier than 2026-01-08 |  |
| 417 | 1.5.7.2 | **Балки перекрытий и фермы ФП1** | 1d | 2026-04-03 | 2026-04-03 |  | 66d |  |  | 350.06h |
| 418 | 1.5.7.2.1 | Монтаж балок, ригелей перекрытия, покрытия и под установку оборудования многоэтажных зданий при высоте здания: до 25 м | 1d | 2026-04-03 | 2026-04-03 | 416SS | 66d | 0d | finish no earlier than 2025-08-28 | 350.06h |

| ID | WBS | Task | Duration | Start | Finish | Predecessors | Total slack | Free slack | Constraint | Work |
| --- | --- | --- | --- | --- | --- | --- | --- | --- | --- | --- |
| 419 | 1.5.7.3 | **Связи горизонт. и вертик.** | 1d | 2026-04-03 | 2026-04-03 |  | 62d |  |  |  |
| 420 | 1.5.7.3.1 | Монтаж связей и распорок из одиночных и парных уголков, гнутосварных профилей для пролетов: до 24 м при высоте здания до 25 м | 1d | 2026-04-03 | 2026-04-03 | 418SS | 62d | 0d | start no earlier than 2026-01-10 |  |
| 421 | 1.5.7.4 | **Установка С-элемента** | 2d | 2026-04-04 | 2026-04-05 |  | 62d |  |  |  |
| 422 | 1.5.7.4.1 | Монтаж балок, ригелей перекрытия, покрытия и под установку оборудования многоэтажных зданий при высоте здания: до 25 м | 2d | 2026-04-04 | 2026-04-05 | 420 | 62d | 0d | finish no earlier than 2026-01-11 |  |
| 423 | 1.5.7.5 | **Прогоны покрытия** | 2d | 2026-04-06 | 2026-04-07 |  | 62d |  |  |  |
| 424 | 1.5.7.5.1 | Монтаж балок, ригелей перекрытия, покрытия и под установку оборудования многоэтажных зданий при высоте здания: до 25 м | 2d | 2026-04-06 | 2026-04-07 | 422 | 62d | 0d | finish no earlier than 2026-01-12 |  |
| 425 | 1.5.7.6 | **Стеновой фахверк** | 2d | 2026-04-06 | 2026-04-07 |  | 61d | 0d |  |  |
| 426 | 1.5.7.6.1 | Монтаж фахверка | 2d | 2026-04-06 | 2026-04-07 | 424SS | 61d |  | start no earlier than 2026-01-09 |  |
| 427 | 1.5.8 | **Ось 33-35** | 5d | 2026-04-08 | 2026-04-12 |  | 42d |  |  | 350.06h |
| 428 | 1.5.8.1 | **Колонны** | 1d | 2026-04-08 | 2026-04-08 |  | 61d |  |  |  |
| 429 | 1.5.8.1.1 | Монтаж колонн одноэтажных и многоэтажных зданий и крановых эстакад высотой: до 25 м составного сечения массой до 5,0 т | 1d | 2026-04-08 | 2026-04-08 | 425 | 61d | 0d | finish no earlier than 2026-01-08 |  |
| 430 | 1.5.8.2 | **Балки перекрытий и фермы ФП1** | 1d | 2026-04-08 | 2026-04-08 |  | 61d |  |  | 350.06h |
| 431 | 1.5.8.2.1 | Монтаж балок, ригелей перекрытия, покрытия и под установку оборудования многоэтажных зданий при высоте здания: до 25 м | 1d | 2026-04-08 | 2026-04-08 | 429SS | 61d | 0d | finish no earlier than 2025-08-28 | 350.06h |
| 432 | 1.5.8.3 | **Связи горизонт. и вертик.** | 1d | 2026-04-08 | 2026-04-08 |  | 42d |  |  |  |
| 433 | 1.5.8.3.1 | Монтаж связей и распорок из одиночных и парных уголков, гнутосварных профилей для пролетов: до 24 м при высоте здания до 25 м | 1d | 2026-04-08 | 2026-04-08 | 431SS | 42d | 0d | start no earlier than 2026-01-10 |  |
| 434 | 1.5.8.4 | **Установка С-элемента** | 2d | 2026-04-09 | 2026-04-10 |  | 42d |  |  |  |
| 435 | 1.5.8.4.1 | Монтаж балок, ригелей перекрытия, покрытия и под установку оборудования многоэтажных зданий при высоте здания: до 25 м | 2d | 2026-04-09 | 2026-04-10 | 433 | 42d | 0d | finish no earlier than 2026-01-11 |  |
| 436 | 1.5.8.5 | **Прогоны покрытия** | 2d | 2026-04-11 | 2026-04-12 |  | 42d |  |  |  |
| 437 | 1.5.8.5.1 | Монтаж балок, ригелей перекрытия, покрытия и под установку оборудования многоэтажных зданий при высоте здания: до 25 м | 2d | 2026-04-11 | 2026-04-12 | 435 | 42d | 0d | finish no earlier than 2026-01-12 |  |
| 438 | 1.5.8.6 | **Стеновой фахверк** | 2d | 2026-04-11 | 2026-04-12 |  | 42d |  |  |  |
| 439 | 1.5.8.6.1 | Монтаж фахверка | 2d | 2026-04-11 | 2026-04-12 | 437SS | 42d | 0d | start no earlier than 2026-01-09 |  |
| 440 | 1.5.9 | **Профлист** | 15d | 2026-04-13 | 2026-04-27 |  | 42d |  |  | 160h |
| 441 | 1.5.9.1 | Монтаж кровельного покрытия: из профилированного листа при высоте здания до 25 м | 15d | 2026-04-13 | 2026-04-27 | 437 | 42d |  | start no earlier than 2025-08-27 | 80h |
| 442 | 1.5.9.2 | Монтаж ограждающих конструкций стен: из профилированного листа при высоте здания до 30 м (10% на подрезку) | 15d | 2026-04-13 | 2026-04-27 | 439 | 42d |  | start no earlier than 2026-01-09 | 80h |
| 443 | 1.5.9.3 | Монтаж лестниц | 7d | 2026-04-18 | 2026-04-24 | 413 | 45d |  |  |  |

| ID | WBS | Task | Duration | Start | Finish | Predecessors | Total slack | Free slack | Constraint | Work |
| --- | --- | --- | --- | --- | --- | --- | --- | --- | --- | --- |
| 444 | 1.5.10 | **Опоры под оборудование ЗД1-ЗД3** | 7d | 2026-04-18 | 2026-04-24 |  | 45d |  |  |  |
| 445 | 1.5.10.1 | Монтаж металлоконструкций постаментов под технологическое оборудование | 7d | 2026-04-18 | 2026-04-24 | 413 | 45d |  | start no earlier than 2025-09-01 |  |
| 446 | 1.6 | **ОЧЕРЕДЬ 4** | 55d | 2026-04-11 | 2026-06-04 |  | 4d |  |  | 2960.48h |
| 447 | 1.6.1 | **Ось 32-33** | 5d | 2026-04-11 | 2026-04-15 |  | 53d |  |  | 350.06h |
| 448 | 1.6.1.1 | **Колонны** | 1d | 2026-04-11 | 2026-04-11 |  | 58d |  |  |  |
| 449 | 1.6.1.1.1 | Монтаж колонн одноэтажных и многоэтажных зданий и крановых эстакад высотой: до 25 м составного сечения массой до 5,0 т | 1d | 2026-04-11 | 2026-04-11 | 435 | 58d | 0d | finish no earlier than 2026-01-08 |  |
| 450 | 1.6.1.2 | **Балки перекрытий и фермы ФП1** | 1d | 2026-04-11 | 2026-04-11 |  | 58d |  |  | 350.06h |
| 451 | 1.6.1.2.1 | Монтаж балок, ригелей перекрытия, покрытия и под установку оборудования многоэтажных зданий при высоте здания: до 25 м | 1d | 2026-04-11 | 2026-04-11 | 449SS | 58d | 0d | finish no earlier than 2025-08-28 | 350.06h |
| 452 | 1.6.1.3 | **Связи горизонт. и вертик.** | 1d | 2026-04-11 | 2026-04-11 |  | 53d |  |  |  |
| 453 | 1.6.1.3.1 | Монтаж связей и распорок из одиночных и парных уголков, гнутосварных профилей для пролетов: до 24 м при высоте здания до 25 м | 1d | 2026-04-11 | 2026-04-11 | 451SS | 53d | 0d | start no earlier than 2026-01-10 |  |
| 454 | 1.6.1.4 | **Установка С-элемента** | 2d | 2026-04-12 | 2026-04-13 |  | 53d |  |  |  |
| 455 | 1.6.1.4.1 | Монтаж балок, ригелей перекрытия, покрытия и под установку оборудования многоэтажных зданий при высоте здания: до 25 м | 2d | 2026-04-12 | 2026-04-13 | 453 | 53d | 0d | finish no earlier than 2026-01-11 |  |
| 456 | 1.6.1.5 | **Прогоны покрытия** | 2d | 2026-04-14 | 2026-04-15 |  | 53d |  |  |  |
| 457 | 1.6.1.5.1 | Монтаж балок, ригелей перекрытия, покрытия и под установку оборудования многоэтажных зданий при высоте здания: до 25 м | 2d | 2026-04-14 | 2026-04-15 | 455 | 53d | 0d | finish no earlier than 2026-01-12 |  |
| 458 | 1.6.1.6 | **Стеновой фахверк** | 2d | 2026-04-14 | 2026-04-15 |  | 54d |  |  |  |
| 459 | 1.6.1.6.1 | Монтаж фахверка | 2d | 2026-04-14 | 2026-04-15 | 457SS | 54d |  | start no earlier than 2026-01-09 |  |
| 460 | 1.6.2 | **Ось 31-32** | 5d | 2026-04-16 | 2026-04-20 |  | 48d |  |  | 350.06h |
| 461 | 1.6.2.1 | **Колонны** | 1d | 2026-04-16 | 2026-04-16 |  | 53d |  |  |  |
| 462 | 1.6.2.1.1 | Монтаж колонн одноэтажных и многоэтажных зданий и крановых эстакад высотой: до 25 м составного сечения массой до 5,0 т | 1d | 2026-04-16 | 2026-04-16 | 457 | 53d | 0d | finish no earlier than 2026-01-08 |  |
| 463 | 1.6.2.2 | **Балки перекрытий и фермы ФП1** | 1d | 2026-04-16 | 2026-04-16 |  | 53d |  |  | 350.06h |
| 464 | 1.6.2.2.1 | Монтаж балок, ригелей перекрытия, покрытия и под установку оборудования многоэтажных зданий при высоте здания: до 25 м | 1d | 2026-04-16 | 2026-04-16 | 462SS | 53d | 0d | finish no earlier than 2025-08-28 | 350.06h |
| 465 | 1.6.2.3 | **Связи горизонт. и вертик.** | 1d | 2026-04-16 | 2026-04-16 |  | 48d |  |  |  |
| 466 | 1.6.2.3.1 | Монтаж связей и распорок из одиночных и парных уголков, гнутосварных профилей для пролетов: до 24 м при высоте здания до 25 м | 1d | 2026-04-16 | 2026-04-16 | 464SS | 48d | 0d | start no earlier than 2026-01-10 |  |
| 467 | 1.6.2.4 | **Установка С-элемента** | 2d | 2026-04-17 | 2026-04-18 |  | 48d |  |  |  |
| 468 | 1.6.2.4.1 | Монтаж балок, ригелей перекрытия, покрытия и под установку оборудования многоэтажных зданий при высоте здания: до 25 м | 2d | 2026-04-17 | 2026-04-18 | 466 | 48d | 0d | finish no earlier than 2026-01-11 |  |

| ID | WBS | Task | Duration | Start | Finish | Predecessors | Total slack | Free slack | Constraint | Work |
| --- | --- | --- | --- | --- | --- | --- | --- | --- | --- | --- |
| 469 | 1.6.2.5 | **Прогоны покрытия** | 2d | 2026-04-19 | 2026-04-20 |  | 48d |  |  |  |
| 470 | 1.6.2.5.1 | Монтаж балок, ригелей перекрытия, покрытия и под установку оборудования многоэтажных зданий при высоте здания: до 25 м | 2d | 2026-04-19 | 2026-04-20 | 468 | 48d | 0d | finish no earlier than 2026-01-12 |  |
| 471 | 1.6.2.6 | **Стеновой фахверк** | 2d | 2026-04-19 | 2026-04-20 |  | 49d |  |  |  |
| 472 | 1.6.2.6.1 | Монтаж фахверка | 2d | 2026-04-19 | 2026-04-20 | 468 | 49d |  | start no earlier than 2026-01-09 |  |
| 473 | 1.6.3 | **Ось 30-31** | 5d | 2026-04-21 | 2026-04-25 |  | 43d |  |  | 350.06h |
| 474 | 1.6.3.1 | **Колонны** | 1d | 2026-04-21 | 2026-04-21 |  | 48d |  |  |  |
| 475 | 1.6.3.1.1 | Монтаж колонн одноэтажных и многоэтажных зданий и крановых эстакад высотой: до 25 м составного сечения массой до 5,0 т | 1d | 2026-04-21 | 2026-04-21 | 470 | 48d | 0d | finish no earlier than 2026-01-08 |  |
| 476 | 1.6.3.2 | **Балки перекрытий и фермы ФП1** | 1d | 2026-04-21 | 2026-04-21 |  | 48d |  |  | 350.06h |
| 477 | 1.6.3.2.1 | Монтаж балок, ригелей перекрытия, покрытия и под установку оборудования многоэтажных зданий при высоте здания: до 25 м | 1d | 2026-04-21 | 2026-04-21 | 475SS | 48d | 0d | finish no earlier than 2025-08-28 | 350.06h |
| 478 | 1.6.3.3 | **Связи горизонт. и вертик.** | 1d | 2026-04-21 | 2026-04-21 |  | 43d |  |  |  |
| 479 | 1.6.3.3.1 | Монтаж связей и распорок из одиночных и парных уголков, гнутосварных профилей для пролетов: до 24 м при высоте здания до 25 м | 1d | 2026-04-21 | 2026-04-21 | 477SS | 43d | 0d | start no earlier than 2026-01-10 |  |
| 480 | 1.6.3.4 | **Установка С-элемента** | 2d | 2026-04-22 | 2026-04-23 |  | 43d |  |  |  |
| 481 | 1.6.3.4.1 | Монтаж балок, ригелей перекрытия, покрытия и под установку оборудования многоэтажных зданий при высоте здания: до 25 м | 2d | 2026-04-22 | 2026-04-23 | 479 | 43d | 0d | finish no earlier than 2026-01-11 |  |
| 482 | 1.6.3.5 | **Прогоны покрытия** | 2d | 2026-04-24 | 2026-04-25 |  | 43d |  |  |  |
| 483 | 1.6.3.5.1 | Монтаж балок, ригелей перекрытия, покрытия и под установку оборудования многоэтажных зданий при высоте здания: до 25 м | 2d | 2026-04-24 | 2026-04-25 | 481 | 43d | 0d | finish no earlier than 2026-01-12 |  |
| 484 | 1.6.3.6 | **Стеновой фахверк** | 2d | 2026-04-24 | 2026-04-25 |  | 44d |  |  |  |
| 485 | 1.6.3.6.1 | Монтаж фахверка | 2d | 2026-04-24 | 2026-04-25 | 481 | 44d |  | start no earlier than 2026-01-09 |  |
| 486 | 1.6.4 | **Ось 29-30** | 5d | 2026-04-26 | 2026-04-30 |  | 38d |  |  | 350.06h |
| 487 | 1.6.4.1 | **Колонны** | 1d | 2026-04-26 | 2026-04-26 |  | 43d |  |  |  |
| 488 | 1.6.4.1.1 | Монтаж колонн одноэтажных и многоэтажных зданий и крановых эстакад высотой: до 25 м составного сечения массой до 5,0 т | 1d | 2026-04-26 | 2026-04-26 | 483 | 43d | 0d | finish no earlier than 2026-01-08 |  |
| 489 | 1.6.4.2 | **Балки перекрытий и фермы ФП1** | 1d | 2026-04-26 | 2026-04-26 |  | 43d |  |  | 350.06h |
| 490 | 1.6.4.2.1 | Монтаж балок, ригелей перекрытия, покрытия и под установку оборудования многоэтажных зданий при высоте здания: до 25 м | 1d | 2026-04-26 | 2026-04-26 | 488SS | 43d | 0d | finish no earlier than 2025-08-28 | 350.06h |
| 491 | 1.6.4.3 | **Связи горизонт. и вертик.** | 1d | 2026-04-26 | 2026-04-26 |  | 38d |  |  |  |
| 492 | 1.6.4.3.1 | Монтаж связей и распорок из одиночных и парных уголков, гнутосварных профилей для пролетов: до 24 м при высоте здания до 25 м | 1d | 2026-04-26 | 2026-04-26 | 490SS | 38d | 0d | start no earlier than 2026-01-10 |  |

| ID | WBS | Task | Duration | Start | Finish | Predecessors | Total slack | Free slack | Constraint | Work |
| --- | --- | --- | --- | --- | --- | --- | --- | --- | --- | --- |
| 493 | 1.6.4.4 | **Установка С-элемента** | 2d | 2026-04-27 | 2026-04-28 |  | 38d |  |  |  |
| 494 | 1.6.4.4.1 | Монтаж балок, ригелей перекрытия, покрытия и под установку оборудования многоэтажных зданий при высоте здания: до 25 м | 2d | 2026-04-27 | 2026-04-28 | 492 | 38d | 0d | finish no earlier than 2026-01-11 |  |
| 495 | 1.6.4.5 | **Прогоны покрытия** | 2d | 2026-04-29 | 2026-04-30 |  | 38d |  |  |  |
| 496 | 1.6.4.5.1 | Монтаж балок, ригелей перекрытия, покрытия и под установку оборудования многоэтажных зданий при высоте здания: до 25 м | 2d | 2026-04-29 | 2026-04-30 | 494 | 38d | 0d | finish no earlier than 2026-01-12 |  |
| 497 | 1.6.4.6 | **Стеновой фахверк** | 2d | 2026-04-29 | 2026-04-30 |  | 39d |  |  |  |
| 498 | 1.6.4.6.1 | Монтаж фахверка | 2d | 2026-04-29 | 2026-04-30 | 496SS | 39d |  | start no earlier than 2026-01-09 |  |
| 499 | 1.6.5 | **Ось 28-29** | 5d | 2026-05-01 | 2026-05-05 |  | 7d |  |  | 350.06h |
| 500 | 1.6.5.1 | **Колонны** | 1d | 2026-05-01 | 2026-05-01 |  | 38d |  |  |  |
| 501 | 1.6.5.1.1 | Монтаж колонн одноэтажных и многоэтажных зданий и крановых эстакад высотой: до 25 м составного сечения массой до 5,0 т | 1d | 2026-05-01 | 2026-05-01 | 496 | 38d | 0d | finish no earlier than 2026-01-08 |  |
| 502 | 1.6.5.2 | **Балки перекрытий и фермы ФП1** | 1d | 2026-05-01 | 2026-05-01 |  | 38d |  |  | 350.06h |
| 503 | 1.6.5.2.1 | Монтаж балок, ригелей перекрытия, покрытия и под установку оборудования многоэтажных зданий при высоте здания: до 25 м | 1d | 2026-05-01 | 2026-05-01 | 501SS | 38d | 0d | finish no earlier than 2025-08-28 | 350.06h |
| 504 | 1.6.5.3 | **Связи горизонт. и вертик.** | 1d | 2026-05-01 | 2026-05-01 |  | 7d |  |  |  |
| 505 | 1.6.5.3.1 | Монтаж связей и распорок из одиночных и парных уголков, гнутосварных профилей для пролетов: до 24 м при высоте здания до 25 м | 1d | 2026-05-01 | 2026-05-01 | 503SS | 7d | 0d | start no earlier than 2026-01-10 |  |
| 506 | 1.6.5.4 | **Установка С-элемента** | 2d | 2026-05-02 | 2026-05-03 |  | 7d |  |  |  |
| 507 | 1.6.5.4.1 | Монтаж балок, ригелей перекрытия, покрытия и под установку оборудования многоэтажных зданий при высоте здания: до 25 м | 2d | 2026-05-02 | 2026-05-03 | 505 | 7d | 0d | finish no earlier than 2026-01-11 |  |
| 508 | 1.6.5.5 | **Прогоны покрытия** | 2d | 2026-05-04 | 2026-05-05 |  | 7d |  |  |  |
| 509 | 1.6.5.5.1 | Монтаж балок, ригелей перекрытия, покрытия и под установку оборудования многоэтажных зданий при высоте здания: до 25 м | 2d | 2026-05-04 | 2026-05-05 | 507 | 7d | 0d | finish no earlier than 2026-01-12 |  |
| 510 | 1.6.5.6 | **Стеновой фахверк** | 2d | 2026-05-04 | 2026-05-05 |  | 34d |  |  |  |
| 511 | 1.6.5.6.1 | Монтаж фахверка | 2d | 2026-05-04 | 2026-05-05 | 509SS | 34d |  | start no earlier than 2026-01-09 |  |
| 512 | 1.6.6 | Монтаж площадок с настилом и ограждением из листовой, рифленой, просечной и круглой стали | 20d | 2026-05-06 | 2026-05-25 | 509 | 7d | 0d |  |  |
| 513 | 1.6.7 | **Ось 27-28** | 5d | 2026-05-06 | 2026-05-10 |  | 28d |  |  | 350.06h |
| 514 | 1.6.7.1 | **Колонны** | 1d | 2026-05-06 | 2026-05-06 |  | 33d |  |  |  |
| 515 | 1.6.7.1.1 | Монтаж колонн одноэтажных и многоэтажных зданий и крановых эстакад высотой: до 25 м составного сечения массой до 5,0 т | 1d | 2026-05-06 | 2026-05-06 | 509 | 33d | 0d | finish no earlier than 2026-01-08 |  |
| 516 | 1.6.7.2 | **Балки перекрытий и фермы ФП1** | 1d | 2026-05-06 | 2026-05-06 |  | 33d |  |  | 350.06h |
| 517 | 1.6.7.2.1 | Монтаж балок, ригелей перекрытия, покрытия и под установку оборудования многоэтажных зданий при высоте здания: до 25 м | 1d | 2026-05-06 | 2026-05-06 | 515SS | 33d | 0d | finish no earlier than 2025-08-28 | 350.06h |

| ID | WBS | Task | Duration | Start | Finish | Predecessors | Total slack | Free slack | Constraint | Work |
| --- | --- | --- | --- | --- | --- | --- | --- | --- | --- | --- |
| 518 | 1.6.7.3 | **Связи горизонт. и вертик.** | 1d | 2026-05-06 | 2026-05-06 |  | 28d |  |  |  |
| 519 | 1.6.7.3.1 | Монтаж связей и распорок из одиночных и парных уголков, гнутосварных профилей для пролетов: до 24 м при высоте здания до 25 м | 1d | 2026-05-06 | 2026-05-06 | 517SS | 28d | 0d | start no earlier than 2026-01-10 |  |
| 520 | 1.6.7.4 | **Установка С-элемента** | 2d | 2026-05-07 | 2026-05-08 |  | 28d |  |  |  |
| 521 | 1.6.7.4.1 | Монтаж балок, ригелей перекрытия, покрытия и под установку оборудования многоэтажных зданий при высоте здания: до 25 м | 2d | 2026-05-07 | 2026-05-08 | 519 | 28d | 0d | finish no earlier than 2026-01-11 |  |
| 522 | 1.6.7.5 | **Прогоны покрытия** | 2d | 2026-05-09 | 2026-05-10 |  | 28d |  |  |  |
| 523 | 1.6.7.5.1 | Монтаж балок, ригелей перекрытия, покрытия и под установку оборудования многоэтажных зданий при высоте здания: до 25 м | 2d | 2026-05-09 | 2026-05-10 | 521 | 28d | 0d | finish no earlier than 2026-01-12 |  |
| 524 | 1.6.7.6 | **Стеновой фахверк** | 2d | 2026-05-09 | 2026-05-10 |  | 29d |  |  |  |
| 525 | 1.6.7.6.1 | Монтаж фахверка | 2d | 2026-05-09 | 2026-05-10 | 523SS | 29d |  | start no earlier than 2026-01-09 |  |
| 526 | 1.6.8 | **Ось 26-27** | 5d | 2026-05-11 | 2026-05-15 |  | 23d |  |  | 350.06h |
| 527 | 1.6.8.1 | **Колонны** | 1d | 2026-05-11 | 2026-05-11 |  | 28d |  |  |  |
| 528 | 1.6.8.1.1 | Монтаж колонн одноэтажных и многоэтажных зданий и крановых эстакад высотой: до 25 м составного сечения массой до 5,0 т | 1d | 2026-05-11 | 2026-05-11 | 523 | 28d | 0d | finish no earlier than 2026-01-08 |  |
| 529 | 1.6.8.2 | **Балки перекрытий и фермы ФП1** | 1d | 2026-05-11 | 2026-05-11 |  | 28d |  |  | 350.06h |
| 530 | 1.6.8.2.1 | Монтаж балок, ригелей перекрытия, покрытия и под установку оборудования многоэтажных зданий при высоте здания: до 25 м | 1d | 2026-05-11 | 2026-05-11 | 528SS | 28d | 0d | finish no earlier than 2025-08-28 | 350.06h |
| 531 | 1.6.8.3 | **Связи горизонт. и вертик.** | 1d | 2026-05-11 | 2026-05-11 |  | 23d |  |  |  |
| 532 | 1.6.8.3.1 | Монтаж связей и распорок из одиночных и парных уголков, гнутосварных профилей для пролетов: до 24 м при высоте здания до 25 м | 1d | 2026-05-11 | 2026-05-11 | 530SS | 23d | 0d | start no earlier than 2026-01-10 |  |
| 533 | 1.6.8.4 | **Установка С-элемента** | 2d | 2026-05-12 | 2026-05-13 |  | 23d |  |  |  |
| 534 | 1.6.8.4.1 | Монтаж балок, ригелей перекрытия, покрытия и под установку оборудования многоэтажных зданий при высоте здания: до 25 м | 2d | 2026-05-12 | 2026-05-13 | 532 | 23d | 0d | finish no earlier than 2026-01-11 |  |
| 535 | 1.6.8.5 | **Прогоны покрытия** | 2d | 2026-05-14 | 2026-05-15 |  | 23d |  |  |  |
| 536 | 1.6.8.5.1 | Монтаж балок, ригелей перекрытия, покрытия и под установку оборудования многоэтажных зданий при высоте здания: до 25 м | 2d | 2026-05-14 | 2026-05-15 | 534 | 23d | 0d | finish no earlier than 2026-01-12 |  |
| 537 | 1.6.8.6 | **Стеновой фахверк** | 2d | 2026-05-14 | 2026-05-15 |  | 24d |  |  |  |
| 538 | 1.6.8.6.1 | Монтаж фахверка | 2d | 2026-05-14 | 2026-05-15 | 534 | 24d |  | start no earlier than 2026-01-09 |  |
| 539 | 1.6.9 | **Ось 25-26** | 5d | 2026-05-16 | 2026-05-20 |  | 4d |  |  | 350.06h |
| 540 | 1.6.9.1 | **Колонны** | 1d | 2026-05-16 | 2026-05-16 |  | 23d |  |  |  |
| 541 | 1.6.9.1.1 | Монтаж колонн одноэтажных и многоэтажных зданий и крановых эстакад высотой: до 25 м составного сечения массой до 5,0 т | 1d | 2026-05-16 | 2026-05-16 | 536 | 23d | 0d | finish no earlier than 2026-01-08 |  |

| ID | WBS | Task | Duration | Start | Finish | Predecessors | Total slack | Free slack | Constraint | Work |
| --- | --- | --- | --- | --- | --- | --- | --- | --- | --- | --- |
| 542 | 1.6.9.2 | **Балки перекрытий и фермы ФП1** | 1d | 2026-05-16 | 2026-05-16 |  | 23d |  |  | 350.06h |
| 543 | 1.6.9.2.1 | Монтаж балок, ригелей перекрытия, покрытия и под установку оборудования многоэтажных зданий при высоте здания: до 25 м | 1d | 2026-05-16 | 2026-05-16 | 541SS | 23d | 0d | finish no earlier than 2025-08-28 | 350.06h |
| 544 | 1.6.9.3 | **Связи горизонт. и вертик.** | 1d | 2026-05-16 | 2026-05-16 |  | 4d |  |  |  |
| 545 | 1.6.9.3.1 | Монтаж связей и распорок из одиночных и парных уголков, гнутосварных профилей для пролетов: до 24 м при высоте здания до 25 м | 1d | 2026-05-16 | 2026-05-16 | 543SS | 4d | 0d | start no earlier than 2026-01-10 |  |
| 546 | 1.6.9.4 | **Установка С-элемента** | 2d | 2026-05-17 | 2026-05-18 |  | 4d |  |  |  |
| 547 | 1.6.9.4.1 | Монтаж балок, ригелей перекрытия, покрытия и под установку оборудования многоэтажных зданий при высоте здания: до 25 м | 2d | 2026-05-17 | 2026-05-18 | 545 | 4d | 0d | finish no earlier than 2026-01-11 |  |
| 548 | 1.6.9.5 | **Прогоны покрытия** | 2d | 2026-05-19 | 2026-05-20 |  | 4d |  |  |  |
| 549 | 1.6.9.5.1 | Монтаж балок, ригелей перекрытия, покрытия и под установку оборудования многоэтажных зданий при высоте здания: до 25 м | 2d | 2026-05-19 | 2026-05-20 | 547 | 4d | 0d | finish no earlier than 2026-01-12 |  |
| 550 | 1.6.9.6 | **Стеновой фахверк** | 2d | 2026-05-19 | 2026-05-20 |  | 4d |  |  |  |
| 551 | 1.6.9.6.1 | Монтаж фахверка | 2d | 2026-05-19 | 2026-05-20 | 547 | 4d | 0d | start no earlier than 2026-01-09 |  |
| 552 | 1.6.10 | **Настил** | 15d | 2026-05-21 | 2026-06-04 |  | 4d |  |  | 160h |
| 553 | 1.6.10.1 | Монтаж кровельного покрытия: из профилированного листа при высоте здания до 25 м | 15d | 2026-05-21 | 2026-06-04 | 549 | 4d |  | start no earlier than 2025-08-27 | 80h |
| 554 | 1.6.10.2 | Монтаж ограждающих конструкций стен: из профилированного листа при высоте здания до 30 м (10% на подрезку) | 15d | 2026-05-21 | 2026-06-04 | 551 | 4d |  | start no earlier than 2026-01-09 | 80h |
| 555 | 1.6.10.3 | Монтаж лестниц | 7d | 2026-05-26 | 2026-06-01 | 512 | 7d |  |  |  |
| 556 | 1.6.11 | **Опоры под оборудование ЗД1-ЗД3** | 7d | 2026-05-26 | 2026-06-01 |  | 7d |  |  |  |
| 557 | 1.6.11.1 | Монтаж металлоконструкций постаментов под технологическое оборудование | 7d | 2026-05-26 | 2026-06-01 | 512 | 7d |  | start no earlier than 2025-09-01 |  |
