# ГПР КГ3 15.02 ред.1

Schedule from MS Project, 2026-02-15 to 2026-05-18.

## Calendars

- Стандартный: Mon-Sun 09:00-13:00, 14:00-18:00.

## Schedule

| ID | WBS | Task | Type | Duration | Start | Finish | Predecessors | Total slack | Free slack | Constraint |
| --- | --- | --- | --- | --- | --- | --- | --- | --- | --- | --- |
| 1 | 1 | **Конвейерная галерея №3** |  | 93d | 2026-02-15 | 2026-05-18 |  | 0d |  |  |
| 2 | 1.1 | **Поставка металлоконструкций ВЗМК** |  | 41d | 2026-02-15 | 2026-03-27 |  | 15d |  |  |
| 3 | 1.1.1 | Поставка материалов 1-я очередь (1-9) |  | 2d | 2026-02-15 | 2026-02-16 |  | 86d |  | start no earlier than 2026-02-15 |
| 4 | 1.1.2 | Поставка материалов 2-я очередь (10-25) |  | 17d | 2026-02-15 | 2026-03-03 |  | 71d |  |  |
| 5 | 1.1.3 | Поставка материалов 3-я очередь (26-33) |  | 32d | 2026-02-15 | 2026-03-18 |  | 20d | 18d | start no earlier than 2026-02-15 |
| 6 | 1.1.4 | Поставка материалов 4-я очередь (34-41) |  | 41d | 2026-02-15 | 2026-03-27 |  | 15d |  | start no earlier than 2026-02-15 |
| 7 | 1.2 | **Мобилизация** |  | 11d | 2026-02-17 | 2026-02-27 |  | 7d |  |  |
| 8 | 1.2.1 | Выход второго звена на монтаж | milestone | 0d | 2026-02-27 | 2026-02-27 | 26 | 75d |  |  |
| 9 | 1.2.2 | Выход догоночного звена | milestone | 0d | 2026-02-18 | 2026-02-18 |  | 69d | 0d | start no earlier than 2026-02-18 |
| 10 | 1.2.3 | Выход звена укрпупнительная сборка | milestone | 0d | 2026-02-17 | 2026-02-17 |  | 2d | 0d | start no earlier than 2026-02-17 |
| 11 | 1.3 | **Укрупнительная сборка** |  | 84d | 2026-02-17 | 2026-05-11 |  | 7d |  |  |
| 12 | 1.3.1 | Укрупнительная сборка 2-я захватка |  | 10d | 2026-02-17 | 2026-02-26 | 10 | 2d | 0d | start no earlier than 2026-02-17 |
| 13 | 1.3.2 | Укрупнительная сборка 3-я захватка |  | 20d | 2026-02-27 | 2026-03-18 | 12, 35SF | 7d | 0d |  |
| 14 | 1.3.3 | Укрупнительная сборка 4-я захватка |  | 30d | 2026-03-19 | 2026-04-17 | 13, 44SF | 7d | 0d |  |
| 15 | 1.3.4 | Укрупнительная сборка 5-я захватка |  | 24d | 2026-04-18 | 2026-05-11 | 14, 53SF | 7d |  |  |
| 16 | 1.4 | **Захватка №1** |  | 19d | 2026-02-15 | 2026-03-05 |  | 0d |  |  |
| 17 | 1.4.1 | Ось 1-2 |  | 4d | 2026-02-18 | 2026-02-21 | 9 | 69d | 0d |  |
| 18 | 1.4.2 | Ось 2-3 |  | 4d | 2026-02-22 | 2026-02-25 | 17 | 69d | 0d |  |
| 19 | 1.4.3 | Ось 3-4 |  | 4d | 2026-02-26 | 2026-03-01 | 18 | 69d | 0d |  |
| 20 | 1.4.4 | Ось 4-5 |  | 4d | 2026-03-02 | 2026-03-05 | 19 | 69d |  |  |
| 21 | 1.4.5 | Ось 5-6 (жесткий блок) |  | 4d | 2026-02-15 | 2026-02-18 |  | 0d |  |  |
| 22 | 1.4.6 | Ось 6-7 |  | 5d | 2026-02-19 | 2026-02-23 | 21 | 0d |  |  |
| 23 | 1.4.7 | Ось 7-8 |  | 5d | 2026-02-24 | 2026-02-28 | 22 | 0d |  |  |
| 24 | 1.4.8 | Ось 8-9 |  | 5d | 2026-03-01 | 2026-03-05 | 23 | 0d |  |  |

| ID | WBS | Task | Duration | Start | Finish | Predecessors | Total slack | Free slack | Constraint |
| --- | --- | --- | --- | --- | --- | --- | --- | --- | --- |
| 25 | 1.5 | **Захватка №2** | 37d | 2026-02-27 | 2026-04-04 |  | 7d |  |  |
| 26 | 1.5.1 | Ось 9-10 (переход) | 1d | 2026-02-27 | 2026-02-27 | 12 | 2d | 0d | start no earlier than 2026-02-23 |
| 27 | 1.5.2 | Ось 10-11 | 5d | 2026-02-28 | 2026-03-04 | 26 | 2d | 0d |  |
| 28 | 1.5.3 | Ось 11-12 | 5d | 2026-03-05 | 2026-03-09 | 27 | 2d | 0d |  |
| 29 | 1.5.4 | Ось 12-13 | 5d | 2026-03-10 | 2026-03-14 | 28 | 2d | 0d |  |
| 30 | 1.5.5 | Ось 13-14 (жесткий блок) | 6d | 2026-03-15 | 2026-03-20 | 29 | 2d | 0d |  |
| 31 | 1.5.6 | Ось 14-15 | 5d | 2026-03-21 | 2026-03-25 | 30 | 2d | 0d |  |
| 32 | 1.5.7 | Ось 15-16 | 5d | 2026-03-26 | 2026-03-30 | 31 | 2d | 0d |  |
| 33 | 1.5.8 | Ось 16-17 | 5d | 2026-03-31 | 2026-04-04 | 32 | 2d | 0d |  |
| 34 | 1.6 | **Захватка №3** | 37d | 2026-03-06 | 2026-04-11 |  | 0d |  |  |
| 35 | 1.6.1 | Ось 17-18 (переход) | 1d | 2026-03-06 | 2026-03-06 | 24 | 0d |  |  |
| 36 | 1.6.2 | Ось 18-19 | 5d | 2026-03-07 | 2026-03-11 | 35 | 0d |  |  |
| 37 | 1.6.3 | Ось 19-20 | 5d | 2026-03-12 | 2026-03-16 | 36 | 0d |  |  |
| 38 | 1.6.4 | Ось 20-21 | 5d | 2026-03-17 | 2026-03-21 | 37 | 0d |  |  |
| 39 | 1.6.5 | Ось 21-22 (жесткий блок) | 6d | 2026-03-22 | 2026-03-27 | 38 | 0d |  |  |
| 40 | 1.6.6 | Ось 22-23 | 5d | 2026-03-28 | 2026-04-01 | 39 | 0d |  |  |
| 41 | 1.6.7 | Ось 23-24 | 5d | 2026-04-02 | 2026-04-06 | 40 | 0d |  |  |
| 42 | 1.6.8 | Ось 24-25 | 5d | 2026-04-07 | 2026-04-11 | 41 | 0d |  |  |
| 43 | 1.7 | **Захватка №4** | 37d | 2026-04-05 | 2026-05-11 |  | 7d |  |  |
| 44 | 1.7.1 | Ось 25-26 (переход) | 1d | 2026-04-05 | 2026-04-05 | 33 | 2d | 0d |  |
| 45 | 1.7.2 | Ось 26-27 | 5d | 2026-04-06 | 2026-04-10 | 44, 5 | 2d | 0d |  |
| 46 | 1.7.3 | Ось 27-28 | 5d | 2026-04-11 | 2026-04-15 | 45 | 2d | 0d |  |
| 47 | 1.7.4 | Ось 28-29 | 5d | 2026-04-16 | 2026-04-20 | 46 | 2d | 0d |  |
| 48 | 1.7.5 | Ось 29-30 (жесткий блок) | 6d | 2026-04-21 | 2026-04-26 | 47 | 2d | 0d |  |
| 49 | 1.7.6 | Ось 30-31 | 5d | 2026-04-27 | 2026-05-01 | 48 | 2d | 0d |  |
| 50 | 1.7.7 | Ось 31-32 | 5d | 2026-05-02 | 2026-05-06 | 49 | 2d | 0d |  |
| 51 | 1.7.8 | Ось 32-33 | 5d | 2026-05-07 | 2026-05-11 | 50 | 2d |  |  |

| ID | WBS | Task | Duration | Start | Finish | Predecessors | Total slack |
| --- | --- | --- | --- | --- | --- | --- | --- |
| 52 | 1.8 | **Захватка №5** | 37d | 2026-04-12 | 2026-05-18 |  | 0d |
| 53 | 1.8.1 | Ось 33-34 (переход) | 1d | 2026-04-12 | 2026-04-12 | 42, 6 | 0d |
| 54 | 1.8.2 | Ось 34-35 | 5d | 2026-04-13 | 2026-04-17 | 53 | 0d |
| 55 | 1.8.3 | Ось 35-36 | 5d | 2026-04-18 | 2026-04-22 | 54 | 0d |
| 56 | 1.8.4 | Ось 36-37 | 5d | 2026-04-23 | 2026-04-27 | 55 | 0d |
| 57 | 1.8.5 | Ось 37-38 (жесткий блок) | 6d | 2026-04-28 | 2026-05-03 | 56 | 0d |
| 58 | 1.8.6 | Ось 38-39 | 5d | 2026-05-04 | 2026-05-08 | 57 | 0d |
| 59 | 1.8.7 | Ось 39-40 | 5d | 2026-05-09 | 2026-05-13 | 58 | 0d |
| 60 | 1.8.8 | Ось 40-41 | 5d | 2026-05-14 | 2026-05-18 | 59 | 0d |
