# ГПР КГ3 15.02

Schedule from MS Project, 2026-02-15 to 2026-05-13.

## Calendars

- Стандартный: Mon-Sun 09:00-13:00, 14:00-18:00.

## Schedule

| ID | WBS | Task | Type | Duration | Start | Finish | Predecessors | Total slack | Free slack | Constraint |
| --- | --- | --- | --- | --- | --- | --- | --- | --- | --- | --- |
| 1 | 1 | **Конвейерная галерея №3** |  | 88d | 2026-02-15 | 2026-05-13 |  | 0d |  |  |
| 2 | 1.1 | **Поставка металлоконструкций ВЗМК** |  | 41d | 2026-02-15 | 2026-03-27 |  | 15d |  |  |
| 3 | 1.1.1 | Поставка материалов 1-я очередь (1-9) |  | 2d | 2026-02-15 | 2026-02-16 |  | 86d |  | start no earlier than 2026-02-15 |
| 4 | 1.1.2 | Поставка материалов 2-я очередь (10-25) |  | 17d | 2026-02-15 | 2026-03-03 |  | 71d |  |  |
| 5 | 1.1.3 | Поставка материалов 3-я очередь (26-33) |  | 32d | 2026-02-15 | 2026-03-18 |  | 20d | 15d | start no earlier than 2026-02-15 |
| 6 | 1.1.4 | Поставка материалов 4-я очередь (34-41) |  | 41d | 2026-02-15 | 2026-03-27 |  | 15d |  | start no earlier than 2026-02-15 |
| 7 | 1.2 | **Мобилизация** |  | 8d | 2026-02-17 | 2026-02-24 |  | 5d |  |  |
| 8 | 1.2.1 | Выход второго звена на монтаж | milestone | 0d | 2026-02-24 | 2026-02-24 | 20 | 78d |  |  |
| 9 | 1.2.2 | Запуск укрупнительной сборки 2-я захватка |  | 7d | 2026-02-17 | 2026-02-23 |  | 5d | 0d | start no earlier than 2026-02-17 |
| 10 | 1.3 | **Захватка №1** |  | 19d | 2026-02-15 | 2026-03-05 |  | 0d |  |  |
| 11 | 1.3.1 | Ось 1-2 |  | 10d | 2026-02-15 | 2026-02-24 |  | 78d |  |  |
| 12 | 1.3.2 | Ось 2-3 |  | 5d | 2026-02-15 | 2026-02-19 |  | 83d |  |  |
| 13 | 1.3.3 | Ось 3-4 |  | 5d | 2026-02-15 | 2026-02-19 |  | 83d |  |  |
| 14 | 1.3.4 | Ось 4-5 |  | 5d | 2026-02-15 | 2026-02-19 |  | 83d |  |  |
| 15 | 1.3.5 | Ось 5-6 (жесткий блок) |  | 4d | 2026-02-15 | 2026-02-18 |  | 0d |  |  |
| 16 | 1.3.6 | Ось 6-7 |  | 5d | 2026-02-19 | 2026-02-23 | 15 | 0d |  |  |
| 17 | 1.3.7 | Ось 7-8 |  | 5d | 2026-02-24 | 2026-02-28 | 16 | 0d |  |  |
| 18 | 1.3.8 | Ось 8-9 |  | 5d | 2026-03-01 | 2026-03-05 | 17 | 0d |  |  |
| 19 | 1.4 | **Захватка №2** |  | 37d | 2026-02-24 | 2026-04-01 |  | 5d |  |  |
| 20 | 1.4.1 | Ось 9-10 (переход) |  | 1d | 2026-02-24 | 2026-02-24 | 9 | 5d | 0d | start no earlier than 2026-02-23 |
| 21 | 1.4.2 | Ось 10-11 |  | 5d | 2026-02-25 | 2026-03-01 | 20 | 5d | 0d |  |
| 22 | 1.4.3 | Ось 11-12 |  | 5d | 2026-03-02 | 2026-03-06 | 21 | 5d | 0d |  |
| 23 | 1.4.4 | Ось 12-13 |  | 5d | 2026-03-07 | 2026-03-11 | 22 | 5d | 0d |  |
| 24 | 1.4.5 | Ось 13-14 (жесткий блок) |  | 6d | 2026-03-12 | 2026-03-17 | 23 | 5d | 0d |  |
| 25 | 1.4.6 | Ось 14-15 |  | 5d | 2026-03-18 | 2026-03-22 | 24 | 5d | 0d |  |
| 26 | 1.4.7 | Ось 15-16 |  | 5d | 2026-03-23 | 2026-03-27 | 25 | 5d | 0d |  |
| 27 | 1.4.8 | Ось 16-17 |  | 5d | 2026-03-28 | 2026-04-01 | 26 | 5d | 0d |  |

| ID | WBS | Task | Duration | Start | Finish | Predecessors | Total slack | Free slack |
| --- | --- | --- | --- | --- | --- | --- | --- | --- |
| 28 | 1.5 | **Захватка №3** | 37d | 2026-03-06 | 2026-04-11 |  | 0d |  |
| 29 | 1.5.1 | Ось 17-18 (переход) | 1d | 2026-03-06 | 2026-03-06 | 18 | 0d |  |
| 30 | 1.5.2 | Ось 18-19 | 5d | 2026-03-07 | 2026-03-11 | 29 | 0d |  |
| 31 | 1.5.3 | Ось 19-20 | 5d | 2026-03-12 | 2026-03-16 | 30 | 0d |  |
| 32 | 1.5.4 | Ось 20-21 | 5d | 2026-03-17 | 2026-03-21 | 31 | 0d |  |
| 33 | 1.5.5 | Ось 21-22 (жесткий блок) | 6d | 2026-03-22 | 2026-03-27 | 32 | 0d |  |
| 34 | 1.5.6 | Ось 22-23 | 5d | 2026-03-28 | 2026-04-01 | 33 | 0d |  |
| 35 | 1.5.7 | Ось 23-24 | 5d | 2026-04-02 | 2026-04-06 | 34 | 0d |  |
| 36 | 1.5.8 | Ось 24-25 | 5d | 2026-04-07 | 2026-04-11 | 35 | 0d |  |
| 37 | 1.6 | **Захватка №4** | 37d | 2026-04-02 | 2026-05-08 |  | 5d |  |
| 38 | 1.6.1 | Ось 25-26 (переход) | 1d | 2026-04-02 | 2026-04-02 | 27 | 5d | 0d |
| 39 | 1.6.2 | Ось 26-27 | 5d | 2026-04-03 | 2026-04-07 | 38, 5 | 5d | 0d |
| 40 | 1.6.3 | Ось 27-28 | 5d | 2026-04-08 | 2026-04-12 | 39 | 5d | 0d |
| 41 | 1.6.4 | Ось 28-29 | 5d | 2026-04-13 | 2026-04-17 | 40 | 5d | 0d |
| 42 | 1.6.5 | Ось 29-30 (жесткий блок) | 6d | 2026-04-18 | 2026-04-23 | 41 | 5d | 0d |
| 43 | 1.6.6 | Ось 30-31 | 5d | 2026-04-24 | 2026-04-28 | 42 | 5d | 0d |
| 44 | 1.6.7 | Ось 31-32 | 5d | 2026-04-29 | 2026-05-03 | 43 | 5d | 0d |
| 45 | 1.6.8 | Ось 32-33 | 5d | 2026-05-04 | 2026-05-08 | 44 | 5d |  |
| 46 | 1.7 | **Захватка №5** | 32d | 2026-04-12 | 2026-05-13 |  | 0d |  |
| 47 | 1.7.1 | Ось 33-34 (переход) | 1d | 2026-04-12 | 2026-04-12 | 36, 6 | 0d |  |
| 48 | 1.7.2 | Ось 34-35 | 5d | 2026-04-13 | 2026-04-17 | 47 | 0d |  |
| 49 | 1.7.3 | Ось 36-37 | 5d | 2026-04-18 | 2026-04-22 | 48 | 0d |  |
| 50 | 1.7.4 | Ось 37-38 (жесткий блок) | 6d | 2026-04-23 | 2026-04-28 | 49 | 0d |  |
| 51 | 1.7.5 | Ось 38-39 | 5d | 2026-04-29 | 2026-05-03 | 50 | 0d |  |
| 52 | 1.7.6 | Ось 39-40 | 5d | 2026-05-04 | 2026-05-08 | 51 | 0d |  |
| 53 | 1.7.7 | Ось 40-41 | 5d | 2026-05-09 | 2026-05-13 | 52 | 0d |  |
