# ГПР КГ3 16.03 ред.1

Schedule from MS Project, 2026-04-06 to 2026-06-06.

## Calendars

- Стандартный: Mon-Sun 09:00-13:00, 14:00-18:00.

## Schedule

| ID | WBS | Task | Type | Duration | Start | Finish | Predecessors | Total slack | Free slack | Constraint |
| --- | --- | --- | --- | --- | --- | --- | --- | --- | --- | --- |
| 1 | 1 | **Конвейерная галерея №3** |  | 62d | 2026-04-06 | 2026-06-06 |  | 0d |  |  |
| 2 | 1.1 | укрупнение колонн (2 сварщика, 2 слесаря) | manual | 1d? | 2026-04-06 | 2026-04-06 |  |  |  |  |
| 3 | 1.2 | выход нового звена и техники на лапшу и настилы | milestone | 0d | 2026-04-16 | 2026-04-16 |  | 1d | 0d | start no earlier than 2026-04-16 |
| 4 | 1.3 | **Укрупнительная сборка (7 сварщиков и 3 слесаря, кран 60т.)** |  | 15d | 2026-04-06 | 2026-04-20 |  | 28d |  |  |
| 5 | 1.3.1 | Ось 26 |  | 2d | 2026-04-06 | 2026-04-07 |  | 29d | 1d | start no earlier than 2026-04-06 |
| 6 | 1.3.2 | Ось 26,5 |  | 2d | 2026-04-06 | 2026-04-07 |  | 28d | 0d | start no earlier than 2026-04-06 |
| 7 | 1.3.3 | Ось 27 |  | 2d | 2026-04-07 | 2026-04-08 | 6FS-1d | 28d | 0d |  |
| 8 | 1.3.4 | Ось 27,5 |  | 2d | 2026-04-07 | 2026-04-08 | 7SS | 29d | 0d |  |
| 9 | 1.3.5 | Ось 28 |  | 2d | 2026-04-08 | 2026-04-09 | 8FS-1d | 29d | 0d |  |
| 10 | 1.3.6 | Ось 28,5 |  | 2d | 2026-04-08 | 2026-04-09 | 9SS | 30d | 0d |  |
| 11 | 1.3.7 | Ось 29 |  | 2d | 2026-04-09 | 2026-04-10 | 10FS-1d | 30d | 0d |  |
| 12 | 1.3.8 | Ось 29,5 |  | 2d | 2026-04-09 | 2026-04-10 | 11SS | 31d | 0d |  |
| 13 | 1.3.9 | Ось 30 |  | 2d | 2026-04-10 | 2026-04-11 | 12FS-1d | 31d | 0d |  |
| 14 | 1.3.10 | Ось 30,5 |  | 2d | 2026-04-10 | 2026-04-11 | 13SS | 33d | 0d |  |
| 15 | 1.3.11 | Ось 31 |  | 2d | 2026-04-11 | 2026-04-12 | 14FS-1d | 33d | 0d |  |
| 16 | 1.3.12 | Ось 31,5 |  | 2d | 2026-04-11 | 2026-04-12 | 15SS | 34d | 0d |  |
| 17 | 1.3.13 | Ось 32 |  | 2d | 2026-04-12 | 2026-04-13 | 16FS-1d | 34d | 0d |  |
| 18 | 1.3.14 | Ось 32,5 |  | 2d | 2026-04-12 | 2026-04-13 | 17SS | 35d | 0d |  |
| 19 | 1.3.15 | Ось 33 |  | 2d | 2026-04-13 | 2026-04-14 | 18FS-1d | 35d | 0d |  |
| 20 | 1.3.16 | Ось 34 |  | 2d | 2026-04-13 | 2026-04-14 | 19SS | 37d | 0d |  |
| 21 | 1.3.17 | Ось 34,5 |  | 2d | 2026-04-14 | 2026-04-15 | 20FS-1d | 37d | 0d |  |
| 22 | 1.3.18 | Ось 35 |  | 2d | 2026-04-14 | 2026-04-15 | 21SS | 37d | 0d |  |
| 23 | 1.3.19 | Ось 35,5 |  | 2d | 2026-04-15 | 2026-04-16 | 22FS-1d | 38d | 0d |  |
| 24 | 1.3.20 | Ось 36 |  | 2d | 2026-04-15 | 2026-04-16 | 23SS | 39d | 0d |  |
| 25 | 1.3.21 | Ось 36,5 |  | 2d | 2026-04-16 | 2026-04-17 | 24FS-1d | 39d | 0d |  |
| 26 | 1.3.22 | Ось 37 |  | 2d | 2026-04-16 | 2026-04-17 | 25SS | 40d | 0d |  |
| 27 | 1.3.23 | Ось 37,5 |  | 2d | 2026-04-17 | 2026-04-18 | 26FS-1d | 40d | 0d |  |
| 28 | 1.3.24 | Ось 38 |  | 2d | 2026-04-17 | 2026-04-18 | 27SS | 40d | 0d |  |
| 29 | 1.3.25 | Ось 38,5 |  | 2d | 2026-04-18 | 2026-04-19 | 28FS-1d | 42d | 0d |  |
| 30 | 1.3.26 | Ось 39 |  | 2d | 2026-04-18 | 2026-04-19 | 29SS | 42d | 0d |  |
| 31 | 1.3.27 | Ось 39,5 |  | 2d | 2026-04-19 | 2026-04-20 | 30FS-1d | 43d | 0d |  |
| 32 | 1.3.28 | Ось 40 |  | 2d | 2026-04-19 | 2026-04-20 | 31SS | 43d | 15d |  |

| ID | WBS | Task | Duration | Start | Finish | Predecessors | Total slack | Free slack | Constraint |
| --- | --- | --- | --- | --- | --- | --- | --- | --- | --- |
| 33 | 1.4 | **Захватка №1 11 человек (4 монтажника, 2 сварщика, 4 строполя, 1 ищет)** | 20d | 2026-04-08 | 2026-04-27 |  | 0d |  |  |
| 34 | 1.4.1 | Монтаж связей и прогонов | 20d | 2026-04-08 | 2026-04-27 |  | 26d | 0d | finish no earlier than 2026-04-27 |
| 35 | 1.4.2 | Монтаж настила | 8d | 2026-04-08 | 2026-04-15 | 34SS | 0d |  | finish no earlier than 2026-04-15 |
| 36 | 1.5 | **Захватка №2** | 20d | 2026-04-16 | 2026-05-05 |  | 0d |  |  |
| 37 | 1.5.1 | Монтаж связей и прогонов | 20d | 2026-04-16 | 2026-05-05 | 3 | 1d | 0d |  |
| 38 | 1.5.2 | Монтаж настила | 14d | 2026-04-16 | 2026-04-29 | 35 | 0d |  |  |
| 39 | 1.6 | **Захватка №3** | 23d | 2026-04-30 | 2026-05-22 |  | 0d |  |  |
| 40 | 1.6.1 | Монтаж связей и прогонов | 17d | 2026-05-06 | 2026-05-22 | 37 | 1d | 0d |  |
| 41 | 1.6.2 | Монтаж настила | 14d | 2026-04-30 | 2026-05-13 | 38 | 0d |  |  |
| 42 | 1.7 | **Захватка №4 (кран 60т. Гусянка, кран 30т., 2 подъемника, 4 монтажника, 2 строполя)** | 49d | 2026-04-09 | 2026-05-27 |  | 10d |  |  |
| 43 | 1.7.1 | Ось 26-27 | 2d | 2026-04-09 | 2026-04-10 | 5, 6, 7 | 28d | 0d |  |
| 44 | 1.7.2 | Ось 27-28 | 2d | 2026-04-11 | 2026-04-12 | 43, 8, 9 | 28d | 0d |  |
| 45 | 1.7.3 | Ось 28-29 | 2d | 2026-04-13 | 2026-04-14 | 44, 10, 11 | 28d | 0d |  |
| 46 | 1.7.4 | Ось 29-30 (жесткий блок) | 3d | 2026-04-15 | 2026-04-17 | 45, 11, 12, 13 | 28d | 0d |  |
| 47 | 1.7.5 | Ось 30-31 | 2d | 2026-04-18 | 2026-04-19 | 46, 14, 15 | 28d | 0d |  |
| 48 | 1.7.6 | Ось 31-32 | 2d | 2026-04-20 | 2026-04-21 | 47, 16, 17 | 28d | 0d |  |
| 49 | 1.7.7 | Ось 32-33 | 2d | 2026-04-22 | 2026-04-23 | 48, 18, 19 | 28d | 0d |  |
| 50 | 1.7.8 | Монтаж связей и прогонов | 14d | 2026-04-28 | 2026-05-11 | 34 | 26d |  |  |
| 51 | 1.7.9 | Монтаж настила | 14d | 2026-05-14 | 2026-05-27 | 41 | 0d |  |  |
| 52 | 1.8 | **Захватка №5** | 44d | 2026-04-24 | 2026-06-06 |  | 0d |  |  |
| 53 | 1.8.1 | Ось 33-34 (переход) | 1d | 2026-04-24 | 2026-04-24 | 49 | 28d | 0d |  |
| 54 | 1.8.2 | Ось 34-35 | 2d | 2026-04-25 | 2026-04-26 | 53, 20, 21, 22 | 28d | 0d |  |
| 55 | 1.8.3 | Ось 35-36 | 2d | 2026-04-27 | 2026-04-28 | 54, 22, 23 | 28d | 0d |  |
| 56 | 1.8.4 | Ось 36-37 | 2d | 2026-04-29 | 2026-04-30 | 55, 24, 25 | 28d | 0d |  |
| 57 | 1.8.5 | Ось 37-38 (жесткий блок) | 3d | 2026-05-01 | 2026-05-03 | 56, 26, 27, 28 | 28d | 0d |  |
| 58 | 1.8.6 | Ось 38-39 | 2d | 2026-05-04 | 2026-05-05 | 57, 29, 30 | 28d | 0d |  |
| 59 | 1.8.7 | Ось 39-40 | 2d | 2026-05-06 | 2026-05-07 | 58, 31, 32 | 28d | 0d |  |
| 60 | 1.8.8 | Ось 40-41 | 2d | 2026-05-08 | 2026-05-09 | 59 | 28d |  |  |
| 61 | 1.8.9 | Монтаж связей и прогонов | 14d | 2026-05-23 | 2026-06-05 | 40 | 1d |  |  |
| 62 | 1.8.10 | Монтаж настила | 10d | 2026-05-28 | 2026-06-06 | 51 | 0d |  |  |
