# ГПР КГ3 16.03

Schedule from MS Project, 2026-02-15 to 2026-05-30.

## Calendars

- Стандартный: Mon-Sun 09:00-13:00, 14:00-18:00.

## Schedule

| ID | WBS | Task | Type | Duration | Start | Finish | Predecessors | Total slack | Free slack | Constraint |
| --- | --- | --- | --- | --- | --- | --- | --- | --- | --- | --- |
| 1 | 1 | **Конвейерная галерея №3** |  | 105d | 2026-02-15 | 2026-05-30 |  | 0d |  |  |
| 2 | 1.1 | **Поставка металлоконструкций ВЗМК** |  | 41d | 2026-02-15 | 2026-03-27 |  | 42d |  |  |
| 3 | 1.1.1 | Поставка материалов 1-я очередь (1-9) |  | 2d | 2026-02-15 | 2026-02-16 |  | 103d |  | start no earlier than 2026-02-15 |
| 4 | 1.1.2 | Поставка материалов 2-я очередь (10-25) |  | 17d | 2026-02-15 | 2026-03-03 |  | 88d |  |  |
| 5 | 1.1.3 | Поставка материалов 3-я очередь (26-33) |  | 32d | 2026-02-15 | 2026-03-18 |  | 42d | 26d | start no earlier than 2026-02-15 |
| 6 | 1.1.4 | Поставка материалов 4-я очередь (34-41) |  | 41d | 2026-02-15 | 2026-03-27 |  | 64d |  | start no earlier than 2026-02-15 |
| 7 | 1.2 | **Мобилизация** |  | 10d | 2026-03-09 | 2026-03-19 |  | 7d |  |  |
| 8 | 1.2.1 | Выход догоночного звена №1 | milestone | 0d | 2026-03-09 | 2026-03-09 |  | 7d |  | start no earlier than 2026-03-09 |
| 9 | 1.2.2 | Выход догоночного звена №2 | milestone | 0d | 2026-03-13 | 2026-03-13 |  | 79d |  | start no earlier than 2026-03-13 |
| 10 | 1.2.3 | Выход дополнительного звена на укрупнительную сборку и организация третьего стапеля | milestone | 0d | 2026-03-19 | 2026-03-19 |  | 73d |  | start no earlier than 2026-03-19 |
| 11 | 1.3 | **Укрупнительная сборка** |  | 31d | 2026-03-16 | 2026-04-15 |  | 45d |  |  |
| 12 | 1.3.1 | Укрупнительная сборка 2-я захватка |  | 10d | 2026-03-16 | 2026-03-25 |  | 45d | 0d | start no earlier than 2026-03-16 |
| 13 | 1.3.2 | Укрупнительная сборка 3-я захватка |  | 7d | 2026-03-26 | 2026-04-01 | 12 | 45d | 0d |  |
| 14 | 1.3.3 | Укрупнительная сборка 4-я захватка |  | 7d | 2026-04-02 | 2026-04-08 | 13 | 45d | 0d |  |
| 15 | 1.3.4 | Укрупнительная сборка 5-я захватка |  | 7d | 2026-04-09 | 2026-04-15 | 14 | 45d |  |  |
| 16 | 1.4 | **Захватка №1** |  | 24d | 2026-03-16 | 2026-04-08 |  | 0d |  |  |
| 17 | 1.4.1 | Монтаж связей и прогонов |  | 10d | 2026-03-16 | 2026-03-25 | 8 | 0d |  | start no earlier than 2026-03-16 |
| 18 | 1.4.2 | Монтаж настила |  | 14d | 2026-03-26 | 2026-04-08 | 17 | 0d |  |  |
| 19 | 1.5 | **Захватка №2** |  | 38d | 2026-03-16 | 2026-04-22 |  | 0d |  |  |
| 20 | 1.5.1 | Ось 13-14 (жесткий блок) |  | 3d | 2026-03-16 | 2026-03-18 |  | 16d | 0d | start no earlier than 2026-03-16 |
| 21 | 1.5.2 | Ось 14-15 |  | 3d | 2026-03-19 | 2026-03-21 | 20 | 16d | 0d |  |
| 22 | 1.5.3 | Ось 15-16 |  | 3d | 2026-03-22 | 2026-03-24 | 21 | 16d | 0d |  |
| 23 | 1.5.4 | Ось 16-17 |  | 3d | 2026-03-25 | 2026-03-27 | 22 | 16d | 0d |  |
| 24 | 1.5.5 | Монтаж связей и прогонов |  | 14d | 2026-03-26 | 2026-04-08 | 17 | 14d | 0d |  |
| 25 | 1.5.6 | Монтаж настила |  | 14d | 2026-04-09 | 2026-04-22 | 18 | 0d |  |  |

| ID | WBS | Task | Duration | Start | Finish | Predecessors | Total slack | Free slack |
| --- | --- | --- | --- | --- | --- | --- | --- | --- |
| 26 | 1.6 | **Захватка №3** | 40d | 2026-03-28 | 2026-05-06 |  | 0d |  |
| 27 | 1.6.1 | Ось 17-18 (переход) | 1d | 2026-03-28 | 2026-03-28 | 23 | 16d | 0d |
| 28 | 1.6.2 | Ось 18-19 | 2d | 2026-03-29 | 2026-03-30 | 27 | 16d | 0d |
| 29 | 1.6.3 | Ось 19-20 | 2d | 2026-03-31 | 2026-04-01 | 28 | 16d | 0d |
| 30 | 1.6.4 | Ось 20-21 | 2d | 2026-04-02 | 2026-04-03 | 29 | 16d | 0d |
| 31 | 1.6.5 | Ось 21-22 (жесткий блок) | 3d | 2026-04-04 | 2026-04-06 | 30 | 16d | 0d |
| 32 | 1.6.6 | Ось 22-23 | 2d | 2026-04-07 | 2026-04-08 | 31 | 16d | 0d |
| 33 | 1.6.7 | Ось 23-24 | 2d | 2026-04-09 | 2026-04-10 | 32 | 16d | 0d |
| 34 | 1.6.8 | Ось 24-25 | 2d | 2026-04-11 | 2026-04-12 | 33 | 16d | 0d |
| 35 | 1.6.9 | Монтаж связей и прогонов | 12d | 2026-04-09 | 2026-04-20 | 24 | 14d | 0d |
| 36 | 1.6.10 | Монтаж настила | 14d | 2026-04-23 | 2026-05-06 | 25 | 0d |  |
| 37 | 1.7 | **Захватка №4** | 38d | 2026-04-13 | 2026-05-20 |  | 0d |  |
| 38 | 1.7.1 | Ось 25-26 (переход) | 1d | 2026-04-13 | 2026-04-13 | 34 | 16d | 0d |
| 39 | 1.7.2 | Ось 26-27 | 2d | 2026-04-14 | 2026-04-15 | 38, 5 | 16d | 0d |
| 40 | 1.7.3 | Ось 27-28 | 2d | 2026-04-16 | 2026-04-17 | 39 | 16d | 0d |
| 41 | 1.7.4 | Ось 28-29 | 2d | 2026-04-18 | 2026-04-19 | 40 | 16d | 0d |
| 42 | 1.7.5 | Ось 29-30 (жесткий блок) | 3d | 2026-04-20 | 2026-04-22 | 41 | 16d | 0d |
| 43 | 1.7.6 | Ось 30-31 | 2d | 2026-04-23 | 2026-04-24 | 42 | 16d | 0d |
| 44 | 1.7.7 | Ось 31-32 | 2d | 2026-04-25 | 2026-04-26 | 43 | 16d | 0d |
| 45 | 1.7.8 | Ось 32-33 | 2d | 2026-04-27 | 2026-04-28 | 44 | 16d | 0d |
| 46 | 1.7.9 | Монтаж связей и прогонов | 12d | 2026-04-21 | 2026-05-02 | 35 | 14d | 0d |
| 47 | 1.7.10 | Монтаж настила | 14d | 2026-05-07 | 2026-05-20 | 36 | 0d |  |
| 48 | 1.8 | **Захватка №5** | 32d | 2026-04-29 | 2026-05-30 |  | 0d |  |
| 49 | 1.8.1 | Ось 33-34 (переход) | 1d | 2026-04-29 | 2026-04-29 | 45 | 16d | 0d |
| 50 | 1.8.2 | Ось 34-35 | 2d | 2026-04-30 | 2026-05-01 | 49 | 16d | 0d |
| 51 | 1.8.3 | Ось 35-36 | 2d | 2026-05-02 | 2026-05-03 | 50 | 16d | 0d |
| 52 | 1.8.4 | Ось 36-37 | 2d | 2026-05-04 | 2026-05-05 | 51 | 16d | 0d |
| 53 | 1.8.5 | Ось 37-38 (жесткий блок) | 3d | 2026-05-06 | 2026-05-08 | 52 | 16d | 0d |
| 54 | 1.8.6 | Ось 38-39 | 2d | 2026-05-09 | 2026-05-10 | 53 | 16d | 0d |
| 55 | 1.8.7 | Ось 39-40 | 2d | 2026-05-11 | 2026-05-12 | 54 | 16d | 0d |
| 56 | 1.8.8 | Ось 40-41 | 2d | 2026-05-13 | 2026-05-14 | 55 | 16d |  |
| 57 | 1.8.9 | Монтаж связей и прогонов | 14d | 2026-05-03 | 2026-05-16 | 46 | 14d |  |
| 58 | 1.8.10 | Монтаж настила | 10d | 2026-05-21 | 2026-05-30 | 47 | 0d |  |
